# Outline ELEXON Plan_kc

How a schedule from MS Project changed from version to version. A marks actual dates.

## Version 21 (data date 2026-02-11, saved 2026-02-11, file MHHS-DEL1139 - MHHS Plan v6.43.mpp)

| ID | WBS | Task | Duration | Start | Finish | Predecessors | Complete | Total float | Constraint |
| --- | --- | --- | --- | --- | --- | --- | --- | --- | --- |
| 1 | 1 | **PROGRAMME PLAN.** | 1344d? | 2022-10-31 A | 2027-12-23 |  | 87% |  |  |
| 2 |  | MHHS Programme Start | 0d | 2022-10-31 A | 2022-10-31 A |  | 100% |  |  |
| 3 | 1.2 | **PROGRAMME MANAGEMENT** | 32917d | 2022-10-31 A | 2148-12-31 |  | 74% | 0d |  |
| 4 | 1.2.1 | **Programme Management** | 1089d | 2022-10-31 A | 2026-12-31 |  | 79% | 31828d |  |
| 5 |  | Sprint-based prioritisation planning and execution | 1089d | 2022-10-31 A | 2026-12-31 |  | 79% | 31828d | finish no earlier than 2026-12-31 |
| 6 |  | Programme governance secretariat | 1089d | 2022-10-31 A | 2026-12-31 |  | 79% | 31828d |  |
| 7 |  | RAID management and reporting | 1089d | 2022-10-31 A | 2026-12-31 |  | 79% | 31828d |  |
| 8 |  | Tracking against Programme outcomes and KPIs | 1089d | 2022-10-31 A | 2026-12-31 |  | 79% | 31828d |  |
| 9 |  | Change control and reporting | 1089d | 2022-10-31 A | 2026-12-31 |  | 79% | 31828d |  |
| 10 |  | Ongoing identification of lessons learned relating to the PMO and implementation of improvements | 1089d | 2022-10-31 A | 2026-12-31 |  | 79% | 31828d |  |
| 11 | 1.2.2 | **Programme Internal Assurance Reviews** | 1089d | 2022-10-31 A | 2026-12-31 |  | 79% | 31828d |  |
| 12 |  | Programme Internal Assurance Reviews | 1089d | 2022-10-31 A | 2026-12-31 |  | 79% | 31828d |  |
| 13 | 1.2.3 | **Engagement with PPs** | 32917d | 2022-10-31 A | 2148-12-31 |  | 67% | 0d |  |
| 14 |  | Ongoing PP liaison activities | 1089d | 2022-10-31 A | 2026-12-31 |  | 79% | 31828d |  |
| 15 |  | Milestone and Control Point objective setting | 1089d | 2022-10-31 A | 2026-12-31 |  | 79% | 31828d |  |
| 16 |  | Reporting | 1089d | 2022-10-31 A | 2026-12-31 |  | 79% | 31828d |  |
| 17 | 1.2.3.4 | **PP Engagement Events** | 1089d | 2022-10-31 A | 2026-12-31 |  | 79% | 31828d |  |
| 18 |  | Bilateral meetings | 1089d | 2022-10-31 A | 2026-12-31 |  | 79% | 31828d |  |
| 19 |  | Monthly webinars | 1089d | 2022-10-31 A | 2026-12-31 |  | 79% | 31828d |  |
| 20 |  | Open days | 1089d | 2022-10-31 A | 2026-12-31 |  | 79% | 31828d |  |
| 21 | 1.2.3.5 | **PP Communications** | 32917d | 2022-10-31 A | 2148-12-31 |  | 46% | 0d |  |
| 22 |  | The Clock updates (weekly) | 2654d | 2022-10-31 A | 2148-12-31 |  | 32% | 0d |  |
| 23 |  | Maintain and update content on public-facing Portal (and ongoing feedback reviews to identify and implement Portal improvements) | 1088d | 2022-10-31 A | 2026-12-30 |  | 79% | 31829d |  |
| 24 | 1.2.4 | **Code Change Support / Other Programme Alignment** | 1089d | 2022-10-31 A | 2026-12-31 |  | 79% | 31828d |  |
| 25 |  | Support DCC/BEIS on SEC change | 1089d | 2022-10-31 A | 2026-12-31 |  | 79% | 31828d |  |
| 26 |  | Support on Smart Meters Act changes | 1089d | 2022-10-31 A | 2026-12-31 |  | 79% | 31828d |  |
| 27 |  | Support DCC/RECCo on CSS change | 1089d | 2022-10-31 A | 2026-12-31 |  | 79% | 31828d |  |
| 28 |  | Support Elexon on BSC change | 1089d | 2022-10-31 A | 2026-12-31 |  | 79% | 31828d |  |
| 29 |  | Support code change inside & outside CCIAG | 1089d | 2022-10-31 A | 2026-12-31 |  | 79% | 31828d |  |
| 30 |  | Support code change inside & outside CCAG | 1089d | 2022-10-31 A | 2026-12-31 |  | 79% | 31828d |  |
| 31 | 1.2.5 | **Programme Replan Baseline** | 163d | 2022-10-31 A | 2023-06-14 A |  | 100% |  |  |
| 32 |  | Round 3 consultation preparation | 32d | 2022-10-31 A | 2022-12-13 A |  | 100% |  |  |
| 33 |  | PSG decision to launch Round 3 consultation | 0d | 2022-12-07 A | 2022-12-07 A | 32FS-5d | 100% |  |  |
| 34 |  | Round 3 consultation (incl. walkthroughs and Q&A) | 35d | 2022-12-14 A | 2023-01-31 A | 33FS+5d | 100% |  |  |
| 35 |  | Review and uplift of foundational testing documents to align with replan approach | 92d | 2022-12-14 A | 2023-04-20 A | 34SS | 100% |  |  |
| 36 |  | Round 3 consultation responses analysis (incl. identification of SIT volunteers) | 10d | 2023-02-01 A | 2023-02-14 A | 34 | 100% |  |  |
| 37 |  | Replan re-drafting and supporting artefact updates (incl. engagement with Ofgem) | 26d | 2023-02-15 A | 2023-03-22 A | 36 | 100% |  |  |
| 38 |  | Draft Replan Change Request | 31d | 2023-02-15 A | 2023-03-29 A | 36 | 100% |  |  |
| 39 |  | PSG decision to issue CR for industry impact assessment | 0d | 2023-04-05 A | 2023-04-05 A | 38FS+5d | 100% |  |  |
| 40 |  | Industry impact assessment | 10d | 2023-04-06 A | 2023-04-19 A | 39 | 100% |  |  |
| 41 |  | Replan playbacks (to assist PPs in impact assessment) | 5d | 2023-04-11 A | 2023-04-17 A | 40SS+3d | 100% |  |  |
| 42 |  | Industry impact assessment responses analysis | 5d | 2023-04-20 A | 2023-04-26 A | 40 | 100% |  |  |
| 43 |  | Extraordinary PSG decision to agree baseline recommendation | 0d | 2023-05-03 A | 2023-05-03 A | 42FS+5d | 100% |  |  |
| 44 |  | Programme Replan playbacks and drop-in sessions | 5d | 2023-06-08 A | 2023-06-14 A |  | 100% |  |  |
| 45 | 1.3 | **DESIGN, BUILD & TEST (PIT)** | 1101d? | 2022-10-31 A | 2027-01-18 |  | 97% | 31816d |  |
| 46 | 1.3.1 | **Design Baseline & Enduring PP Support** | 1101d | 2022-10-31 A | 2027-01-18 |  | 90% | 31816d |  |
| 47 |  | Physical design baselined (M5) | 0d | 2022-10-31 A | 2022-10-31 A |  | 100% |  |  |
| 48 | 1.3.1.2 | **M5 Design Work-Off Plan Implementation & Approval** | 79d | 2022-10-31 A | 2023-02-16 A |  | 100% |  |  |
| 49 |  | Implementation of M5 design Work-Off Plan | 74d | 2022-10-31 A | 2023-02-09 A | 47 | 100% |  |  |
| 50 |  | M5 design Work-Off Plan completion approved | 0d | 2023-02-16 A | 2023-02-16 A | 49FS+5d | 100% |  |  |
| 51 | 1.3.1.3 | **Enduring PP Design Support** | 1089d | 2022-10-31 A | 2026-12-31 A |  | 100% |  |  |
| 52 |  | Design playbacks and drop-in sessions | 45d | 2022-10-31 A | 2022-12-30 A | 47 | 100% |  |  |
| 53 |  | Support participants on E2E MHHS Design | 1089d | 2022-10-31 A | 2026-12-31 A | 47 | 100% |  |  |
| 54 |  | DIP Onboarding Support | 70d | 2022-11-14 A | 2023-02-17 A |  | 100% |  | must start on 2022-11-14 |
| 55 |  | iServer Launch | 0d | 2023-02-16 A | 2023-02-16 A | 50 | 100% |  |  |
| 56 | 1.3.1.4 | **Establish Design Change Management Processes** | 1101d | 2022-10-31 A | 2027-01-18 |  | 77% | 31816d |  |
| 57 |  | Internal review of internal change management processes | 35d | 2022-10-31 A | 2022-12-16 A |  | 100% |  |  |
| 58 |  | SRO approval of internal change management processes | 0d | 2022-12-16 A | 2022-12-16 A | 57FF | 100% |  |  |
| 59 |  | Change Process Webinar | 0d | 2023-01-16 A | 2023-01-16 A |  | 100% |  | must start on 2023-01-16 |
| 60 |  | Enduring change management process approved | 0d | 2023-02-16 A | 2023-02-16 A | 50FF | 100% |  |  |
| 61 |  | Maintain E2E MHHS Design (post-M5 design change management processes operational) | 1022d | 2023-02-17 A | 2027-01-18 | 60 | 76% | 31816d |  |
| 62 | 1.3.1.5 | **Design Authority Mobilisation** | 29d | 2022-12-14 A | 2023-01-23 A |  | 100% |  |  |
| 63 |  | Design Authority ToR approved | 0d | 2022-12-14 A | 2022-12-14 A |  | 100% |  | must start on 2022-12-14 |
| 64 |  | Inaugural Design Authority | 0d | 2023-01-23 A | 2023-01-23 A | 63FS+29d | 100% |  |  |
| 65 | 1.3.1.6 | **Network Operation Services Adaptor Procurement** | 0d | 2023-05-23 A | 2023-05-23 A |  | 100% |  |  |
| 66 |  | All SIT LDSOs have procured their adapter providers | 0d | 2023-05-23 A | 2023-05-23 A | 588SS | 100% |  |  |
| 67 | 1.3.2 | **PP Mobilisation** | 67d | 2022-10-31 A | 2023-01-31 A |  | 100% |  |  |
| 68 |  | Set up governance | 67d | 2022-10-31 A | 2023-01-31 A |  | 100% |  |  |
| 69 |  | Set up reporting | 67d | 2022-10-31 A | 2023-01-31 A |  | 100% |  |  |
| 70 |  | Obtain funding | 67d | 2022-10-31 A | 2023-01-31 A |  | 100% |  |  |

| ID | WBS | Task | Duration | Start | Finish | Predecessors | Complete | Constraint |
| --- | --- | --- | --- | --- | --- | --- | --- | --- |
| 71 |  | Earmark resources | 67d | 2022-10-31 A | 2023-01-31 A |  | 100% |  |
| 72 |  | Mobilise initial team | 67d | 2022-10-31 A | 2023-01-31 A |  | 100% |  |
| 73 | 1.3.3 | **PIT Stub Specification and Delivery** | 435d | 2022-10-31 A | 2024-06-28 A |  | 100% |  |
| 74 | 1.3.3.1 | **DIP Simulator** | 108d | 2022-10-31 A | 2023-03-29 A |  | 100% |  |
| 75 |  | Build & Test | 95d | 2022-10-31 A | 2023-03-10 A | 47 | 100% |  |
| 76 |  | UAT | 85d | 2022-11-14 A | 2023-03-10 A | 75SS+10d | 100% |  |
| 77 |  | Beta test | 95d | 2022-10-31 A | 2023-03-10 A | 75SS | 100% |  |
| 78 |  | Prepare for release | 18d | 2023-03-06 A | 2023-03-29 A | 77FS-5d | 100% |  |
| 79 |  | DIP Simulator released | 0d | 2023-03-29 A | 2023-03-29 A | 78FF | 100% | start no earlier than 2023-01-30 |
| 80 | 1.3.3.2 | **DIP Simulator Uplifts** | 257d | 2023-07-06 A | 2024-06-28 A |  | 100% |  |
| 81 |  | DIP Simulator uplifted to align with design releases - design/build/test | 27d | 2023-07-06 A | 2023-08-11 A | 117 | 100% |  |
| 82 |  | DIP Simulator uplifted to align with Interim Release 2 | 0d | 2023-08-11 A | 2023-08-11 A | 81 | 100% |  |
| 83 |  | DIP Simulator uplifted to align with design releases - design/build/test | 20d | 2023-10-09 A | 2023-11-03 A | 126FS+2d | 100% |  |
| 84 |  | DIP Simulator uplifted to align with Interim Release 5 | 0d | 2023-11-03 A | 2023-11-03 A | 83 | 100% |  |
| 85 |  | DIP Simulator uplifted to align with design releases - design/build/test | 37d | 2024-02-01 A | 2024-03-22 A | 134 | 100% |  |
| 86 |  | DIP Simulator uplifted to align with Interim Release 7 | 0d | 2024-03-22 A | 2024-03-22 A | 85 | 100% |  |
| 87 |  | DIP Simulator uplifted to align with design releases - design/build/test | 57d | 2024-04-04 A | 2024-06-21 A | 138 | 100% |  |
| 88 |  | DIP Simulator uplifted to align with Interim Release 8 | 0d | 2024-06-28 A | 2024-06-28 A | 87FS+5d | 100% |  |
| 89 | 1.3.3.3 | **Data Generator** | 130d | 2022-12-01 A | 2023-05-31 A |  | 100% |  |
| 90 |  | Design | 15d | 2022-12-01 A | 2022-12-21 A |  | 100% |  |
| 91 |  | Build & Test | 50d | 2023-02-16 A | 2023-04-26 A | 90FS+40d | 100% |  |
| 92 |  | UAT | 10d | 2023-04-27 A | 2023-05-10 A | 91 | 100% |  |
| 93 |  | Beta test | 45d | 2023-03-30 A | 2023-05-31 A | 91FS-20d, 95FF | 100% |  |
| 94 |  | Prepare for release | 24d | 2023-04-27 A | 2023-05-30 A | 92SS | 100% |  |
| 95 |  | Data Generator released | 0d | 2023-05-31 A | 2023-05-31 A | 94FS+1d | 100% |  |
| 96 | 1.3.4 | **Design Artefact Releases** | 566d? | 2023-02-22 A | 2025-04-23 A |  | 100% |  |
| 97 | 1.3.4.1 | **Interim release 1** | 79d | 2023-02-22 A | 2023-06-12 A |  | 100% |  |
| 98 |  | Prioritise DINs and CR | 1d | 2023-02-22 A | 2023-02-22 A |  | 100% | must start on 2023-02-22 |
| 99 | 1.3.4.1.2 | **Industry input session** | 7d | 2023-02-23 A | 2023-03-03 A |  | 100% |  |
| 100 |  | Raise a CR covering prioritized assessment cluster | 1d | 2023-02-23 A | 2023-02-23 A | 98 | 100% |  |
| 101 |  | Organize Industry Input session to go through significant items to reach consensus | 1d | 2023-02-23 A | 2023-02-23 A | 100SS | 100% |  |
| 102 |  | Conduct Meeting | 1d | 2023-03-03 A | 2023-03-03 A | 101FS+5d | 100% |  |
| 103 |  | Update baselined artefacts | 10d | 2023-03-24 A | 2023-04-06 A |  | 100% |  |
| 104 | 1.3.4.1.4 | **Participant review and impact assess changes** | 18d | 2023-04-14 A | 2023-05-09 A |  | 100% |  |
| 105 |  | Issue Redline Version of documents | 1d | 2023-04-14 A | 2023-04-14 A | 103FS+5d | 100% |  |
| 106 |  | Participants provide review comments to common log | 17d | 2023-04-17 A | 2023-05-09 A | 105 | 100% |  |
| 107 | 1.3.4.1.5 | **Assurance review** | 19d | 2023-05-10 A | 2023-06-05 A |  | 100% |  |
| 108 |  | SI Design Review and Respond to Comments | 5d | 2023-05-10 A | 2023-05-16 A | 106 | 100% |  |
| 109 |  | Prep for Assurance Review Meeting | 7d | 2023-05-17 A | 2023-05-25 A | 108 | 100% |  |
| 110 |  | Conduct Assurance Review Meeting | 1d | 2023-05-26 A | 2023-05-26 A | 109 | 100% |  |
| 111 |  | Update Artefacts following Assurance Review | 6d | 2023-05-29 A | 2023-06-05 A | 110 | 100% |  |
| 112 |  | PSG Approval of interim release plan | 1d | 2023-06-08 A | 2023-06-08 A |  | 100% | must start on 2023-06-08 |
| 113 |  | Publish updated baselined artefacts | 0d | 2023-06-06 A | 2023-06-06 A | 111 | 100% |  |
| 114 |  | Interim release 1 Go live | 0d | 2023-06-12 A | 2023-06-12 A | 113 | 100% |  |
| 115 | 1.3.4.2 | **Interim release 2** | 27d | 2023-05-30 A | 2023-07-05 A |  | 100% |  |
| 116 |  | Update baselined artefacts | 27d | 2023-05-30 A | 2023-07-05 A |  | 100% | must start on 2023-05-30 |
| 117 |  | Interim release 2 Go live | 0d | 2023-07-05 A | 2023-07-05 A | 116 | 100% |  |
| 118 | 1.3.4.3 | **Interim release 3** | 35d | 2023-06-15 A | 2023-08-02 A |  | 100% |  |
| 119 |  | Update baselined artefacts | 35d | 2023-06-15 A | 2023-08-02 A |  | 100% | must start on 2023-06-15 |
| 120 |  | Interim release 3 Go live | 0d | 2023-08-02 A | 2023-08-02 A | 119 | 100% |  |
| 121 | 1.3.4.4 | **Interim release 4** | 36d | 2023-07-12 A | 2023-08-30 A |  | 100% |  |
| 122 |  | Update baselined artefacts | 36d | 2023-07-12 A | 2023-08-30 A |  | 100% | must start on 2023-07-12 |
| 123 |  | Interim release 4 Go live | 0d | 2023-08-30 A | 2023-08-30 A | 122 | 100% |  |
| 124 | 1.3.4.5 | **Interim release 5** | 147d | 2023-08-17 A | 2024-03-08 A |  | 100% |  |
| 125 |  | Update baselined artefacts | 35d | 2023-08-17 A | 2023-10-04 A |  | 100% | must start on 2023-08-17 |
| 126 |  | Interim release 5 Go live | 0d | 2023-10-04 A | 2023-10-04 A | 125 | 100% |  |
| 127 |  | Interim Release 5 Deployed to SIT | 10d | 2024-02-26 A | 2024-03-08 A | 126FS+102d | 100% |  |
| 128 | 1.3.4.6 | **Interim release 6** | 192d | 2023-09-14 A | 2024-06-07 A |  | 100% |  |
| 129 |  | Update baselined artefacts | 35d | 2023-09-14 A | 2023-11-01 A |  | 100% | must start on 2023-09-14 |
| 130 |  | Interim release 6 Go live | 0d | 2023-11-01 A | 2023-11-01 A | 129 | 100% |  |
| 131 |  | Interim Release 6 Deployed to SIT | 10d | 2024-05-27 A | 2024-06-07 A | 130FS+147d | 100% |  |
| 132 | 1.3.4.7 | **Interim release 7** | 168d | 2023-10-18 A | 2024-06-07 A |  | 100% |  |
| 133 |  | Update baselined artefacts | 76d | 2023-10-18 A | 2024-01-31 A |  | 100% | start no earlier than 2023-10-18 |
| 134 |  | Interim release 7 Go live | 0d | 2024-01-31 A | 2024-01-31 A | 133 | 100% |  |
| 135 |  | Interim Release 7 Deployed to SIT | 10d | 2024-05-27 A | 2024-06-07 A | 134FS+82d | 100% |  |
| 136 | 1.3.4.8 | **Interim release 8** | 311d? | 2024-02-14 A | 2025-04-23 A |  | 100% |  |
| 137 |  | Update baselined artefacts | 36d | 2024-02-14 A | 2024-04-03 A |  | 100% | start no earlier than 2024-02-14 |
| 138 |  | Interim release 8 Go live | 0d | 2024-04-03 A | 2024-04-03 A | 137 | 100% | start no earlier than 2024-01-10 |
| 139 | 1.3.4.8.3 | **Interim Release 8.3 - Maintenance Window** | 11d | 2024-10-07 A | 2024-10-21 A |  | 100% |  |
| 140 |  | Interim Release 8.3 'effective from date' to SIT A | 0d | 2024-10-21 A | 2024-10-21 A | 138FS+143d | 100% |  |

| ID | WBS | Task | Duration | Start | Finish | Predecessors | Complete | Constraint |
| --- | --- | --- | --- | --- | --- | --- | --- | --- |
| 141 |  | Interim Release 8.3 'effective from date' to SIT B | 0d | 2024-10-07 A | 2024-10-07 A | 140SS-11d | 100% |  |
| 142 | 1.3.4.8.4 | **Interim Release 8.4** | 49d | 2024-09-25 A | 2024-12-02 A |  | 100% |  |
| 143 |  | Update baselined artefacts | 8d | 2024-09-25 A | 2024-10-04 A |  | 100% | start no earlier than 2024-09-25 |
| 144 |  | Interim Release 8.4 Published | 0d | 2024-10-16 A | 2024-10-16 A | 143FS+8d | 100% | start no earlier than 2024-10-09 |
| 145 |  | Interim Release 8.4 Deployed to SIT by Participants | 6d | 2024-11-25 A | 2024-12-02 A | 144FS+25d | 100% |  |
| 146 | 1.3.4.8.5 | **Interim Release 8.5** | 71d | 2024-10-16 A | 2025-01-22 A |  | 100% |  |
| 147 |  | Update baselined artefacts | 8d | 2024-10-16 A | 2024-10-25 A |  | 100% | start no earlier than 2024-10-16 |
| 148 |  | Interim Release 8.5 Published | 0d | 2024-11-06 A | 2024-11-06 A | 147FS+8d | 100% |  |
| 149 |  | Interim Release 8.5 Deployed to SIT by Participants | 3d | 2025-01-20 A | 2025-01-22 A | 148FS+52d | 100% |  |
| 150 | 1.3.4.8.6 | **Interim Release 8.6** | 45d? | 2024-11-21 A | 2025-01-22 A |  | 100% |  |
| 151 |  | Update baselined artefacts | 2d? | 2024-11-21 A | 2024-11-22 A |  | 100% | start no earlier than 2024-11-21 |
| 152 |  | Interim Release 8.6 Published | 1d? | 2024-11-25 A | 2024-11-25 A | 151 | 100% |  |
| 153 |  | Interim Release 8.6 Deployed to SIT by Participants | 3d | 2025-01-20 A | 2025-01-22 A | 152FS+39d | 100% |  |
| 154 | 1.3.4.8.7 | **Interim Release 8.7** | 5d | 2025-01-20 A | 2025-01-24 A |  | 100% |  |
| 155 |  | Update baselined artefacts | 2d | 2025-01-20 A | 2025-01-21 A |  | 100% | start no earlier than 2025-01-20 |
| 156 |  | Interim Release 8.7 Published | 1d | 2025-01-22 A | 2025-01-22 A | 155 | 100% |  |
| 157 |  | Interim Release 8.7 Deployed to SIT by Participants | 3d | 2025-01-22 A | 2025-01-24 A | 156FS-1d | 100% |  |
| 158 | 1.3.4.8.8 | **Interim Release 8.8** | 26d | 2025-02-05 A | 2025-03-12 A |  | 100% |  |
| 159 |  | Update baselined artefacts | 4d | 2025-02-05 A | 2025-02-10 A |  | 100% | start no earlier than 2025-02-05 |
| 160 |  | Interim Release 8.8 Published | 1d | 2025-02-12 A | 2025-02-12 A | 159FS+1d | 100% |  |
| 161 |  | Interim Release 8.8 Deployed to SIT by Participants | 20d | 2025-02-13 A | 2025-03-12 A | 160 | 100% |  |
| 162 | 1.3.4.8.9 | **Interim Release 8.9** | 45d | 2025-02-05 A | 2025-04-08 A |  | 100% |  |
| 163 |  | Update baselined artefacts | 4d | 2025-02-05 A | 2025-02-10 A |  | 100% | start no earlier than 2025-02-05 |
| 164 |  | Interim Release 8.9 Published | 0d | 2025-03-11 A | 2025-03-11 A | 163FS+1d | 100% | finish no earlier than 2025-03-26 |
| 165 |  | Interim Release 8.9 Deployed to SIT by Participants | 20d | 2025-03-12 A | 2025-04-08 A | 164 | 100% |  |
| 166 | 1.3.4.8.10 | **Interim Release 8.10** | 56d | 2025-02-05 A | 2025-04-23 A |  | 100% |  |
| 167 |  | Update baselined artefacts | 4d | 2025-02-05 A | 2025-02-10 A |  | 100% | start no earlier than 2025-02-05 |
| 168 |  | Interim Release 8.10 Published | 1d | 2025-03-26 A | 2025-03-26 A | 167FS+1d | 100% | finish no earlier than 2025-03-26 |
| 169 |  | Interim Release 8.10 Deployed to SIT by Participants | 20d | 2025-03-27 A | 2025-04-23 A | 168 | 100% | finish no earlier than 2025-03-27 |
| 170 | 1.3.5 | **Queries Support / Knowledgebase & Tool Roll-Out (Systems)** | 325d | 2023-01-03 A | 2024-04-01 A |  | 100% |  |
| 171 | 1.3.5.1 | **Query Management** | 325d | 2023-01-03 A | 2024-04-01 A |  | 100% |  |
| 172 |  | Respond to Participant Queries | 325d | 2023-01-03 A | 2024-04-01 A |  | 100% | must start on 2023-01-03 |
| 173 |  | Respond to Programme Queries | 325d | 2023-01-03 A | 2024-04-01 A | 172SS | 100% |  |
| 174 | 1.3.5.2 | **Query Support tooling (FreshDesk)** | 23d | 2023-06-01 A | 2023-07-03 A |  | 100% |  |
| 175 |  | Migrate to Standalone Freshdesk | 10d | 2023-06-01 A | 2023-06-14 A |  | 100% | must start on 2023-06-01 |
| 176 |  | Develop reporting dashboard | 5d | 2023-06-15 A | 2023-06-21 A | 175 | 100% |  |
| 177 |  | Issue to SRO for Review | 5d | 2023-06-22 A | 2023-06-28 A | 176 | 100% |  |
| 178 |  | Update following review | 2d | 2023-06-29 A | 2023-06-30 A | 177 | 100% |  |
| 179 |  | Sign off | 1d | 2023-07-03 A | 2023-07-03 A | 178 | 100% |  |
| 180 | 1.3.5.3 | **KnowledgeBase Development** | 72d | 2023-06-01 A | 2023-09-08 A |  | 100% |  |
| 181 |  | Define Scope of KB | 1d | 2023-06-01 A | 2023-06-01 A | 175SS | 100% |  |
| 182 |  | Capture Existing KB artefacts | 20d | 2023-06-02 A | 2023-06-29 A | 181 | 100% |  |
| 183 |  | Tag artefacts | 5d | 2023-06-30 A | 2023-07-06 A | 182 | 100% |  |
| 184 |  | Develop Participant Interfaces | 20d | 2023-07-07 A | 2023-08-03 A | 183 | 100% |  |
| 185 |  | Promote to Collaboration Portal | 21d | 2023-08-04 A | 2023-09-01 A | 184 | 100% |  |
| 186 |  | Link into FreshDesk | 5d | 2023-09-04 A | 2023-09-08 A | 185 | 100% |  |
| 187 | 1.3.6 | **PP Design, Build & Test (DBT)** | 605d | 2022-10-31 A | 2025-02-21 A |  | 100% |  |
| 188 | 1.3.6.1 | **PP Impact Assessment, Planning & Procurement** | 110d | 2022-10-31 A | 2023-03-31 A |  | 100% |  |
| 189 | 1.3.6.1.1 | **PP Impact Assessment** | 67d | 2022-10-31 A | 2023-01-31 A |  | 100% |  |
| 190 |  | Develop heatmap for impact of MHHS | 67d | 2022-10-31 A | 2023-01-31 A | 47 | 100% |  |
| 191 |  | Develop detailed impact assessment | 67d | 2022-10-31 A | 2023-01-31 A | 47 | 100% |  |
| 192 | 1.3.6.1.2 | **PP Planning** | 67d | 2022-10-31 A | 2023-01-31 A |  | 100% |  |
| 193 |  | Develop detailed short-term plan | 23d | 2022-10-31 A | 2022-11-30 A | 47 | 100% |  |
| 194 |  | Develop overall project plan for implementation | 67d | 2022-10-31 A | 2023-01-31 A | 47 | 100% |  |
| 195 |  | Develop procurement plan | 67d | 2022-10-31 A | 2023-01-31 A | 47 | 100% |  |
| 196 | 1.3.6.1.3 | **PP Software/Service Procurement** | 110d | 2022-10-31 A | 2023-03-31 A |  | 100% |  |
| 197 |  | Run tender process | 67d | 2022-10-31 A | 2023-01-31 A | 47 | 100% |  |
| 198 |  | Select provider & sign commercials | 43d | 2023-02-01 A | 2023-03-31 A | 197 | 100% |  |
| 199 | 1.3.6.2 | **Central Systems DBT** | 325d | 2022-10-31 A | 2024-01-26 A |  | 100% |  |
| 200 | 1.3.6.2.1 | **Elexon Central Systems DBT CIT (Entering at Interval 1)** | 248d | 2022-10-31 A | 2023-10-11 A |  | 100% |  |
| 201 | 1.3.6.2.1.1 | **Design and Build** | 235d | 2022-10-31 A | 2023-09-22 A |  | 100% |  |
| 202 |  | Helix Design and Build | 235d | 2022-10-31 A | 2023-09-22 A | 2 | 100% |  |
| 203 | 1.3.6.2.1.2 | **Test Approach & Plan** | 235d | 2022-10-31 A | 2023-09-22 A |  | 100% |  |
| 204 |  | Develop Test Approach & Plan | 180d | 2022-10-31 A | 2023-07-07 A |  | 100% |  |
| 205 |  | Elexon Central Systems Test Approach & Plan (PIT) submitted to Programme for assurance | 0d | 2023-07-13 A | 2023-07-13 A | 204FF+4d | 100% |  |
| 206 |  | Elexon Central Systems Test Approach & Plan (PIT) V2 resubmitted to Programme for assurance | 0d | 2023-07-27 A | 2023-07-27 A | 205FS+9d | 100% |  |
| 207 |  | Elexon Central Systems Test Approach & Plan (PIT) V3 resubmitted to Programme for assurance | 0d | 2023-08-18 A | 2023-08-18 A | 206FS+17d | 100% |  |
| 208 |  | Elexon Central Systems Test approach and plan MHHS Review Completed | 0d | 2023-09-22 A | 2023-09-22 A | 207FS+25d | 100% |  |
| 209 | 1.3.6.2.1.3 | **Test Readiness Report** | 16d | 2023-07-28 A | 2023-08-18 A |  | 100% |  |
| 210 |  | Test readiness reporting | 16d | 2023-07-28 A | 2023-08-18 A | 205FS+10d | 100% |  |

| ID | WBS | Task | Duration | Start | Finish | Predecessors | Complete | Constraint |
| --- | --- | --- | --- | --- | --- | --- | --- | --- |
| 211 | 1.3.6.2.1.4 | **Requirements to test Traceability Matrix (RTTM)** | 35d | 2023-08-04 A | 2023-09-22 A |  | 100% |  |
| 212 |  | Elexon Central Systems RTTM submitted to Programme for assurance | 0d | 2023-08-04 A | 2023-08-04 A | 205 | 100% | start no earlier than 2023-04-28 |
| 213 |  | Elexon Central Systems RTTM MHHS Review Completed | 0d | 2023-09-22 A | 2023-09-22 A | 212FS+35d | 100% |  |
| 214 | 1.3.6.2.1.5 | **Test Scenarios** | 35d | 2023-08-04 A | 2023-09-22 A |  | 100% |  |
| 215 |  | Elexon Central Systems test scenarios submitted to Programme for assurance | 0d | 2023-08-04 A | 2023-08-04 A | 205 | 100% |  |
| 216 |  | Elexon Central Systems Test scenarios MHHS Review Completed | 0d | 2023-09-22 A | 2023-09-22 A | 215FS+35d | 100% |  |
| 217 | 1.3.6.2.1.6 | **PIT Execution** | 38d | 2023-08-21 A | 2023-10-11 A |  | 100% |  |
| 218 |  | PIT Test Execution Progress Report | 18d | 2023-09-04 A | 2023-09-27 A | 210FS+10d | 100% |  |
| 219 |  | Elexon Central Systems PIT Execution | 28d | 2023-08-21 A | 2023-09-27 A | 210 | 100% |  |
| 220 |  | Elexon Central Systems PIT Completion Report submitted to Programme for assurance | 0d | 2023-09-27 A | 2023-09-27 A | 219 | 100% |  |
| 221 |  | Elexon Central Systems PIT Completion Report MHHS Review Completed | 0d | 2023-10-11 A | 2023-10-11 A | 213, 216, 218, 220FS+10d, 208 | 100% |  |
| 222 | 1.3.6.2.2 | **DIP DBT CIT (Entering at Interval 1)** | 221d | 2023-01-02 A | 2023-11-06 A |  | 100% |  |
| 223 |  | Design | 80d | 2023-01-02 A | 2023-04-21 A |  | 100% | must start on 2023-01-02 |
| 224 |  | Build | 155d | 2023-01-09 A | 2023-08-11 A | 223SS+5d | 100% |  |
| 225 | 1.3.6.2.2.3 | **Test Approach & Plan** | 9d | 2023-07-07 A | 2023-07-20 A |  | 100% |  |
| 226 |  | DIP Test Approach & Plan (PIT) submitted to Programme for assurance | 0d | 2023-07-07 A | 2023-07-07 A |  | 100% |  |
| 227 |  | DIP Test Approach & Plan (PIT) MHHS Review Completed | 0d | 2023-07-20 A | 2023-07-20 A | 226FS+9d | 100% |  |
| 228 | 1.3.6.2.2.4 | **PIT Test Readiness Report** | 31d | 2023-07-21 A | 2023-09-01 A |  | 100% |  |
| 229 |  | Test readiness reporting | 31d | 2023-07-21 A | 2023-09-01 A | 226FS+9d | 100% |  |
| 230 | 1.3.6.2.2.5 | **Requirements to test Traceability Matrix (RTTM)** | 18d | 2023-08-04 A | 2023-08-30 A |  | 100% |  |
| 231 |  | DIP RTTM submitted to Programme for assurance | 0d | 2023-08-04 A | 2023-08-04 A | 226FS+15d | 100% |  |
| 232 |  | DIP RTTM MHHS Review Completed | 0d | 2023-08-30 A | 2023-08-30 A | 231FS+18d | 100% |  |
| 233 | 1.3.6.2.2.6 | **Test Scenarios** | 22d | 2023-07-31 A | 2023-08-30 A |  | 100% |  |
| 234 |  | DIP PIT test scenarios submitted to Programme for assurance | 0d | 2023-07-31 A | 2023-07-31 A | 226FS+15d | 100% |  |
| 235 |  | DIP Test scenarios MHHS Review Completed | 0d | 2023-08-30 A | 2023-08-30 A | 234FS+22d | 100% |  |
| 236 | 1.3.6.2.2.7 | **PIT execution** | 50d | 2023-08-29 A | 2023-11-06 A |  | 100% |  |
| 237 |  | PIT Test Execution Progress Report | 37d | 2023-09-01 A | 2023-10-23 A | 238FF, 229 | 100% | start no earlier than 2023-08-29 |
| 238 |  | PIT Execution (Interim Release 1) | 30d | 2023-08-29 A | 2023-10-09 A |  | 100% | start no earlier than 2023-08-29 |
| 239 |  | PIT Execution (Interim Release 2) | 10d | 2023-10-10 A | 2023-10-23 A | 238 | 100% |  |
| 240 |  | DIP PIT Completion Report (Interim Release 1) submitted to Programme for assurance | 0d | 2023-10-09 A | 2023-10-09 A | 238 | 100% |  |
| 241 |  | DIP PIT Completion Report (Interim Release 1) MHHS Review Completed | 0d | 2023-10-23 A | 2023-10-23 A | 240FS+10d | 100% |  |
| 242 |  | DIP PIT Completion Report (Interim Release 2) submitted to Programme for assurance | 0d | 2023-10-23 A | 2023-10-23 A | 239, 237 | 100% |  |
| 243 |  | DIP PIT Completion Report (Interim Release 2) MHHS Review Completed | 0d | 2023-11-06 A | 2023-11-06 A | 242FS+10d | 100% |  |
| 244 | 1.3.6.2.3 | **DCC (DSP) DBT SIT Functional (Entering at SIT Functional)** | 325d | 2022-10-31 A | 2024-01-26 A |  | 100% |  |
| 245 |  | Design | 67d | 2022-10-31 A | 2023-01-31 A |  | 100% |  |
| 246 | 1.3.6.2.3.2 | **Test Approach & Plan** | 20d | 2023-11-17 A | 2023-12-15 A |  | 100% |  |
| 247 |  | DCC Test Approach & Plan (PIT) submitted to Programme for assurance | 0d | 2023-11-17 A | 2023-11-17 A | 245FS+208d | 100% |  |
| 248 |  | DCC Test Approach & Plan (PIT) MHHS Review Completed | 0d | 2023-12-15 A | 2023-12-15 A | 247FS+20d | 100% |  |
| 249 | 1.3.6.2.3.3 | **Test Readiness Report** | 22d | 2023-12-04 A | 2024-01-02 A |  | 100% |  |
| 250 |  | Test readiness reporting | 22d | 2023-12-04 A | 2024-01-02 A | 247FS+10d | 100% |  |
| 251 | 1.3.6.2.3.4 | **Requirements to test Traceability Matrix (RTTM)** | 30d | 2023-12-15 A | 2024-01-26 A |  | 100% |  |
| 252 |  | DCC RTTM submitted to Programme for assurance | 0d | 2023-12-15 A | 2023-12-15 A | 247FS+20d | 100% | start no earlier than 2023-04-28 |
| 253 |  | DCC RTTM MHHS Review Completed | 0d | 2024-01-26 A | 2024-01-26 A | 252FS+30d | 100% |  |
| 254 | 1.3.6.2.3.5 | **Test Scenarios** | 30d | 2023-12-15 A | 2024-01-26 A |  | 100% |  |
| 255 |  | DCC test scenarios submitted to Programme for assurance | 0d | 2023-12-15 A | 2023-12-15 A | 247FS+20d | 100% |  |
| 256 |  | DCC Test Scenarios MHHS Review Completed | 0d | 2024-01-26 A | 2024-01-26 A | 255FS+30d | 100% |  |
| 257 | 1.3.6.2.4 | **RECCo (EES) DBT CIT (Entering at Interval 6)** | 71d | 2023-10-13 A | 2024-01-19 A |  | 100% |  |
| 258 | 1.3.6.2.4.1 | **Test Approach & Plan** | 20d | 2023-10-13 A | 2023-11-09 A |  | 100% |  |
| 259 |  | EES Test Approach & Plan (PIT) submitted to Programme for assurance | 0d | 2023-10-13 A | 2023-10-13 A |  | 100% | start no earlier than 2023-10-13 |
| 260 |  | EES Test approach and plan (PIT) MHHS Review Completed | 0d | 2023-11-09 A | 2023-11-09 A | 259FS+20d | 100% |  |
| 261 | 1.3.6.2.4.2 | **Test Readiness Report** | 10d | 2023-10-27 A | 2023-11-09 A |  | 100% |  |
| 262 |  | Test readiness reporting | 10d | 2023-10-27 A | 2023-11-09 A | 259FS+10d | 100% |  |
| 263 | 1.3.6.2.4.3 | **Requirements to test Traceability Matrix (RTTM)** | 20d | 2023-11-02 A | 2023-11-30 A |  | 100% |  |
| 264 |  | EES RTTM submitted to Programme for assurance | 0d | 2023-11-02 A | 2023-11-02 A | 259FS+15d | 100% |  |
| 265 |  | EES RTTM MHHS Review Completed | 0d | 2023-11-30 A | 2023-11-30 A | 264FS+20d | 100% |  |
| 266 | 1.3.6.2.4.4 | **Test Scenarios** | 20d | 2023-11-02 A | 2023-11-30 A |  | 100% |  |
| 267 |  | EES test scenarios submitted to Programme for assurance | 0d | 2023-11-02 A | 2023-11-02 A | 259FS+15d | 100% |  |
| 268 |  | EES Test scenarios MHHS Review Completed | 0d | 2023-11-30 A | 2023-11-30 A | 267FS+20d | 100% |  |
| 269 | 1.3.6.2.4.5 | **PIT execution** | 51d | 2023-11-10 A | 2024-01-19 A |  | 100% |  |
| 270 |  | PIT Test Execution Progress Report | 41d | 2023-11-10 A | 2024-01-05 A | 262 | 100% |  |
| 271 |  | PIT Execution | 41d | 2023-11-10 A | 2024-01-05 A | 267FS+5d | 100% |  |
| 272 |  | EES PIT Completion Report submitted to Programme for assurance | 0d | 2024-01-05 A | 2024-01-05 A | 270, 271 | 100% |  |
| 273 |  | EES PIT Completion Report MHHS Review Completed | 0d | 2024-01-19 A | 2024-01-19 A | 260, 265, 268, 272FS+10d | 100% |  |
| 274 | 1.3.6.2.5 | **Registration Services DBT CIT (Entering at Interval 2)** | 70d | 2023-07-28 A | 2023-11-03 A |  | 100% |  |
| 275 | 1.3.6.2.5.1 | **Test Approach & Plan** | 40d | 2023-07-28 A | 2023-09-22 A |  | 100% |  |
| 276 |  | Registration Services Test Approach & Plan (PIT) submitted to Programme for assurance | 0d | 2023-07-28 A | 2023-07-28 A |  | 100% |  |
| 277 |  | Registration Services Test approach and plan MHHS Review Completed | 0d | 2023-09-22 A | 2023-09-22 A | 276FS+40d | 100% |  |
| 278 | 1.3.6.2.5.2 | **Test Readiness Report** | 20d | 2023-08-14 A | 2023-09-08 A |  | 100% |  |
| 279 |  | Test readiness reporting | 20d | 2023-08-14 A | 2023-09-08 A | 276FS+10d | 100% |  |
| 280 | 1.3.6.2.5.3 | **Requirements to test Traceability Matrix (RTTM)** | 20d | 2023-09-01 A | 2023-09-29 A |  | 100% |  |

| ID | WBS | Task | Duration | Start | Finish | Predecessors | Complete | Constraint |
| --- | --- | --- | --- | --- | --- | --- | --- | --- |
| 281 |  | Registration Services RTTM submitted to Programme for assurance | 0d | 2023-09-01 A | 2023-09-01 A | 276FS+15d | 100% | start no earlier than 2023-04-28 |
| 282 |  | Registration Services RTTM MHHS Review Completed | 0d | 2023-09-29 A | 2023-09-29 A | 281FS+20d | 100% |  |
| 283 | 1.3.6.2.5.4 | **Test Scenarios** | 20d | 2023-09-01 A | 2023-09-29 A |  | 100% |  |
| 284 |  | Registration Services test scenarios submitted to Programme for assurance | 0d | 2023-09-01 A | 2023-09-01 A | 276FS+15d | 100% |  |
| 285 |  | Registration Services Test scenarios MHHS Review Completed | 0d | 2023-09-29 A | 2023-09-29 A | 284FS+20d | 100% |  |
| 286 | 1.3.6.2.5.5 | **PIT execution** | 40d | 2023-09-11 A | 2023-11-03 A |  | 100% |  |
| 287 |  | PIT Test Execution Progress Report | 33d | 2023-09-11 A | 2023-10-25 A | 279 | 100% |  |
| 288 |  | PIT Execution | 30d | 2023-09-11 A | 2023-10-20 A | 284FS+5d | 100% |  |
| 289 |  | Registration Services PIT (CIT interval 2) Completion Report submitted to Programme for assurance | 0d | 2023-10-25 A | 2023-10-25 A | 287, 288 | 100% |  |
| 290 |  | Registration Services PIT (CIT interval 2) Completion Report MHHS Review Completed | 0d | 2023-11-03 A | 2023-11-03 A | 277, 282, 285, 289FS+7d | 100% |  |
| 291 | 1.3.6.3 | **SIT Participants DBT** | 401d | 2023-08-11 A | 2025-02-21 A |  | 100% |  |
| 292 | 1.3.6.3.1 | **All Data Services DBT CIT (Entering at Interval 3)** | 71d | 2023-08-11 A | 2023-11-17 A |  | 100% |  |
| 293 | 1.3.6.3.1.1 | **Test Approach & Plan** | 30d | 2023-08-11 A | 2023-09-21 A |  | 100% |  |
| 294 |  | All Data Services Test Approach & Plans (PIT) submitted to Programme for assurance | 0d | 2023-08-11 A | 2023-08-11 A |  | 100% | start no earlier than 2023-08-11 |
| 295 |  | All Data Services Test approach and plans MHHS Review Completed | 0d | 2023-09-21 A | 2023-09-21 A | 294FS+30d | 100% |  |
| 296 | 1.3.6.3.1.2 | **Test Readiness Report** | 11d | 2023-08-25 A | 2023-09-08 A |  | 100% |  |
| 297 |  | Test readiness reporting | 11d | 2023-08-25 A | 2023-09-08 A | 294FS+10d | 100% |  |
| 298 | 1.3.6.3.1.3 | **Requirements to test Traceability Matrix (RTTM)** | 7d | 2023-09-20 A | 2023-09-29 A |  | 100% |  |
| 299 |  | All Data Services RTTMs submitted to Programme for assurance | 0d | 2023-09-20 A | 2023-09-20 A | 294FS+29d | 100% |  |
| 300 |  | All Data Services RTTMs MHHS Review Completed | 0d | 2023-09-29 A | 2023-09-29 A | 299FS+7d | 100% |  |
| 301 | 1.3.6.3.1.4 | **Test Scenarios** | 6d | 2023-09-20 A | 2023-09-28 A |  | 100% |  |
| 302 |  | All Data Services test scenarios' submitted to Programme for assurance | 0d | 2023-09-20 A | 2023-09-20 A | 294FS+29d | 100% |  |
| 303 |  | All Data Services Test scenarios' MHHS Review Completed | 0d | 2023-09-28 A | 2023-09-28 A | 302FS+6d | 100% |  |
| 304 | 1.3.6.3.1.5 | **PIT execution** | 50d | 2023-09-11 A | 2023-11-17 A |  | 100% |  |
| 305 |  | PIT Test Execution Progress Report | 40d | 2023-09-11 A | 2023-11-03 A | 297 | 100% |  |
| 306 |  | PIT Execution | 27d | 2023-09-28 A | 2023-11-03 A | 302FS+5d | 100% |  |
| 307 |  | All Data Services PIT Completion Reports submitted to Programme for assurance | 0d | 2023-11-03 A | 2023-11-03 A | 305, 306 | 100% |  |
| 308 |  | All Data Services PIT Completion Reports MHHS Review Completed | 0d | 2023-11-17 A | 2023-11-17 A | 295, 300, 303, 307FS+10d | 100% |  |
| 309 | 1.3.6.3.2 | **All Metering Services DBT CIT (Entering at Interval 4)** | 70d | 2023-08-25 A | 2023-12-01 A |  | 100% |  |
| 310 | 1.3.6.3.2.1 | **Test Approach & Plan** | 40d | 2023-08-25 A | 2023-10-20 A |  | 100% |  |
| 311 |  | All Metering Services Test Approach & Plans (PIT) submitted to Programme for assurance | 0d | 2023-08-25 A | 2023-08-25 A |  | 100% |  |
| 312 |  | All Metering Services Test approach and plans MHHS Review Completed | 0d | 2023-10-20 A | 2023-10-20 A | 311FS+40d | 100% |  |
| 313 | 1.3.6.3.2.2 | **Test Readiness Report** | 11d | 2023-09-11 A | 2023-09-25 A |  | 100% |  |
| 314 |  | Test readiness reporting | 11d | 2023-09-11 A | 2023-09-25 A | 311FS+10d | 100% |  |
| 315 | 1.3.6.3.2.3 | **Requirements to test Traceability Matrix (RTTM)** | 30d | 2023-09-15 A | 2023-10-27 A |  | 100% |  |
| 316 |  | All Metering Services RTTMs submitted to Programme for assurance | 0d | 2023-09-15 A | 2023-09-15 A | 311FS+15d | 100% |  |
| 317 |  | All Metering Services MHHS Reviews Completed | 0d | 2023-10-27 A | 2023-10-27 A | 316FS+30d | 100% |  |
| 318 | 1.3.6.3.2.4 | **Test Scenarios** | 30d | 2023-09-15 A | 2023-10-27 A |  | 100% |  |
| 319 |  | All Metering Services test scenarios' submitted to Programme for assurance | 0d | 2023-09-15 A | 2023-09-15 A | 311FS+15d | 100% |  |
| 320 |  | All Metering Services Test scenarios' MHHS Review Completed | 0d | 2023-10-27 A | 2023-10-27 A | 319FS+30d | 100% |  |
| 321 | 1.3.6.3.2.5 | **PIT execution** | 50d | 2023-09-25 A | 2023-12-01 A |  | 100% |  |
| 322 |  | PIT Test Execution Progress Report | 39d | 2023-09-26 A | 2023-11-17 A | 314 | 100% |  |
| 323 |  | PIT Execution | 40d | 2023-09-25 A | 2023-11-17 A | 319FS+5d | 100% |  |
| 324 |  | All Metering Services PIT Completion Reports submitted to Programme for assurance | 0d | 2023-11-17 A | 2023-11-17 A | 322, 323 | 100% |  |
| 325 |  | All Metering Services PIT Completion Reports MHHS Review Completed | 0d | 2023-12-01 A | 2023-12-01 A | 312, 317, 320, 324FS+10d | 100% |  |
| 326 | 1.3.6.3.3 | **All SIT Programme Participants PIT (SIT Functional)** | 331d | 2023-11-17 A | 2025-02-21 A |  | 100% |  |
| 327 | 1.3.6.3.3.1 | **Test Approach & Plans** | 40d | 2023-11-17 A | 2024-01-11 A |  | 100% |  |
| 328 |  | SIT Functional PIT Test Approach & Plan (PIT) submitted to Programme for assurance | 0d | 2023-11-17 A | 2023-11-17 A |  | 100% | start no earlier than 2023-11-17 |
| 329 |  | All SIT Functional Test approach and plans MHHS Reviews Completed | 0d | 2024-01-11 A | 2024-01-11 A | 328FS+40d | 100% |  |
| 330 | 1.3.6.3.3.2 | **Test Readiness Reports** | 11d | 2023-12-01 A | 2023-12-15 A |  | 100% |  |
| 331 |  | Test readiness reporting | 11d | 2023-12-01 A | 2023-12-15 A | 328FS+10d | 100% |  |
| 332 | 1.3.6.3.3.3 | **Requirements to test Traceability Matrices (RTTM)** | 30d | 2023-12-07 A | 2024-01-18 A |  | 100% |  |
| 333 |  | SIT Functional PIT RTTM submitted to Programme for assurance | 0d | 2023-12-07 A | 2023-12-07 A | 328FS+15d | 100% |  |
| 334 |  | All SIT Functional RTTMs MHHS Reviews Completed | 0d | 2024-01-18 A | 2024-01-18 A | 333FS+30d | 100% |  |
| 335 | 1.3.6.3.3.4 | **Test Scenarios** | 30d | 2023-12-07 A | 2024-01-18 A |  | 100% |  |
| 336 |  | SIT Functional PIT test scenarios submitted to Programme for assurance | 0d | 2023-12-07 A | 2023-12-07 A | 328FS+15d | 100% |  |
| 337 |  | All SIT Functional Test scenarios' MHHS Reviews Completed | 0d | 2024-01-18 A | 2024-01-18 A | 336FS+30d | 100% |  |
| 338 | 1.3.6.3.3.5 | **PIT execution** | 51d | 2023-12-15 A | 2024-02-23 A |  | 100% |  |
| 339 |  | PIT Test Execution Progress Reports | 40d | 2023-12-18 A | 2024-02-09 A | 331 | 100% |  |
| 340 |  | PIT Execution | 41d | 2023-12-15 A | 2024-02-09 A | 336FS+5d | 100% |  |
| 341 |  | All SIT Functional PIT Completion Reports submitted to Programme for Assurance | 0d | 2024-02-09 A | 2024-02-09 A | 339, 340 | 100% |  |
| 342 |  | All SIT Functional PIT Completion Reports MHHS Review Completed | 0d | 2024-02-23 A | 2024-02-23 A | 329, 334, 337, 341FS+10d | 100% |  |
| 343 | 1.3.6.3.3.6 | **All SIT Programme Participants PIT (SIT Migration)** | 71d | 2024-02-16 A | 2024-05-24 A |  | 100% |  |
| 344 | 1.3.6.3.3.6.1 | **Test Approach & Plans** | 40d | 2024-02-16 A | 2024-04-11 A |  | 100% |  |
| 345 |  | All SIT Migration PIT Test Approach & Plans submitted to Programme for assurance | 0d | 2024-02-16 A | 2024-02-16 A |  | 100% | start no earlier than 2024-02-16 |
| 346 |  | All SIT Migration PIT Test approach and plans MHHS Reviews Completed | 0d | 2024-04-11 A | 2024-04-11 A | 345FS+40d | 100% |  |
| 347 | 1.3.6.3.3.6.2 | **Test Readiness Reports** | 11d | 2024-03-01 A | 2024-03-15 A |  | 100% |  |
| 348 |  | Test readiness reporting | 11d | 2024-03-01 A | 2024-03-15 A | 345FS+10d | 100% |  |
| 349 | 1.3.6.3.3.6.3 | **Requirements to test Traceability Matrices (RTTM)** | 30d | 2024-03-07 A | 2024-04-18 A |  | 100% |  |
| 350 |  | All SIT Migration PIT RTTMs submitted to Programme for assurance | 0d | 2024-03-07 A | 2024-03-07 A | 345FS+15d | 100% |  |

| ID | WBS | Task | Duration | Start | Finish | Predecessors | Complete | Constraint |
| --- | --- | --- | --- | --- | --- | --- | --- | --- |
| 351 |  | All SIT Migration RTTMs MHHS Reviews Completed | 0d | 2024-04-18 A | 2024-04-18 A | 350FS+30d | 100% |  |
| 352 | 1.3.6.3.3.6.4 | **Test Scenarios** | 30d | 2024-03-07 A | 2024-04-18 A |  | 100% |  |
| 353 |  | All SIT Migration PIT test scenarios submitted to Programme for assurance | 0d | 2024-03-07 A | 2024-03-07 A | 345FS+15d | 100% |  |
| 354 |  | All SIT Migration Test scenarios MHHS Reviews Completed | 0d | 2024-04-18 A | 2024-04-18 A | 353FS+30d | 100% |  |
| 355 | 1.3.6.3.3.6.5 | **PIT execution** | 51d | 2024-03-15 A | 2024-05-24 A |  | 100% |  |
| 356 |  | PIT Test Execution Progress Reports | 40d | 2024-03-18 A | 2024-05-10 A | 348 | 100% |  |
| 357 |  | PIT Execution | 41d | 2024-03-15 A | 2024-05-10 A | 353FS+5d | 100% |  |
| 358 |  | All SIT Migration PIT Completion Reports submitted to Programme for assurance | 0d | 2024-05-10 A | 2024-05-10 A | 356, 357 | 100% |  |
| 359 |  | All SIT Migration PIT Completion Reports MHHS Review Completed | 0d | 2024-05-24 A | 2024-05-24 A | 346, 351, 354, 358FS+10d | 100% |  |
| 360 | 1.3.6.3.3.7 | **All SIT Programme Participants PIT (SIT Non Functional)** | 161d | 2024-07-12 A | 2025-02-21 A |  | 100% |  |
| 361 | 1.3.6.3.3.7.1 | **Test Approach & Plan** | 41d | 2024-09-27 A | 2024-11-22 A |  | 100% |  |
| 362 |  | SIT Non-Functional PIT Test Approach & Plan (PIT) submitted to Programme for assurance | 0d | 2024-09-27 A | 2024-09-27 A |  | 100% | start no earlier than 2024-05-10 |
| 363 |  | SIT Non-Functional Test approach and plan MHHS Review Completed | 1d | 2024-11-21 A | 2024-11-22 A | 362FS+40d | 100% |  |
| 364 | 1.3.6.3.3.7.2 | **Test Readiness Report** | 13d | 2024-10-04 A | 2024-10-22 A |  | 100% |  |
| 365 |  | Test readiness reporting | 13d | 2024-10-04 A | 2024-10-22 A | 362FS+10d | 100% |  |
| 366 | 1.3.6.3.3.7.3 | **Requirements to test Traceability Matrix (RTTM)** | 20d | 2024-11-01 A | 2024-11-29 A |  | 100% |  |
| 367 |  | SIT Non-Functional PIT RTTM submitted to Programme for assurance | 0d | 2024-11-01 A | 2024-11-01 A | 362FS+26d | 100% |  |
| 368 |  | SIT Non-Functional RTTM MHHS Review Completed | 0d | 2024-11-29 A | 2024-11-29 A | 367FS+20d | 100% | start no earlier than 2024-11-29 |
| 369 | 1.3.6.3.3.7.4 | **Test Scenarios** | 20d | 2024-11-01 A | 2024-11-29 A |  | 100% |  |
| 370 |  | SIT Non-Functional PIT test scenarios submitted to Programme for assurance | 0d | 2024-11-01 A | 2024-11-01 A | 362FS+26d | 100% |  |
| 371 |  | SIT Non-Functional Test scenarios MHHS Review Completed | 0d | 2024-11-29 A | 2024-11-29 A | 370FS+20d | 100% |  |
| 372 | 1.3.6.3.3.7.5 | **PIT execution** | 161d | 2024-07-12 A | 2025-02-21 A |  | 100% |  |
| 373 |  | PIT Test Execution Progress Report | 50d | 2024-07-15 A | 2024-11-21 A | 365 | 100% | finish no earlier than 2024-11-21 |
| 374 |  | PIT Execution | 44d | 2024-07-12 A | 2024-11-29 A | 370FS+5d | 100% | finish no earlier than 2024-11-29 |
| 375 |  | SIT Non-Functional PIT Completion Report submitted to Programme for assurance | 0d | 2024-11-29 A | 2024-11-29 A | 373, 374 | 100% |  |
| 376 |  | SIT Non-Functional PIT Completion Report Theme 1 MHHS Review Completed | 0d | 2024-12-20 A | 2024-12-20 A | 363, 368, 371, 375FS+15d | 100% |  |
| 377 |  | SIT Non-Functional PIT Completion Report Theme 2 & 3 MHHS Review Completed | 0d | 2025-02-21 A | 2025-02-21 A | 363, 368, 371, 375FS+60d | 100% |  |
| 378 | 1.3.6.3.3.8 | **SIT Programme Participants PIT (SIT Operational Theme 1, 2, 3 (Batch 2))** | 146d | 2024-07-12 A | 2025-01-31 A |  | 100% |  |
| 379 | 1.3.6.3.3.8.1 | **Test Approach & Plan** | 40d | 2024-09-27 A | 2024-11-21 A |  | 100% |  |
| 380 |  | SIT Operational PIT Test Approach & Plan (PIT) submitted to Programme for assurance | 0d | 2024-09-27 A | 2024-09-27 A |  | 100% | start no earlier than 2024-09-27 |
| 381 |  | SIT Operational Test approach and plan MHHS Review Completed | 0d | 2024-11-21 A | 2024-11-21 A | 380FS+40d | 100% |  |
| 382 | 1.3.6.3.3.8.2 | **Test Readiness Report** | 13d | 2024-10-04 A | 2024-10-22 A |  | 100% |  |
| 383 |  | Test readiness reporting | 13d | 2024-10-04 A | 2024-10-22 A | 380FS+10d | 100% |  |
| 384 | 1.3.6.3.3.8.3 | **Requirements to test Traceability Matrix (RTTM)** | 20d | 2024-11-01 A | 2024-11-29 A |  | 100% |  |
| 385 |  | SIT Operational PIT RTTM submitted to Programme for assurance | 0d | 2024-11-01 A | 2024-11-01 A | 380FS+26d | 100% |  |
| 386 |  | SIT Operational RTTM MHHS Review Completed | 0d | 2024-11-29 A | 2024-11-29 A | 385FS+20d | 100% |  |
| 387 | 1.3.6.3.3.8.4 | **Test Scenarios** | 20d | 2024-11-01 A | 2024-11-29 A |  | 100% |  |
| 388 |  | SIT Operational PIT test scenarios submitted to Programme for assurance | 0d | 2024-11-01 A | 2024-11-01 A | 380FS+26d | 100% |  |
| 389 |  | SIT Operational Test scenarios MHHS Review Completed | 0d | 2024-11-29 A | 2024-11-29 A | 388FS+20d | 100% |  |
| 390 | 1.3.6.3.3.8.5 | **PIT execution** | 146d | 2024-07-12 A | 2025-01-31 A |  | 100% |  |
| 391 |  | PIT Test Execution Progress Report | 40d | 2024-07-15 A | 2024-11-21 A | 383 | 100% |  |
| 392 |  | PIT Execution | 39d | 2024-07-12 A | 2024-11-29 A | 388 | 100% |  |
| 393 |  | SIT Operational Theme 1, 2, 3 (Batch 2) PIT Completion Report submitted to Programme for assurance | 0d | 2025-01-14 A | 2025-01-14 A | 391, 392FS+32d | 100% |  |
| 394 |  | SIT Operational Theme 1, 2, 3 (Batch 2) PIT Completion Report MHHS Review Completed | 0d | 2025-01-31 A | 2025-01-31 A | 381, 386, 389, 393FS+13d | 100% |  |
| 395 | 1.3.6.3.3.9 | **SIT Programme Participants PIT (SIT Operational Theme 3 (Batch 1))** | 76d | 2024-09-27 A | 2025-01-10 A |  | 100% |  |
| 396 | 1.3.6.3.3.9.1 | **Test Approach & Plan** | 40d | 2024-09-27 A | 2024-11-21 A |  | 100% |  |
| 397 |  | SIT Operational PIT Test Approach& Plan (PIT) submitted to Programme for assurance | 0d | 2024-09-27 A | 2024-09-27 A |  | 100% | start no earlier than 2024-09-27 |
| 398 |  | SIT Operational Test approach and plan MHHS Review Completed | 0d | 2024-11-21 A | 2024-11-21 A | 397FS+40d | 100% |  |
| 399 | 1.3.6.3.3.9.2 | **Test Readiness Report** | 13d | 2024-10-04 A | 2024-10-22 A |  | 100% |  |
| 400 |  | Test readiness reporting | 13d | 2024-10-04 A | 2024-10-22 A | 397FS+5d | 100% |  |
| 401 | 1.3.6.3.3.9.3 | **Requirements to test Traceability Matrix (RTTM)** | 20d | 2024-11-01 A | 2024-11-29 A |  | 100% |  |
| 402 |  | SIT Operational PIT RTTM submitted to Programme for assurance | 0d | 2024-11-01 A | 2024-11-01 A | 397FS+26d | 100% |  |
| 403 |  | SIT Operational RTTM MHHS Review Completed | 0d | 2024-11-29 A | 2024-11-29 A | 402FS+20d | 100% |  |
| 404 | 1.3.6.3.3.9.4 | **Test Scenarios** | 20d | 2024-11-01 A | 2024-11-29 A |  | 100% |  |
| 405 |  | SIT Operational PIT test scenarios submitted to Programme for assurance | 0d | 2024-11-01 A | 2024-11-01 A | 397FS+26d | 100% |  |
| 406 |  | SIT Operational Test scenarios MHHS Review Completed | 0d | 2024-11-29 A | 2024-11-29 A | 405FS+20d | 100% |  |
| 407 | 1.3.6.3.3.9.5 | **PIT execution** | 58d | 2024-10-23 A | 2025-01-10 A |  | 100% |  |
| 408 |  | PIT Test Execution Progress Report | 40d | 2024-10-23 A | 2024-12-17 A | 400 | 100% |  |
| 409 |  | PIT Execution | 39d | 2024-11-04 A | 2024-12-26 A | 405 | 100% |  |
| 410 |  | SIT Operational Theme 3 (Batch 1) PIT Completion Report submitted to Programme for assurance | 0d | 2025-01-10 A | 2025-01-10 A | 391, 392FS+30d | 100% |  |
| 411 |  | SIT Operational Theme 3 (Batch 1) PIT Completion Report MHHS Review Completed | 0d | 2025-01-10 A | 2025-01-10 A | 415, 420, 423, 427, 410 | 100% |  |
| 412 | 1.3.6.3.4 | **All Suppliers DBT CIT (Entering at Interval 5)** | 71d | 2023-09-15 A | 2023-12-22 A |  | 100% |  |
| 413 | 1.3.6.3.4.1 | **Test Approach & Plan** | 20d | 2023-09-15 A | 2023-10-12 A |  | 100% |  |
| 414 |  | All SIT Suppliers Test Approach & Plans (PIT) submitted to Programme for assurance | 0d | 2023-09-15 A | 2023-09-15 A |  | 100% | start no earlier than 2023-09-15 |
| 415 |  | All SIT Suppliers Test Approach & Plans MHHS Review Completed | 0d | 2023-10-12 A | 2023-10-12 A | 414FS+20d | 100% |  |
| 416 | 1.3.6.3.4.2 | **Test Readiness Report** | 11d | 2023-09-29 A | 2023-10-13 A |  | 100% |  |
| 417 |  | Test readiness reporting | 11d | 2023-09-29 A | 2023-10-13 A | 414FS+10d | 100% |  |
| 418 | 1.3.6.3.4.3 | **Requirements to test Traceability Matrix (RTTM)** | 20d | 2023-10-06 A | 2023-11-03 A |  | 100% |  |
| 419 |  | All SIT Suppliers RTTMs submitted to Programme for assurance | 0d | 2023-10-06 A | 2023-10-06 A | 414FS+16d | 100% |  |
| 420 |  | All SIT Suppliers RTTMs MHHS Review Completed | 0d | 2023-11-03 A | 2023-11-03 A | 419FS+20d | 100% |  |

| ID | WBS | Task | Duration | Start | Finish | Predecessors | Complete | Constraint |
| --- | --- | --- | --- | --- | --- | --- | --- | --- |
| 421 | 1.3.6.3.4.4 | **Test Scenarios** | 20d | 2023-10-05 A | 2023-11-02 A |  | 100% |  |
| 422 |  | All SIT Suppliers test scenarios' submitted to Programme for assurance | 0d | 2023-10-05 A | 2023-10-05 A | 414FS+15d | 100% |  |
| 423 |  | All SIT Suppliers Test scenarios' MHHS Review Completed | 0d | 2023-11-02 A | 2023-11-02 A | 422FS+20d | 100% |  |
| 424 | 1.3.6.3.4.5 | **PIT execution** | 51d | 2023-10-13 A | 2023-12-22 A |  | 100% |  |
| 425 |  | PIT Test Execution Progress Report | 40d | 2023-10-16 A | 2023-12-08 A | 422FS+5d, 417 | 100% |  |
| 426 |  | PIT Execution | 41d | 2023-10-13 A | 2023-12-08 A | 422FS+5d | 100% |  |
| 427 |  | All SIT Suppliers PIT Completion Reports submitted to Programme for assurance | 0d | 2023-12-08 A | 2023-12-08 A | 426, 425 | 100% |  |
| 428 |  | All SIT Suppliers PIT Completion Reports MHHS Review Completed | 0d | 2023-12-22 A | 2023-12-22 A | 427FS+10d, 415, 420, 423 | 100% |  |
| 429 | 1.3.6.3.5 | **All LDSO Network Operations DBT CIT (Entering at Interval 5)** | 71d | 2023-09-15 A | 2023-12-22 A |  | 100% |  |
| 430 | 1.3.6.3.5.1 | **Test Approach & Plan** | 71d | 2023-09-15 A | 2023-12-22 A |  | 100% |  |
| 431 |  | All Network Operation Test Approach & Plans (PIT) submitted to Programme for assurance | 0d | 2023-09-15 A | 2023-09-15 A |  | 100% | start no earlier than 2023-09-15 |
| 432 |  | All Network Operation Test Approach & Plans MHHS Review Completed | 0d | 2023-10-12 A | 2023-10-12 A | 431FS+20d | 100% |  |
| 433 | 1.3.6.3.5.1.3 | **Test Readiness Report** | 11d | 2023-09-29 A | 2023-10-13 A |  | 100% |  |
| 434 |  | Test readiness reporting | 11d | 2023-09-29 A | 2023-10-13 A | 431FS+10d | 100% |  |
| 435 | 1.3.6.3.5.1.4 | **Requirements to test Traceability Matrix (RTTM)** | 20d | 2023-10-05 A | 2023-11-02 A |  | 100% |  |
| 436 |  | All Network Operation RTTMs submitted to Programme for assurance | 0d | 2023-10-05 A | 2023-10-05 A | 431FS+15d | 100% | start no earlier than 2023-04-28 |
| 437 |  | All Network Operation RTTMs MHHS Review Completed | 0d | 2023-11-02 A | 2023-11-02 A | 436FS+20d | 100% |  |
| 438 | 1.3.6.3.5.1.5 | **Test Scenarios** | 20d | 2023-10-05 A | 2023-11-02 A |  | 100% |  |
| 439 |  | All Network Operation test scenarios' submitted to Programme for assurance | 0d | 2023-10-05 A | 2023-10-05 A | 431FS+15d | 100% |  |
| 440 |  | All Network Operation test scenarios' MHHS Review Completed | 0d | 2023-11-02 A | 2023-11-02 A | 439FS+20d | 100% |  |
| 441 | 1.3.6.3.5.1.6 | **PIT execution** | 51d | 2023-10-13 A | 2023-12-22 A |  | 100% |  |
| 442 |  | PIT Test Execution Progress Report | 40d | 2023-10-16 A | 2023-12-08 A | 439FS+5d, 434 | 100% |  |
| 443 |  | PIT Execution | 41d | 2023-10-13 A | 2023-12-08 A | 439FS+5d | 100% |  |
| 444 |  | All Network Operation PIT (CIT interval 5) Completion Reports submitted to Programme for assurance | 0d | 2023-12-08 A | 2023-12-08 A | 443, 442 | 100% |  |
| 445 |  | All Network Operation PIT (CIT interval 5) Completion Reports MHHS Review Completed | 0d | 2023-12-22 A | 2023-12-22 A | 444FS+10d, 432, 437, 440 | 100% |  |
| 446 | 1.3.6.3.6 | **All UMSO DBT CIT (Entering at Interval 6)** | 81d | 2023-09-29 | 2024-01-19 A |  | 100% |  |
| 447 | 1.3.6.3.6.1 | **Test Approach & Plan** | 20d | 2023-10-13 A | 2023-11-09 A |  | 100% |  |
| 448 |  | All UMSO Test Approach & Plans (PIT) submitted to Programme for assurance | 0d | 2023-10-13 A | 2023-10-13 A |  | 100% | start no earlier than 2023-10-13 |
| 449 |  | All UMSO Test Approach & Plans MHHS Review Completed | 0d | 2023-11-09 A | 2023-11-09 A | 448FS+20d | 100% |  |
| 450 | 1.3.6.3.6.2 | **Test Readiness Report** | 11d | 2023-09-29 | 2023-10-13 |  | 100% |  |
| 451 |  | Test readiness reporting | 11d | 2023-10-27 A | 2023-11-10 A | 448FS+10d | 100% |  |
| 452 | 1.3.6.3.6.3 | **Requirements to test Traceability Matrix (RTTM)** | 20d | 2023-10-05 | 2023-11-01 |  | 100% |  |
| 453 |  | All UMSO RTTMs submitted to Programme for assurance | 0d | 2023-11-02 A | 2023-11-02 A | 448FS+15d | 100% |  |
| 454 |  | All UMSO RTTMs MHHS Review Completed | 0d | 2023-11-30 A | 2023-11-30 A | 453FS+20d | 100% |  |
| 455 | 1.3.6.3.6.4 | **Test Scenarios** | 20d | 2023-10-05 | 2023-11-01 |  | 100% |  |
| 456 |  | All UMSO test scenarios' submitted to Programme for assurance | 0d | 2023-11-02 A | 2023-11-02 A | 448FS+15d | 100% |  |
| 457 |  | All UMSO Test scenarios' MHHS Review Completed | 0d | 2023-11-30 A | 2023-11-30 A | 456FS+20d | 100% |  |
| 458 | 1.3.6.3.6.5 | **PIT execution** | 51d | 2023-11-10 A | 2024-01-19 A |  | 100% |  |
| 459 |  | PIT Test Execution Progress Report | 40d | 2023-11-13 A | 2024-01-05 A | 456FS+5d, 451 | 100% |  |
| 460 |  | PIT Execution | 40d | 2023-11-10 A | 2024-01-04 A | 456FS+5d | 100% |  |
| 461 |  | All UMSO PIT (CIT interval 6) Completion Reports submitted to Programme for assurance | 0d | 2024-01-05 A | 2024-01-05 A | 460, 459 | 100% |  |
| 462 |  | All UMSO PIT (CIT interval 6) Completion Reports MHHS Review Completed | 0d | 2024-01-19 A | 2024-01-19 A | 449, 454, 457, 461FS+10d | 100% |  |
| 463 | 1.3.7 | **DBT Monitoring and Assurance** | 723d | 2022-10-31 A | 2025-08-06 A |  | 100% |  |
| 464 | 1.3.7.1 | **Planning and DBT Progress Monitoring of PPs** | 696d | 2022-10-31 A | 2025-06-30 A |  | 100% |  |
| 465 |  | Monitor Non-SIT PPs Planning and DBT1 progress (to inform confirmation of Qualification Testing Tranche participants milestones) | 696d | 2022-10-31 A | 2025-06-30 A | 193SS | 100% |  |
| 466 | 1.3.7.2 | **Design Assurance** | 713d | 2022-11-14 A | 2025-08-06 A |  | 100% |  |
| 467 | 1.3.7.2.1 | **Design Assurance Readiness Assessment Preparation** | 39d | 2023-02-28 A | 2023-04-21 A |  | 100% |  |
| 468 |  | Set up FTIG | 15d | 2023-04-03 A | 2023-04-21 A |  | 100% | must start on 2023-04-03 |
| 469 |  | Produce Draft Questions | 10d | 2023-02-28 A | 2023-03-13 A |  | 100% | must start on 2023-02-28 |
| 470 |  | Pilot with SRO | 1d | 2023-03-14 A | 2023-03-14 A | 469 | 100% |  |
| 471 |  | Finalise questions | 10d | 2023-03-15 A | 2023-03-28 A | 470 | 100% |  |
| 472 |  | Prepare on-line RA tooling | 10d | 2023-03-29 A | 2023-04-11 A | 471 | 100% |  |
| 473 |  | Prepare webinar content | 5d | 2023-03-20 A | 2023-03-24 A | 469FS+4d | 100% |  |
| 474 |  | Conduct webinar | 1d | 2023-03-30 A | 2023-03-30 A | 473FS+3d | 100% |  |
| 475 | 1.3.7.2.2 | **Participant Design Assurance Approach** | 43d | 2022-11-14 A | 2023-01-11 A |  | 100% |  |
| 476 |  | Develop document | 20d | 2022-11-14 A | 2022-12-09 A | 47FS+10d | 100% | start no earlier than 2022-11-14 |
| 477 |  | Review document | 18d | 2022-12-12 A | 2023-01-04 A | 476 | 100% |  |
| 478 |  | Participant Design Assurance Approach approved | 0d | 2023-01-11 A | 2023-01-11 A | 477FF+5d | 100% |  |
| 479 | 1.3.7.2.3 | **Phase 1 - SIT Volunteers (Core Providers)** | 145d | 2023-04-10 A | 2023-10-27 A |  | 100% |  |
| 480 |  | Send on-line questionnaire to core capability providers and current SIT volunteers (from Round 3 consultation) | 1d | 2023-04-10 A | 2023-04-10 A |  | 100% | must start on 2023-04-10 |
| 481 |  | Participants Provide Responses to questionnaires | 15d | 2023-04-11 A | 2023-05-01 A | 480 | 100% |  |
| 482 |  | Assess on-line responses and provided evidence | 5d | 2023-05-02 A | 2023-05-08 A | 481 | 100% |  |
| 483 |  | Bi-lateral meeting with each responder, to walk and navigate through provided materials | 31d | 2023-05-09 A | 2023-06-20 A | 482 | 100% |  |
| 484 |  | Plan for, create and execute deep dive assurance interviews based on agreed priorities (participants, design areas) | 62d | 2023-06-07 A | 2023-08-31 A | 483FS-10d | 100% |  |
| 485 |  | SI endorsement of participants’ design – assurance reports | 43d | 2023-08-02 A | 2023-09-29 A | 484FS-22d | 100% |  |
| 486 |  | Post-assurance review of recommendations take-up by assured participants | 44d | 2023-08-29 A | 2023-10-27 A | 485SS+19d | 100% |  |
| 487 |  | Phase 1 - SIT Volunteers (Core Providers) complete | 0d | 2023-10-27 A | 2023-10-27 A | 486 | 100% |  |
| 488 | 1.3.7.2.4 | **Phase 2 - SIT all other participants** | 143d | 2023-05-08 A | 2023-11-22 A |  | 100% |  |
| 489 |  | Send on-line questionnaire to core capability providers and current SIT volunteers (from Round 3 consultation) | 1d | 2023-05-08 A | 2023-05-08 A |  | 100% | must start on 2023-05-08 |
| 490 |  | Participants Provide Responses to questionnaires | 15d | 2023-05-09 A | 2023-05-29 A | 489 | 100% |  |

| ID | WBS | Task | Duration | Start | Finish | Predecessors | Complete | Constraint |
| --- | --- | --- | --- | --- | --- | --- | --- | --- |
| 491 |  | Assess on-line responses and provided evidence | 5d | 2023-05-30 A | 2023-06-05 A | 490 | 100% |  |
| 492 |  | Bi-lateral meeting with each responder, to walk and navigate through provided materials | 84d | 2023-06-06 A | 2023-09-29 A | 491 | 100% |  |
| 493 |  | Plan for, create and execute deep dive assurance interviews based on agreed priorities (participants, design areas) | 69d | 2023-06-27 A | 2023-09-29 A | 492SS+15d | 100% |  |
| 494 |  | SI endorsement of participants’ design – assurance reports | 54d | 2023-07-18 A | 2023-09-29 A | 493SS+15d | 100% |  |
| 495 |  | Post-assurance review of recommendations take-up by assured participants | 73d | 2023-08-14 A | 2023-11-22 A | 494SS+19d | 100% |  |
| 496 |  | SIT PPs design assurance (excl Migration/Reverse Migration) complete | 0d | 2023-11-22 A | 2023-11-22 A | 495 | 100% |  |
| 497 | 1.3.7.2.5 | **Non-SIT PPs design assurance** | 445d | 2023-11-23 A | 2025-08-06 A |  | 100% |  |
| 498 |  | Non-SIT PPs design assurance (risk-based sample) | 445d | 2023-11-23 A | 2025-08-06 A | 496 | 100% |  |
| 499 | 1.3.7.3 | **Test Assurance** | 629d | 2023-02-01 A | 2025-06-30 A |  | 100% |  |
| 500 |  | Non-SIT PPs test assurance | 629d | 2023-02-01 A | 2025-06-30 A |  | 100% |  |
| 501 | 1.3.7.4 | **Pre-Qualification Guidance (PIT Guidance)** | 67d | 2022-10-31 A | 2023-01-31 A |  | 100% |  |
| 502 |  | Develop document (incl. collaboration with code bodies, as required) | 56d | 2022-10-31 A | 2023-01-16 A |  | 100% |  |
| 503 |  | Review, update and agree Pre-Qualification Guidance internally | 11d | 2023-01-17 A | 2023-01-31 A | 502 | 100% |  |
| 504 | 1.3.7.5 | **External Programme Dependency Management** | 0d | 2022-11-03 A | 2022-11-03 A |  | 100% |  |
| 505 | 1.3.7.5.1 | **SLC47** | 0d | 2022-11-03 A | 2022-11-03 A |  | 100% |  |
| 506 |  | SLC47 implementation date | 0d | 2022-11-03 A | 2022-11-03 A |  | 100% | start no earlier than 2022-11-03 |
| 507 | 1.4 | **SYSTEMS INTEGRATION TESTING (SIT)** | 910d? | 2022-10-31 A | 2026-04-24 |  | 98% |  |
| 508 | 1.4.1 | **SIT Preparation** | 670d? | 2022-10-31 A | 2025-05-23 A |  | 100% |  |
| 509 | 1.4.1.1 | **Test Artefact Development** | 472d | 2022-10-31 A | 2024-08-21 A |  | 100% |  |
| 510 | 1.4.1.1.1 | **Environment Approach & Plan** | 460d | 2022-11-16 A | 2024-08-21 A |  | 100% |  |
| 511 |  | Environment Approach & Plan approved | 0d | 2022-11-16 A | 2022-11-16 A |  | 100% | start no earlier than 2022-11-16 |
| 512 |  | Environment Approach & Plan - Work Off | 157d | 2022-11-17 A | 2023-06-23 A | 511FS+1d | 100% |  |
| 513 |  | Environment Approach & Plan - Work Off Approved | 0d | 2023-08-16 A | 2023-08-16 A | 512FS+5d | 100% | start no earlier than 2023-08-16 |
| 514 |  | Environment Approach and Plan - SIT Functional | 0d | 2023-11-20 A | 2023-11-20 A |  | 100% | start no earlier than 2023-11-20 |
| 515 |  | Define Approach to Simulator for Non-SIT LDSO | 0d | 2023-11-15 A | 2023-11-15 A |  | 100% | start no earlier than 2023-11-15 |
| 516 |  | Environment Approach and Plan - Non SIT LDSO Testing | 0d | 2024-04-17 A | 2024-04-17 A |  | 100% | start no earlier than 2024-04-17 |
| 517 |  | Environment Approach and Plan - S and A Testing | 0d | 2024-07-17 A | 2024-07-17 A |  | 100% | start no earlier than 2024-07-17 |
| 518 |  | Environment Approach and Plan - SIT Non Functional | 0d | 2024-06-19 A | 2024-06-19 A |  | 100% | start no earlier than 2024-06-19 |
| 519 |  | Environment Approach and Plan - Sandbox | 0d | 2024-08-21 A | 2024-08-21 A |  | 100% | start no earlier than 2024-08-21 |
| 520 | 1.4.1.1.2 | **Overarching Test Scope (for all stages)** | 65d | 2022-10-31 A | 2023-01-27 A |  | 100% |  |
| 521 | 1.4.1.1.2.1 | **Overarching Test Scope (excl. Migration/Reverse Migration, NFT and Ops components)** | 65d | 2022-10-31 A | 2023-01-27 A |  | 100% |  |
| 522 |  | Develop document (excl Migration/Reverse Migration, NFT and Ops components) | 55d | 2022-10-31 A | 2023-01-13 A | 47 | 100% |  |
| 523 |  | Review, update & agree document (excl Migration/Reverse Migration, NFT and Ops components) | 10d | 2023-01-16 A | 2023-01-27 A | 522 | 100% |  |
| 524 | 1.4.1.1.3 | **Configuration and Release Management Approach & Plan** | 164d | 2022-11-01 A | 2023-06-16 A |  | 100% |  |
| 525 |  | Develop document | 69d | 2022-11-01 A | 2023-06-16 A |  | 100% | start no earlier than 2022-11-01 |
| 526 |  | Review, update and agree Configuration and Release Management Approach & Plan internally | 63d | 2023-02-01 A | 2023-04-28 A | 525 | 100% |  |
| 527 | 1.4.1.1.4 | **Test Data Overarching Approach & Plan** | 179d | 2022-11-14 A | 2023-07-20 A |  | 100% |  |
| 528 |  | Develop document | 20d | 2022-11-14 A | 2022-12-09 A |  | 100% | start no earlier than 2022-11-14 |
| 529 |  | Document review and update | 155d | 2022-12-12 A | 2023-07-14 A | 528 | 100% |  |
| 530 |  | Test Data Overarching Approach & Plan approved by TMAG | 0d | 2023-07-19 A | 2023-07-19 A | 529FS+3d | 100% |  |
| 531 |  | Document publication final version | 1d | 2023-07-20 A | 2023-07-20 A | 530 | 100% |  |
| 532 | 1.4.1.1.5 | **Interface Code of Connection (dates subject to DIP Service Provider's plan)** | 48d | 2023-03-01 A | 2023-05-05 A |  | 100% |  |
| 533 |  | Develop Interface Code of Connection with DIP Service Provider | 43d | 2023-03-01 A | 2023-04-28 A |  | 100% | must start on 2023-03-01 |
| 534 |  | Interface Code of Connection approved at SDWG | 0d | 2023-05-05 A | 2023-05-05 A | 533FS+5d | 100% |  |
| 535 | 1.4.1.1.6 | **Test Traceability** | 165d | 2023-06-01 A | 2024-01-17 A |  | 100% |  |
| 536 |  | RTM containing Method Statement Implied Requirements into Azure DevOps | 22d | 2023-06-01 A | 2023-06-30 A |  | 100% | must start on 2023-06-01 |
| 537 |  | RTM Containing Interface Catalogue Implied Requirements | 27d | 2023-06-01 A | 2023-07-07 A |  | 100% | must start on 2023-06-01 |
| 538 |  | SIT CIT Full Traceability & Coverage complete | 118d | 2023-07-10 A | 2023-12-20 A | 537, 536 | 100% |  |
| 539 |  | SIT Functional Full Traceability & Coverage complete | 138d | 2023-07-10 A | 2024-01-17 A | 537, 536 | 100% |  |
| 540 | 1.4.1.2 | **Test Tool Development** | 256d? | 2022-10-31 A | 2023-10-23 A |  | 100% |  |
| 541 | 1.4.1.2.1 | **Test Management Tool** | 256d | 2022-10-31 A | 2023-10-23 A |  | 100% |  |
| 542 | 1.4.1.2.1.1 | **Test Management Tool Implementation** | 256d | 2022-10-31 A | 2023-10-23 A |  | 100% |  |
| 543 |  | Requirements identification | 40d | 2022-10-31 A | 2022-12-23 A |  | 100% |  |
| 544 |  | Development | 125d | 2023-01-02 A | 2023-06-23 A | 543FS+5d | 100% |  |
| 545 |  | Testing | 125d | 2023-01-02 A | 2023-06-23 A | 544FF | 100% |  |
| 546 |  | Accept tool | 0d | 2023-06-23 A | 2023-06-23 A | 545FF | 100% |  |
| 547 |  | Implementation | 1d | 2023-10-23 A | 2023-10-23 A | 546FS+85d | 100% |  |
| 548 | 1.4.1.2.1.2 | **Test Management Tool User Guide** | 115d | 2023-01-02 A | 2023-06-09 A |  | 100% |  |
| 549 |  | Develop document | 100d | 2023-01-02 A | 2023-05-19 A | 544SS, 545SS | 100% | start no earlier than 2023-01-02 |
| 550 |  | Review, update and agree Test Management Tool User Guide internally | 15d | 2023-05-22 A | 2023-06-09 A | 549 | 100% |  |
| 551 | 1.4.1.2.1.3 | **Test Management Tool Configuration Guide** | 60d | 2023-01-02 A | 2023-03-24 A |  | 100% |  |
| 552 |  | Develop document | 45d | 2023-01-02 A | 2023-03-03 A | 543 | 100% | start no earlier than 2023-01-02 |
| 553 |  | Review, update and agree Test Management Tool Configuration Guide internally | 15d | 2023-03-06 A | 2023-03-24 A | 552 | 100% |  |
| 554 | 1.4.1.2.2 | **Secure Volunteer SIT Participants** | 163d? | 2023-01-31 A | 2023-09-14 A |  | 100% |  |
| 555 |  | PPs decide whether to volunteer to participate in SIT and inform Programme of decision via Round 3 Replan consultation | 1d? | 2023-01-31 A | 2023-01-31 A |  | 100% | finish no earlier than 2023-01-31 |
| 556 |  | Assurance of SIT volunteers' plans (submitted via Round 3 Replan Consultation) | 1d? | 2023-02-14 A | 2023-02-14 A |  | 100% | finish no earlier than 2023-02-14 |
| 557 |  | SIT Participant Volunteers Identified | 1d? | 2023-02-14 A | 2023-02-14 A |  | 100% | start no earlier than 2023-02-14 |
| 558 |  | Engagement with SIT volunteers | 1d? | 2023-05-23 A | 2023-05-23 A |  | 100% | finish no earlier than 2023-05-23 |
| 559 |  | SIT Participants Agreed | 1d? | 2023-05-23 A | 2023-05-23 A |  | 100% | start no earlier than 2023-05-23 |
| 560 | 1.4.1.2.2.6 | **Data Protection Impact Assessment (DPIA)** | 11d? | 2023-06-30 A | 2023-07-14 A |  | 100% |  |

| ID | WBS | Task | Duration | Start | Finish | Predecessors | Complete | Constraint |
| --- | --- | --- | --- | --- | --- | --- | --- | --- |
| 561 |  | Conduct DPIA on Overall Test Data Approach | 1d? | 2023-06-30 A | 2023-06-30 A |  | 100% | finish no earlier than 2023-06-30 |
| 562 |  | Revise Overarching Test Data Approach& plan for DPIA (if required), including engagement with DWG | 1d? | 2023-07-13 A | 2023-07-13 A |  | 100% | finish no earlier than 2023-07-13 |
| 563 |  | Review (internal), update and approve revised Overarching Test Data Approach& Plan (if required) | 1d? | 2023-07-14 A | 2023-07-14 A |  | 100% | start no earlier than 2023-07-14 |
| 564 | 1.4.1.2.2.7 | **Data Sharing Agreements** | 30d? | 2023-08-04 A | 2023-09-14 A |  | 100% |  |
| 565 |  | Produce Data Sharing Agreement for Industry Review | 1d? | 2023-08-04 A | 2023-08-04 A |  | 100% | finish no earlier than 2023-08-04 |
| 566 |  | Manage Participant Queries and Contract Agreement Execution | 1d? | 2023-09-14 A | 2023-09-14 A |  | 100% | finish no earlier than 2023-09-14 |
| 567 |  | Data Sharing Agreements Complete | 1d? | 2023-09-14 A | 2023-09-14 A |  | 100% | start no earlier than 2023-09-14 |
| 568 | 1.4.1.2.2.8 | **Production Data Cut & Data Obfuscation** | 55d? | 2023-06-19 A | 2023-09-01 A |  | 100% |  |
| 569 | 1.4.1.2.2.8.1 | **SI Data Cut Preparation& Infrastructure** | 45d? | 2023-06-19 A | 2023-08-18 A |  | 100% |  |
| 570 |  | SI Data Cut Planning activities (incl. pre-cut and post-cut cleansing and population approach) | 1d? | 2023-06-19 A | 2023-06-19 A |  | 100% | finish no earlier than 2023-06-19 |
| 571 |  | Set up SI database and transmission structure | 1d? | 2023-08-17 A | 2023-08-17 A |  | 100% | finish no earlier than 2023-08-17 |
| 572 |  | Mechanism for transfer of data in place | 1d? | 2023-08-18 A | 2023-08-18 A |  | 100% | start no earlier than 2023-08-18 |
| 573 |  | SI Data Cut Preparation& Infrastructure Complete | 1d? | 2023-08-18 A | 2023-08-18 A |  | 100% | start no earlier than 2023-08-18 |
| 574 | 1.4.1.2.2.8.2 | **Production Data Cut** | 55d? | 2023-06-19 A | 2023-09-01 A |  | 100% |  |
| 575 |  | Notification of Production Data Cut issued to relevant participants | 1d? | 2023-06-19 A | 2023-06-19 A |  | 100% | start no earlier than 2023-06-19 |
| 576 |  | Coordinate relevant participants taking data cut from production systems | 1d? | 2023-08-11 A | 2023-08-11 A |  | 100% | finish no earlier than 2023-08-11 |
| 577 |  | Production data cut GONG decision | 1d? | 2023-08-16 A | 2023-08-16 A |  | 100% | start no earlier than 2023-08-16 |
| 578 |  | Relevant participants take data cut from production systems (Saturday 19 August) | 1d? | 2023-08-21 A | 2023-08-21 A |  | 100% | start no earlier than 2023-08-21 |
| 579 |  | EES transmit request data to SI | 1d? | 2023-08-25 A | 2023-08-25 A |  | 100% | finish no earlier than 2023-08-25 |
| 580 |  | Check data alignment and integrity of data cut | 1d? | 2023-09-01 A | 2023-09-01 A |  | 100% | finish no earlier than 2023-09-01 |
| 581 |  | Data cut from relevant participants' production systems completed (Saturday 19 August) | 1d? | 2023-08-21 A | 2023-08-21 A |  | 100% | start no earlier than 2023-08-21 |
| 582 |  | Production Data Cut Complete | 1d? | 2023-08-21 A | 2023-08-21 A |  | 100% | start no earlier than 2023-08-21 |
| 583 | 1.4.1.3 | **SIT Participation** | 147d | 2022-10-31 A | 2023-05-23 A |  | 100% |  |
| 584 |  | PPs decide whether to volunteer to participate in SIT and inform Programme of decision via Round 3 Replan consultation | 67d | 2022-10-31 A | 2023-01-31 A | 34FF | 100% |  |
| 585 |  | Assurance of SIT volunteers' plans (submitted via Round 3 Replan Consultation) | 10d | 2023-02-01 A | 2023-02-14 A | 584, 34 | 100% |  |
| 586 |  | SIT Participant Volunteers Identified | 0d | 2023-02-14 A | 2023-02-14 A | 585FF | 100% |  |
| 587 |  | Engagement with SIT volunteers | 147d | 2022-10-31 A | 2023-05-23 A |  | 100% |  |
| 588 |  | SIT Participants Agreed | 0d | 2023-05-23 A | 2023-05-23 A | 587, 622FS-74d | 100% |  |
| 589 | 1.4.1.4 | **SIT Stage-Specific Preparation** | 670d? | 2022-10-31 A | 2025-05-23 A |  | 100% |  |
| 590 | 1.4.1.4.1 | **SIT Component Integration Preparation** | 320d | 2022-10-31 A | 2024-01-19 A |  | 100% |  |
| 591 | 1.4.1.4.1.1 | **Test Approach & Plan** | 188d | 2022-10-31 A | 2023-07-19 A |  | 100% |  |
| 592 |  | Develop document with SITWG | 159d | 2022-10-31 A | 2023-06-08 A |  | 100% |  |
| 593 |  | Industry consultation | 10d | 2023-06-09 A | 2023-06-22 A | 592 | 100% |  |
| 594 |  | Artefact review (via TMAG) and updates | 19d | 2023-06-23 A | 2023-07-19 A | 593 | 100% | finish no earlier than 2023-07-06 |
| 595 |  | SIT Component Integration Testing Test Approach & Plan approved | 0d | 2023-07-19 A | 2023-07-19 A | 594 | 100% | finish no earlier than 2023-07-19 |
| 596 | 1.4.1.4.1.2 | **Test Data Approach & Plan** | 29d | 2023-06-09 A | 2023-07-19 A |  | 100% |  |
| 597 |  | Industry consultation | 10d | 2023-06-09 A | 2023-06-22 A | 593SS | 100% |  |
| 598 |  | Artefact review (via TMAG) and updates | 19d | 2023-06-23 A | 2023-07-19 A | 597 | 100% |  |
| 599 |  | SIT Component Integration Testing Test Data Approach & Plan approved | 0d | 2023-07-19 A | 2023-07-19 A | 598 | 100% |  |
| 600 | 1.4.1.4.1.3 | **Test scenarios** | 173d | 2023-01-02 A | 2023-08-30 A |  | 100% |  |
| 601 |  | Development of test scenarios | 0d | 2023-01-02 A | 2023-01-02 A | 592SS+45d | 100% |  |
| 602 |  | Review test scenarios with SIT Working Group | 11d | 2023-02-01 A | 2023-02-15 A | 601SS+22d | 100% |  |
| 603 |  | SIT Component Integration Testing Test scenarios approved | 0d | 2023-08-30 A | 2023-08-30 A | 602FS+15d | 100% |  |
| 604 | 1.4.1.4.1.4 | **Test cases** | 160d | 2023-05-01 A | 2023-12-08 A |  | 100% |  |
| 605 | 1.4.1.4.1.4.1 | **SI Test cases** | 160d | 2023-05-01 A | 2023-12-08 A |  | 100% |  |
| 606 | 1.4.1.4.1.4.1.1 | **Batch 1 (CIT Intervals 1 and 2)** | 110d | 2023-05-01 A | 2023-09-29 A |  | 100% |  |
| 607 |  | Develop Test cases | 100d | 2023-05-01 A | 2023-09-15 A | 601 | 100% |  |
| 608 |  | Review Test cases with SIT Working Group | 9d | 2023-09-18 A | 2023-09-28 A | 607 | 100% |  |
| 609 |  | SIT Component Integration Testing Test cases Batch 1 (CIT Intervals 1 and 2) approved at ETMAG | 0d | 2023-09-29 A | 2023-09-29 A | 608FS+1d | 100% |  |
| 610 | 1.4.1.4.1.4.1.2 | **Batch 2 (CIT Intervals 3 and 4)** | 25d | 2023-10-02 A | 2023-11-03 A |  | 100% |  |
| 611 |  | Develop Test cases | 15d | 2023-10-02 A | 2023-10-20 A | 609 | 100% |  |
| 612 |  | Review Test cases with SIT Working Group | 9d | 2023-10-23 A | 2023-11-02 A | 611 | 100% |  |
| 613 |  | SIT Component Integration Testing Test cases Batch 2 (CIT Intervals 3 and 4) approved at ETMAG | 0d | 2023-11-03 A | 2023-11-03 A | 612FS+1d | 100% |  |
| 614 | 1.4.1.4.1.4.1.3 | **Batch 3 (CIT Intervals 5 and 6)** | 25d | 2023-11-03 A | 2023-12-08 A |  | 100% |  |
| 615 |  | Develop Test cases | 15d | 2023-11-03 A | 2023-11-24 A | 613 | 100% |  |
| 616 |  | Review Test cases with SIT Working Group | 9d | 2023-11-27 A | 2023-12-07 A | 615 | 100% |  |
| 617 |  | SIT Component Integration Testing Test cases Batch 3 (CIT Intervals 5 and 6) approved at ETMAG | 0d | 2023-12-08 A | 2023-12-08 A | 616FS+1d | 100% |  |
| 618 | 1.4.1.4.1.5 | **CIT Interval 1 Preparation** | 283d | 2022-11-16 A | 2023-12-15 A |  | 100% |  |
| 619 | 1.4.1.4.1.5.1 | **Environments (SIT A)** | 246d | 2022-11-16 A | 2023-10-25 A |  | 100% |  |
| 620 |  | PPs register PKI Officers and request PKI certificates | 5d | 2023-10-09 A | 2023-10-13 A |  | 100% | start no earlier than 2023-10-09 |
| 621 |  | PPs register PKI Officers and request PKI certificates Complete - Interval 1 | 0d | 2023-10-25 A | 2023-10-25 A | 620FS+8d | 100% |  |
| 622 |  | PP SIT A environment preparation (incl. security certificates and security compliance) | 238d | 2022-11-16 A | 2023-10-13 A | 511 | 100% |  |
| 623 |  | SI coordinate SIT Participants' SIT A environment preparation | 238d | 2022-11-16 A | 2023-10-13 A | 622SS | 100% |  |
| 624 |  | PP submit self-declaration of environment preparation complete (incl. security certificates and security compliance) to Programme for assurance | 0d | 2023-10-13 A | 2023-10-13 A | 622FF | 100% | start no earlier than 2023-10-13 |
| 625 |  | SI assure PPs' self-declaration of environment preparation complete (incl. security certificates and security compliance) | 5d | 2023-10-16 A | 2023-10-20 A | 624FF+5d | 100% |  |
| 626 |  | SIT Participants' SIT A environments ready to start connectivity proving CIT Interval 1 | 0d | 2023-09-01 A | 2023-09-01 A | 624SS | 100% |  |
| 627 |  | PP SIT A environment connectivity proving | 10d | 2023-09-04 A | 2023-09-15 A | 626 | 100% |  |
| 628 |  | SI coordinate SIT Participants' SIT A environment connectivity proving | 10d | 2023-09-04 A | 2023-09-15 A | 627SS | 100% |  |
| 629 |  | PP deployment of MHHS solution code to SIT A environments | 10d | 2023-09-25 A | 2023-10-06 A | 670FF | 100% |  |
| 630 |  | SI coordinate deployment of MHHS solution code to SIT Participants' SIT A environments | 10d | 2023-09-25 A | 2023-10-06 A | 670FF | 100% |  |

| ID | WBS | Task | Duration | Start | Finish | Predecessors | Complete | Constraint |
| --- | --- | --- | --- | --- | --- | --- | --- | --- |
| 631 |  | PP submit evidence of SIT A environment connectivity proving and code deployment completion to Programme for assurance | 30d | 2023-09-04 A | 2023-10-13 A | 627SS | 100% |  |
| 632 |  | SI assurance of SIT Participants' SIT A environment connectivity proving and code deployment completion | 25d | 2023-09-18 A | 2023-10-20 A | 631FF+5d | 100% |  |
| 633 | 1.4.1.4.1.5.2 | **Test Data - ISD Creation** | 9d | 2023-08-22 A | 2023-09-01 A |  | 100% |  |
| 634 |  | Set-up Market Participants and DIP ID Data | 8d | 2023-08-22 A | 2023-08-31 A |  | 100% |  |
| 635 |  | Distribute ISD Data to Participants | 1d | 2023-09-01 A | 2023-09-01 A | 634 | 100% |  |
| 636 |  | Test Data - ISD Creation Complete | 0d | 2023-09-01 A | 2023-09-01 A | 635 | 100% |  |
| 637 | 1.4.1.4.1.5.3 | **Test Data - SFTP Onboarding** | 70d | 2023-08-21 A | 2023-11-24 A |  | 100% |  |
| 638 |  | Create Containers and Keys for Participants | 3d | 2023-08-21 A | 2023-08-23 A |  | 100% |  |
| 639 |  | Share SFTP Access with Participants | 5d | 2023-08-24 A | 2023-08-30 A | 638 | 100% |  |
| 640 |  | Test SFTP Connectivity | 5d | 2023-08-31 A | 2023-09-06 A | 639 | 100% |  |
| 641 |  | Test Data - SFTP Onboarding Complete | 0d | 2023-11-24 A | 2023-11-24 A | 640FS+57d | 100% |  |
| 642 | 1.4.1.4.1.5.4 | **Test Data - Provide Sample Files** | 10d | 2023-08-21 A | 2023-09-01 A |  | 100% |  |
| 643 |  | Generate Sample Files off IF Messages | 8d | 2023-08-21 A | 2023-08-30 A |  | 100% |  |
| 644 |  | Transmit Sample Files off IF Messages to Participants (More detail needs to be planned for a POC) | 2d | 2023-08-31 A | 2023-09-01 A | 643 | 100% |  |
| 645 |  | Test Data - Provide Sample Files Complete | 0d | 2023-09-01 A | 2023-09-01 A | 644 | 100% |  |
| 646 | 1.4.1.4.1.5.5 | **Test Data - Detailed SIT Data Load Guidance** | 65d | 2023-09-07 A | 2023-12-06 A |  | 100% |  |
| 647 |  | Document Guidance | 21d | 2023-09-07 A | 2023-10-05 A | 645FS+3d | 100% |  |
| 648 |  | Provide Guidance to PPs | 1d | 2023-10-06 A | 2023-10-06 A | 647 | 100% |  |
| 649 |  | Test Data - Detailed SIT Functional Data Load Guidance Complete | 0d | 2023-12-06 A | 2023-12-06 A | 648FS+43d | 100% |  |
| 650 | 1.4.1.4.1.5.6 | **Test Data - Population of Data Items for Testing Guidance - Draft** | 80d | 2023-08-17 A | 2023-12-06 A |  | 100% |  |
| 651 |  | Document Guidance - Draft | 11d | 2023-08-17 A | 2023-08-31 A | 840 | 100% |  |
| 652 |  | Provide Guidance to PPs - Draft | 1d | 2023-09-01 A | 2023-09-01 A | 651 | 100% |  |
| 653 |  | Test Data - Population of Data Items for Testing Guidance - Draft Complete | 0d | 2023-12-06 A | 2023-12-06 A | 652FS+68d | 100% |  |
| 654 | 1.4.1.4.1.5.7 | **Test Data - Population of Data Items for Testing Guidance - Final** | 87d | 2023-08-17 A | 2023-12-15 A |  | 100% |  |
| 655 |  | Update Document Guidance With PPS Feedback | 81d | 2023-08-17 A | 2023-12-07 A | 651SS | 100% |  |
| 656 |  | Provide Final Guidance to PPs | 1d | 2023-12-08 A | 2023-12-08 A | 655 | 100% |  |
| 657 |  | Test Data - Population of Data Items for Testing Guidance - Final Complete | 0d | 2023-12-15 A | 2023-12-15 A | 656FS+5d | 100% |  |
| 658 | 1.4.1.4.1.5.8 | **Test Data (SIT A) Interval 1** | 40d | 2023-09-04 A | 2023-10-27 A |  | 100% |  |
| 659 |  | Run data allocation | 4d | 2023-09-04 A | 2023-09-07 A | 599, 636 | 100% |  |
| 660 |  | Cleanse, anonymise and populate data post cut | 4d | 2023-09-08 A | 2023-09-13 A | 659 | 100% |  |
| 661 |  | Transmit data sets to PPs | 3d | 2023-09-15 A | 2023-09-19 A | 660 | 100% |  |
| 662 |  | PP - Load test data to test environments | 7d | 2023-09-20 A | 2023-09-28 A | 661, 645 | 100% |  |
| 663 |  | PP Check data integrity on test environment | 1d | 2023-09-29 A | 2023-09-29 A | 662 | 100% |  |
| 664 |  | PP submit self-declaration to Programme to confirm loading & verification of test data | 0d | 2023-09-29 A | 2023-09-29 A | 663FF | 100% |  |
| 665 |  | Test Data (SIT A) Interval 1 Complete | 0d | 2023-10-27 A | 2023-10-27 A | 664FS+20d | 100% |  |
| 666 | 1.4.1.4.1.5.9 | **Other Preparation** | 45d | 2023-07-03 A | 2023-09-01 A |  | 100% |  |
| 667 |  | Onboarding of Test Participants to Test Management Tool (Azure DevOps) | 45d | 2023-07-03 A | 2023-09-01 A | 626SF | 100% |  |
| 668 |  | Test Management Tool onboarding | 45d | 2023-07-03 A | 2023-09-01 A | 626SF | 100% |  |
| 669 | 1.4.1.4.1.5.10 | **SIT Component Integration Test Readiness Report** | 28d | 2023-09-14 A | 2023-10-23 A |  | 100% |  |
| 670 |  | PP submit Test Readiness Report to Programme for assurance | 0d | 2023-10-20 A | 2023-10-20 A | 668, 609, 665 | 100% | start no earlier than 2023-10-09 |
| 671 |  | SI assure Test Participants' Test Readiness Reports | 1d | 2023-10-23 A | 2023-10-23 A | 670SS | 100% |  |
| 672 |  | SI develop Overarching SIT Component Integration Test Readiness Report | 23d | 2023-09-14 A | 2023-10-16 A | 595FS+40d | 100% |  |
| 673 |  | Artefact review (via TMAG) and updates | 4d | 2023-10-17 A | 2023-10-20 A | 672 | 100% |  |
| 674 |  | SIT Component Integration Testing 1 Preparation Complete (incl. approval of SI SIT Component Integration Test Readiness Report) | 0d | 2023-10-27 A | 2023-10-27 A | 673FS+1d, 670, 626, 668, 665, 227, 232, 221, 241, 242, 671 | 100% |  |
| 675 | 1.4.1.4.1.6 | **CIT Interval 2 Preparation** | 103d | 2023-07-03 A | 2023-11-22 A |  | 100% |  |
| 676 | 1.4.1.4.1.6.1 | **Environments (SIT A)** | 43d | 2023-09-22 A | 2023-11-22 A |  | 100% |  |
| 677 |  | SIT Participants' SIT A environments ready to start connectivity proving CIT Interval 2 | 0d | 2023-09-22 A | 2023-09-22 A |  | 100% |  |
| 678 |  | Programme Participants Ready to Start Connectivity Proving | 0d | 2023-09-22 A | 2023-09-22 A |  | 100% | finish no earlier than 2023-09-22 |
| 679 |  | Internal Connectivity Proving Phase | 10d | 2023-09-25 A | 2023-10-06 A | 678 | 100% |  |
| 680 |  | Internal Connectivity Proving Phase Complete | 0d | 2023-10-06 A | 2023-10-06 A | 679 | 100% | start no earlier than 2023-10-06 |
| 681 |  | DIP Onboarding Activity (1. PKI Officers and Certificates, 2. Set-up Validation, 3. End Point Creation, 4. Controlled Smoke Test ) | 28d | 2023-10-16 A | 2023-11-22 A | 680FS+5d | 100% |  |
| 682 |  | DIP Onboarding Complete | 0d | 2023-11-22 A | 2023-11-22 A | 681 | 100% |  |
| 683 |  | PPs Register PKI Officers and request PKI certificates Complete - Interval 2 | 0d | 2023-11-22 A | 2023-11-22 A | 682 | 100% |  |
| 684 |  | PP Code Deployment | 0d | 2023-10-20 A | 2023-10-20 A |  | 100% | start no earlier than 2023-10-20 |
| 685 | 1.4.1.4.1.6.2 | **Test Data (SIT A) Interval 2** | 43d | 2023-09-20 A | 2023-11-17 A |  | 100% |  |
| 686 |  | Run data allocation | 7d | 2023-09-20 A | 2023-09-28 A | 662SS | 100% |  |
| 687 |  | Cleanse and populate data post cut | 2d | 2023-09-29 A | 2023-10-02 A | 686 | 100% |  |
| 688 |  | Transmit data sets to PPs | 1d | 2023-10-03 A | 2023-10-03 A | 687 | 100% |  |
| 689 |  | PP - Load test data to test environments | 33d | 2023-10-04 A | 2023-11-17 A | 688 | 100% |  |
| 690 |  | PP Check data integrity on test environment | 15d | 2023-10-23 A | 2023-11-17 A | 689FF | 100% |  |
| 691 |  | PP submit self-declaration to Programme to confirm loading & verification of test data | 0d | 2023-11-17 A | 2023-11-17 A | 690FF | 100% |  |
| 692 |  | Test Data (SIT A) Interval 2 Complete | 0d | 2023-11-17 A | 2023-11-17 A | 691 | 100% |  |
| 693 | 1.4.1.4.1.6.3 | **Other Preparation** | 87d | 2023-07-03 A | 2023-10-31 A |  | 100% |  |
| 694 |  | Onboarding of Test Participants to Test Management Tool (Azure DevOps) | 60d | 2023-07-03 A | 2023-09-22 A | 677SF | 100% |  |
| 695 |  | Test Management Tool onboarding | 27d | 2023-09-25 A | 2023-10-31 A | 694 | 100% |  |
| 696 | 1.4.1.4.1.6.4 | **SIT Component Integration Test Readiness Report** | 25d | 2023-10-02 A | 2023-11-03 A |  | 100% |  |
| 697 |  | PP submit Test Readiness Report to Programme for assurance | 0d | 2023-10-25 A | 2023-10-25 A | 609FS+18d | 100% |  |
| 698 |  | SI assure Test Participants' Test Readiness Reports | 2d | 2023-10-26 A | 2023-10-27 A | 697 | 100% |  |
| 699 |  | SI develop Overarching SIT Component Integration Test Readiness Report | 20d | 2023-10-02 A | 2023-10-27 A | 698FF | 100% |  |
| 700 |  | Artefact review (via TMAG) and updates | 5d | 2023-10-30 A | 2023-11-03 A | 699 | 100% |  |

| ID | WBS | Task | Duration | Start | Finish | Predecessors | Complete | Constraint |
| --- | --- | --- | --- | --- | --- | --- | --- | --- |
| 701 |  | SIT Component Integration Testing 2 Preparation Complete (incl. approval of SI SIT Component Integration Test Readiness Report) | 0d | 2023-11-06 A | 2023-11-06 A | 695, 700FS+1d, 677, 290 | 100% |  |
| 702 | 1.4.1.4.1.7 | **CIT Interval 3 Preparation** | 54d | 2023-10-03 A | 2023-12-15 A |  | 100% |  |
| 703 | 1.4.1.4.1.7.1 | **PIT Test Completion Report (incl. evidence)** | 26d | 2023-10-13 A | 2023-11-17 A |  | 100% |  |
| 704 |  | Submit draft PIT Test Completion Report (incl. evidence) and submit to Programme for assurance | 11d | 2023-10-13 A | 2023-10-27 A |  | 100% | must start on 2023-10-13 |
| 705 |  | Finalise PIT Test Completion Report (incl. evidence) | 5d | 2023-10-30 A | 2023-11-03 A | 704 | 100% |  |
| 706 |  | PP PIT Completion Report (excl. Migration/Reverse Migration) submitted to Programme for assurance CIT Interval 3 | 0d | 2023-11-03 A | 2023-11-03 A | 705, 79, 95 | 100% |  |
| 707 |  | PP Final PIT Completion Reports assured by SI | 10d | 2023-11-06 A | 2023-11-17 A | 706 | 100% |  |
| 708 | 1.4.1.4.1.7.2 | **Environments (SIT A)** | 51d | 2023-10-06 A | 2023-12-15 A |  | 100% |  |
| 709 |  | Programme Participants Ready to Start Connectivity Proving | 0d | 2023-10-06 A | 2023-10-06 A |  | 100% | start no earlier than 2023-10-06 |
| 710 |  | SIT Participants' SIT A environments ready to start connectivity proving CIT Interval 3 | 0d | 2023-10-06 A | 2023-10-06 A | 709 | 100% |  |
| 711 |  | Internal Connectivity Proving Phase | 10d | 2023-10-09 A | 2023-10-20 A | 709FS+1d | 100% |  |
| 712 |  | Internal Connectivity Proving Phase Complete | 0d | 2023-10-20 A | 2023-10-20 A | 711 | 100% |  |
| 713 |  | DIP Onboarding Activity (1. PKI Officers and Certificates, 2. Set-up Validation, 3. End Point Creation, 4. Controlled Smoke Test ) | 35d | 2023-10-30 A | 2023-12-15 A | 712FS+5d | 100% |  |
| 714 |  | DIP Onboarding Complete | 0d | 2023-12-15 A | 2023-12-15 A | 713 | 100% |  |
| 715 |  | PPs Register PKI Officers and Request PKI certificates Complete - Interval 3 | 0d | 2023-12-15 A | 2023-12-15 A | 714FF | 100% |  |
| 716 |  | PP Code Deployment | 0d | 2023-11-10 A | 2023-11-10 A | 712FS+15d | 100% | start no earlier than 2023-10-20 |
| 717 | 1.4.1.4.1.7.3 | **Test Data (SIT A) Interval 3** | 34d | 2023-10-03 A | 2023-11-17 A |  | 100% |  |
| 718 |  | Run data allocation | 4d | 2023-10-03 A | 2023-10-06 A | 688SS | 100% |  |
| 719 |  | Cleanse and populate data post cut | 5d | 2023-10-09 A | 2023-10-13 A | 718 | 100% |  |
| 720 |  | Transmit data sets to PPs | 2d | 2023-10-16 A | 2023-10-17 A | 719 | 100% |  |
| 721 |  | PP - Load test data to test environments | 8d | 2023-10-18 A | 2023-10-27 A | 720 | 100% |  |
| 722 |  | PP Check data integrity on test environment | 15d | 2023-10-30 A | 2023-11-17 A | 721 | 100% |  |
| 723 |  | PP submit self-declaration to Programme to confirm loading & verification of test data | 0d | 2023-11-17 A | 2023-11-17 A | 722FF | 100% |  |
| 724 |  | Test Data (SIT A) Interval 3 Complete | 0d | 2023-11-17 A | 2023-11-17 A | 723 | 100% |  |
| 725 | 1.4.1.4.1.7.4 | **Other Preparation** | 25d | 2023-10-16 A | 2023-11-17 A |  | 100% |  |
| 726 |  | Onboarding of Test Participants to Test Management Tool (Azure DevOps) | 25d | 2023-10-16 A | 2023-11-17 A |  | 100% | start no earlier than 2023-10-16 |
| 727 |  | Test Management Tool onboarding | 25d | 2023-10-16 A | 2023-11-17 A |  | 100% | start no earlier than 2023-10-16 |
| 728 | 1.4.1.4.1.7.5 | **SIT Component Integration Test Readiness Report** | 25d | 2023-10-16 A | 2023-11-17 A |  | 100% |  |
| 729 |  | PP submit Test Readiness Report to Programme for assurance | 0d | 2023-11-03 A | 2023-11-03 A | 613 | 100% |  |
| 730 |  | SI assure Test Participants' Test Readiness Reports | 5d | 2023-11-06 A | 2023-11-10 A | 729FF+5d | 100% |  |
| 731 |  | SI develop Overarching SIT Component Integration Test Readiness Report | 20d | 2023-10-16 A | 2023-11-10 A | 730FF | 100% |  |
| 732 |  | Artefact review (via TMAG) and updates | 5d | 2023-11-13 A | 2023-11-17 A | 731 | 100% |  |
| 733 |  | SIT Component Integration Testing 3 Preparation Complete (incl. approval of SI SIT Component Integration Test Readiness Report) | 0d | 2023-11-20 A | 2023-11-20 A | 732FS+1d, 706, 710, 729, 727, 724, 308 | 100% |  |
| 734 | 1.4.1.4.1.8 | **CIT Interval 4 Preparation** | 36d | 2023-10-16 A | 2023-12-04 A |  | 100% |  |
| 735 | 1.4.1.4.1.8.1 | **PIT Test Completion Report (incl. evidence)** | 21d | 2023-10-27 A | 2023-11-24 A |  | 100% |  |
| 736 |  | Submit draft PIT Test Completion Report (incl. evidence) and submit to Programme for assurance | 1d | 2023-10-27 A | 2023-10-27 A |  | 100% | must start on 2023-10-27 |
| 737 |  | Finalise PIT Test Completion Report (incl. evidence) | 15d | 2023-10-30 A | 2023-11-17 A | 736 | 100% |  |
| 738 |  | PP PIT Completion Report (excl. Migration/Reverse Migration) submitted to Programme for assurance CIT Interval 4 | 0d | 2023-11-17 A | 2023-11-17 A | 737, 79, 95 | 100% |  |
| 739 |  | PP Final PIT Completion Reports assured by SI | 5d | 2023-11-20 A | 2023-11-24 A | 738 | 100% |  |
| 740 | 1.4.1.4.1.8.2 | **Environments (SIT A)** | 25d | 2023-10-23 A | 2023-11-24 A |  | 100% |  |
| 741 |  | Programme Participants Ready to Start Connectivity Proving | 0d | 2023-10-23 A | 2023-10-23 A |  | 100% | start no earlier than 2023-10-23 |
| 742 |  | SIT Participants' SIT A environments ready to start connectivity proving CIT Interval 4 | 0d | 2023-10-23 A | 2023-10-23 A | 741 | 100% |  |
| 743 |  | Internal Connectivity Proving Phase | 10d | 2023-10-23 A | 2023-11-03 A | 742 | 100% |  |
| 744 |  | Internal Connectivity Proving Phase Complete | 0d | 2023-11-03 A | 2023-11-03 A | 743 | 100% |  |
| 745 |  | DIP Onboarding Activity (1. PKI Officers and Certificates, 2. Set-up Validation, 3. End Point Creation, 4. Controlled Smoke Test ) | 10d | 2023-11-13 A | 2023-11-24 A | 744FS+5d | 100% |  |
| 746 |  | DIP Onboarding Complete | 0d | 2023-11-24 A | 2023-11-24 A | 745 | 100% |  |
| 747 |  | PPs register PKI Officers and Request PKI Certificates Complete - Interval 4 | 0d | 2023-11-24 A | 2023-11-24 A | 746 | 100% |  |
| 748 |  | PP Code Deployment | 0d | 2023-11-17 A | 2023-11-17 A |  | 100% | start no earlier than 2023-11-17 |
| 749 | 1.4.1.4.1.8.3 | **Test Data (SIT A) Interval 4** | 30d | 2023-10-23 A | 2023-12-01 A |  | 100% |  |
| 750 |  | Run data allocation | 5d | 2023-10-23 A | 2023-10-27 A | 719FS+5d | 100% |  |
| 751 |  | Cleanse and populate data post cut | 2d | 2023-10-30 A | 2023-10-31 A | 750 | 100% |  |
| 752 |  | Transmit data sets to PPs | 5d | 2023-11-01 A | 2023-11-07 A | 751 | 100% |  |
| 753 |  | PP - Load test data to test environments | 5d | 2023-11-08 A | 2023-11-14 A | 752 | 100% |  |
| 754 |  | PP Check data integrity on test environment | 13d | 2023-11-15 A | 2023-12-01 A | 753 | 100% |  |
| 755 |  | PP submit self-declaration to Programme to confirm loading & verification of test data | 0d | 2023-12-01 A | 2023-12-01 A | 754FF | 100% |  |
| 756 |  | Test Data (SIT A) Interval 4 Complete | 0d | 2023-12-01 A | 2023-12-01 A | 755 | 100% |  |
| 757 | 1.4.1.4.1.8.4 | **Other Preparation** | 25d | 2023-10-30 A | 2023-12-01 A |  | 100% |  |
| 758 |  | Onboarding of Test Participants to Test Management Tool (Azure DevOps) | 25d | 2023-10-30 A | 2023-12-01 A |  | 100% | start no earlier than 2023-10-30 |
| 759 |  | Test Management Tool onboarding | 25d | 2023-10-30 A | 2023-12-01 A |  | 100% | start no earlier than 2023-10-30 |
| 760 | 1.4.1.4.1.8.5 | **SIT Component Integration Test Readiness Report** | 27d | 2023-10-16 A | 2023-11-21 A |  | 100% |  |
| 761 |  | PP submit Test Readiness Report to Programme for assurance | 0d | 2023-11-03 A | 2023-11-03 A | 613 | 100% |  |
| 762 |  | SI assure Test Participants' Test Readiness Reports | 5d | 2023-11-06 A | 2023-11-10 A | 761FF+5d | 100% |  |
| 763 |  | SI develop Overarching SIT Component Integration Test Readiness Report | 20d | 2023-10-16 A | 2023-11-10 A | 762FF | 100% |  |
| 764 |  | Artefact review (via SITAG) and updates | 7d | 2023-11-13 A | 2023-11-21 A | 763 | 100% |  |
| 765 |  | SIT Component Integration Testing 4 Preparation Complete (incl. approval of SI SIT Component Integration Test Readiness Report) | 0d | 2023-12-04 A | 2023-12-04 A | 764FS+2d, 738, 742, 761, 756, 325FS+1d | 100% |  |
| 766 | 1.4.1.4.1.9 | **CIT Interval 5 Preparation** | 53d | 2023-11-01 A | 2024-01-12 A |  | 100% |  |
| 767 | 1.4.1.4.1.9.1 | **PIT Test Completion Report (incl. evidence)** | 21d | 2023-11-17 A | 2023-12-15 A |  | 100% |  |
| 768 |  | Submit draft PIT Test Completion Report (incl. evidence) and submit to Programme for assurance | 1d | 2023-11-17 A | 2023-11-17 A |  | 100% | must start on 2023-11-17 |
| 769 |  | Finalise PIT Test Completion Report (incl. evidence) | 15d | 2023-11-20 A | 2023-12-08 A | 768 | 100% |  |
| 770 |  | PP PIT Completion Report (excl. Migration/Reverse Migration) submitted to Programme for assurance CIT Interval 5 | 0d | 2023-12-08 A | 2023-12-08 A | 769, 79, 95 | 100% |  |

| ID | WBS | Task | Duration | Start | Finish | Predecessors | Complete | Constraint |
| --- | --- | --- | --- | --- | --- | --- | --- | --- |
| 771 |  | PP Final PIT Completion Reports assured by SI | 5d | 2023-12-11 A | 2023-12-15 A | 770 | 100% |  |
| 772 | 1.4.1.4.1.9.2 | **Environments (SIT A)** | 21d | 2023-11-10 A | 2023-12-08 A |  | 100% |  |
| 773 |  | Programme Participants Ready to Start Connectivity Proving | 0d | 2023-11-10 A | 2023-11-10 A |  | 100% | start no earlier than 2023-11-10 |
| 774 |  | SIT Participants' SIT A environments ready to start connectivity proving CIT Interval 5 | 0d | 2023-11-10 A | 2023-11-10 A | 773 | 100% |  |
| 775 |  | Internal Connectivity Proving Phase | 10d | 2023-11-13 A | 2023-11-24 A | 773FS+1d | 100% |  |
| 776 |  | Internal Connectivity Proving Phase Complete | 0d | 2023-11-24 A | 2023-11-24 A | 775 | 100% |  |
| 777 |  | DIP Onboarding Activity (1. PKI Officers and Certificates, 2. Set-up Validation, 3. End Point Creation, 4. Controlled Smoke Test ) | 10d | 2023-11-27 A | 2023-12-08 A | 776 | 100% |  |
| 778 |  | DIP Onboarding Complete | 0d | 2023-12-08 A | 2023-12-08 A | 777 | 100% |  |
| 779 |  | PPs register PKI Officers and Request PKI Certificates Complete - Interval 5 | 0d | 2023-12-08 A | 2023-12-08 A | 778 | 100% |  |
| 780 |  | PP Code Deployment | 0d | 2023-12-08 A | 2023-12-08 A | 779 | 100% | start no earlier than 2023-10-20 |
| 781 | 1.4.1.4.1.9.3 | **Test Data (SIT A) Interval 5** | 33d | 2023-11-01 A | 2023-12-15 A |  | 100% |  |
| 782 |  | Run data allocation | 5d | 2023-11-01 A | 2023-11-07 A | 752SS | 100% |  |
| 783 |  | Cleanse and populate data post cut | 8d | 2023-11-08 A | 2023-11-17 A | 782 | 100% |  |
| 784 |  | Transmit data sets to PPs | 2d | 2023-11-20 A | 2023-11-21 A | 783 | 100% |  |
| 785 |  | PP - Load test data to test environments | 8d | 2023-11-22 A | 2023-12-01 A | 784 | 100% |  |
| 786 |  | PP Check data integrity on test environment | 10d | 2023-12-04 A | 2023-12-15 A | 785 | 100% |  |
| 787 |  | PP submit self-declaration to Programme to confirm loading & verification of test data | 0d | 2023-12-15 A | 2023-12-15 A | 786FF | 100% |  |
| 788 |  | Test Data (SIT A) Interval 5 Complete | 0d | 2023-12-15 A | 2023-12-15 A | 787 | 100% |  |
| 789 | 1.4.1.4.1.9.4 | **Other Preparation** | 40d | 2023-11-20 A | 2024-01-12 A |  | 100% |  |
| 790 |  | Onboarding of Test Participants to Test Management Tool (Azure DevOps) | 40d | 2023-11-20 A | 2024-01-12 A |  | 100% | start no earlier than 2023-11-20 |
| 791 |  | Test Management Tool onboarding | 36d | 2023-11-20 A | 2024-01-08 A |  | 100% | start no earlier than 2023-11-20 |
| 792 | 1.4.1.4.1.9.5 | **SIT Component Integration Test Readiness Report** | 35d | 2023-11-20 A | 2024-01-05 A |  | 100% |  |
| 793 |  | PP submit Test Readiness Report to Programme for assurance | 0d | 2023-12-08 A | 2023-12-08 A | 617 | 100% |  |
| 794 |  | SI assure Test Participants' Test Readiness Reports | 5d | 2023-12-11 A | 2023-12-15 A | 793FF+5d | 100% |  |
| 795 |  | SI develop Overarching SIT Component Integration Test Readiness Report | 20d | 2023-11-20 A | 2023-12-15 A | 794FF | 100% |  |
| 796 |  | Artefact review (via SITAG) and updates | 15d | 2023-12-18 A | 2024-01-05 A | 795 | 100% |  |
| 797 |  | SIT Component Integration Testing 5 Preparation Complete (incl. approval of SI SIT Component Integration Test Readiness Report) | 0d | 2024-01-08 A | 2024-01-08 A | 796FS+1d, 770, 774, 791, 793, 788, 445, 428 | 100% |  |
| 798 | 1.4.1.4.1.10 | **CIT Interval 6 Preparation** | 45d | 2023-11-20 A | 2024-01-19 A |  | 100% |  |
| 799 | 1.4.1.4.1.10.1 | **PIT Test Completion Report (incl. evidence)** | 31d | 2023-12-01 A | 2024-01-12 A |  | 100% |  |
| 800 |  | Submit draft PIT Test Completion Report (incl. evidence) and submit to Programme for assurance | 1d | 2023-12-01 A | 2023-12-01 A |  | 100% | must start on 2023-12-01 |
| 801 |  | Finalise PIT Test Completion Report (incl. evidence) | 25d | 2023-12-04 A | 2024-01-05 A | 800 | 100% |  |
| 802 |  | PP PIT Completion Report (excl. Migration/Reverse Migration) submitted to Programme for assurance CIT Interval 6 | 0d | 2024-01-05 A | 2024-01-05 A | 801, 79, 95, 247, 252, 255 | 100% |  |
| 803 |  | PP Final PIT Completion Reports assured by SI | 5d | 2024-01-08 A | 2024-01-12 A | 802 | 100% |  |
| 804 | 1.4.1.4.1.10.2 | **Environments (SIT A)** | 30d | 2023-11-24 A | 2024-01-05 A |  | 100% |  |
| 805 |  | Programme Participants Ready to Start Connectivity Proving | 0d | 2023-11-24 A | 2023-11-24 A |  | 100% | start no earlier than 2023-11-24 |
| 806 |  | SIT Participants' SIT A environments ready to start connectivity proving CIT Interval 6 | 0d | 2023-11-24 A | 2023-11-24 A | 805 | 100% |  |
| 807 |  | Internal Connectivity Proving Phase | 10d | 2023-11-27 A | 2023-12-08 A | 806FS+1d | 100% |  |
| 808 |  | Internal Connectivity Proving Phase Complete | 0d | 2023-12-08 A | 2023-12-08 A | 807 | 100% |  |
| 809 |  | DIP Onboarding Activity (1. PKI Officers and Certificates, 2. Set-up Validation, 3. End Point Creation, 4. Controlled Smoke Test ) | 5d | 2023-12-04 A | 2023-12-08 A | 806FS+6d | 100% |  |
| 810 |  | DIP Onboarding Complete | 0d | 2023-12-08 A | 2023-12-08 A | 809 | 100% |  |
| 811 |  | PPs register PKI Officers and Request PKI Certificates Complete - Interval 6 | 0d | 2023-12-08 A | 2023-12-08 A | 810 | 100% | start no earlier than 2023-12-08 |
| 812 |  | PP Code Deployment | 0d | 2024-01-05 A | 2024-01-05 A |  | 100% | start no earlier than 2024-01-05 |
| 813 | 1.4.1.4.1.10.3 | **Test Data (SIT A) Interval 6** | 25d | 2023-11-20 A | 2023-12-22 A |  | 100% |  |
| 814 |  | Run data allocation | 10d | 2023-11-20 A | 2023-12-01 A | 784SS | 100% |  |
| 815 |  | Cleanse and populate data post cut | 1d | 2023-12-04 A | 2023-12-04 A | 814 | 100% |  |
| 816 |  | Transmit data sets to PPs | 1d | 2023-12-05 A | 2023-12-05 A | 815 | 100% |  |
| 817 |  | PP - Load test data to test environments | 8d | 2023-12-06 A | 2023-12-15 A | 816 | 100% |  |
| 818 |  | PP Check data integrity on test environment | 5d | 2023-12-18 A | 2023-12-22 A | 817 | 100% |  |
| 819 |  | PP submit self-declaration to Programme to confirm loading & verification of test data | 0d | 2023-12-22 A | 2023-12-22 A | 818FF | 100% |  |
| 820 |  | Test Data (SIT A) Interval 6 Complete | 0d | 2023-12-22 A | 2023-12-22 A | 819 | 100% |  |
| 821 | 1.4.1.4.1.10.4 | **Other Preparation** | 31d | 2023-12-04 A | 2024-01-15 A |  | 100% |  |
| 822 |  | Onboarding of Test Participants to Test Management Tool (Azure DevOps) | 31d | 2023-12-04 A | 2024-01-15 A |  | 100% | start no earlier than 2023-12-04 |
| 823 |  | Test Management Tool onboarding | 31d | 2023-12-04 A | 2024-01-15 A |  | 100% | start no earlier than 2023-12-04 |
| 824 | 1.4.1.4.1.10.5 | **SIT Component Integration Test Readiness Report** | 25d | 2023-11-20 A | 2023-12-22 A |  | 100% |  |
| 825 |  | PP submit Test Readiness Report to Programme for assurance | 0d | 2023-12-08 A | 2023-12-08 A | 617 | 100% |  |
| 826 |  | SI assure Test Participants' Test Readiness Reports | 5d | 2023-12-11 A | 2023-12-15 A | 825FF+5d | 100% |  |
| 827 |  | SI develop Overarching SIT Component Integration Test Readiness Report | 20d | 2023-11-20 A | 2023-12-15 A | 826FF | 100% |  |
| 828 |  | Artefact review (via TMAG) and updates | 5d | 2023-12-18 A | 2023-12-22 A | 827 | 100% |  |
| 829 |  | SIT Component Integration Testing 6 Preparation Complete (incl. approval of SI SIT Component Integration Test Readiness Report) | 0d | 2024-01-19 A | 2024-01-19 A | 828FS+1d, 802, 806, 823, 825, 820, 273, 462 | 100% |  |
| 830 | 1.4.1.4.2 | **SIT Functional Preparation** | 595d? | 2022-10-31 A | 2025-02-07 A |  | 100% |  |
| 831 |  | Environment Approach and Plan - SIT Functional | 1d? | 2023-11-20 A | 2023-11-20 A |  | 100% | start no earlier than 2023-11-20 |
| 832 | 1.4.1.4.2.2 | **Test Approach & Plan** | 208d | 2022-10-31 A | 2023-08-16 A |  | 100% |  |
| 833 |  | Develop document with SITWG | 179d | 2022-10-31 A | 2023-07-06 A |  | 100% | finish no earlier than 2023-07-06 |
| 834 |  | Industry Consultation | 10d | 2023-07-07 A | 2023-07-20 A | 833 | 100% |  |
| 835 |  | Artefact review (via TMAG) and updates | 19d | 2023-07-21 A | 2023-08-16 A | 834 | 100% | finish no earlier than 2023-08-03 |
| 836 |  | SIT Functional Test Approach & Plan approved | 0d | 2023-08-16 A | 2023-08-16 A |  | 100% | finish no earlier than 2023-08-16 |
| 837 | 1.4.1.4.2.3 | **Test Data Approach & Plan** | 29d | 2023-07-07 A | 2023-08-16 A |  | 100% |  |
| 838 |  | Industry Consultation | 10d | 2023-07-07 A | 2023-07-20 A | 834SS | 100% |  |
| 839 |  | Artefact review (via TMAG) and updates | 19d | 2023-07-21 A | 2023-08-16 A | 838 | 100% |  |
| 840 |  | SIT Functional Testing Test Data Approach & Plan approved | 0d | 2023-08-16 A | 2023-08-16 A | 839 | 100% |  |

| ID | WBS | Task | Duration | Start | Finish | Predecessors | Complete | Constraint |
| --- | --- | --- | --- | --- | --- | --- | --- | --- |
| 841 | 1.4.1.4.2.4 | **Test scenarios** | 298d | 2023-01-02 A | 2024-02-21 A |  | 100% |  |
| 842 |  | Development of test scenarios | 85d | 2023-01-02 A | 2023-04-28 A | 833SS+45d | 100% |  |
| 843 |  | Review test scenarios with SIT Working Group | 65d | 2023-08-17 A | 2023-11-15 A | 842FS+78d | 100% |  |
| 844 |  | SIT Functional Testing Test scenarios (themes 1-5) approved | 0d | 2023-12-08 A | 2023-12-08 A | 843FS+17d | 100% |  |
| 845 |  | SIT Functional Testing Test scenarios (themes 6,7,9) approved | 0d | 2024-01-17 A | 2024-01-17 A | 844FS+28d | 100% |  |
| 846 |  | SIT Functional Testing Test scenarios (theme 8) approved | 0d | 2024-02-21 A | 2024-02-21 A | 845FS+25d | 100% |  |
| 847 | 1.4.1.4.2.5 | **Test cases** | 465d? | 2023-05-01 A | 2025-02-07 A |  | 100% |  |
| 848 | 1.4.1.4.2.5.1 | **SI Test cases** | 213d | 2023-05-01 A | 2024-02-21 A |  | 100% |  |
| 849 |  | Development of Test cases | 150d | 2023-05-01 A | 2023-11-24 A | 842 | 100% |  |
| 850 |  | Review Test cases with SIT Working Group | 78d | 2023-09-25 A | 2024-01-10 A | 849SS+105d | 100% |  |
| 851 |  | SIT Functional Testing Test Cases (themes 1-5) approved | 0d | 2024-01-17 A | 2024-01-17 A | 850FS+5d | 100% |  |
| 852 |  | SIT Functional Testing Test cases (themes 6,7,9) approved | 0d | 2024-01-17 A | 2024-01-17 A | 851 | 100% |  |
| 853 |  | SIT Functional Testing Test cases (theme 8) approved | 0d | 2024-02-21 A | 2024-02-21 A | 852FS+25d | 100% |  |
| 854 | 1.4.1.4.2.5.2 | **SIT Functional Programme RTTM** | 74d? | 2024-07-29 A | 2024-11-07 A |  | 100% |  |
| 855 | 1.4.1.4.2.5.2.1 | **RTTM Development** | 30d? | 2024-07-29 A | 2024-09-06 A |  | 100% |  |
| 856 |  | Development of Manual SIT Functional RTTM | 30d? | 2024-07-29 A | 2024-09-06 A |  | 100% | start no earlier than 2024-07-29 |
| 857 |  | Manual SIT Functional RTTM Complete | 0d? | 2024-09-06 A | 2024-09-06 A | 856 | 100% | start no earlier than 2024-07-29 |
| 858 | 1.4.1.4.2.5.2.2 | **Gap analysis** | 54d? | 2024-08-26 A | 2024-11-07 A |  | 100% |  |
| 859 |  | Identify gaps in test case coverage following RTTM review | 20d? | 2024-08-26 A | 2024-09-20 A |  | 100% |  |
| 860 |  | Address gaps in test case coverage following RTTM review | 25d | 2024-09-09 A | 2024-10-11 A | 859SS+10d | 100% |  |
| 861 |  | Gap analysis complete | 0d | 2024-10-11 A | 2024-10-11 A | 860 | 100% |  |
| 862 |  | Test Script updates identified | 1d? | 2024-10-14 A | 2024-10-14 A | 861 | 100% |  |
| 863 |  | Test Scripts updates | 1d | 2024-10-15 A | 2024-10-15 A | 862 | 100% |  |
| 864 |  | RTTM Updated Additional Static RTTM WBS items | 10d | 2024-10-14 A | 2024-10-25 A | 862FS-1d | 100% |  |
| 865 |  | Removal of de-scoped TCs from the RTTMs | 5d | 2024-10-21 A | 2024-10-25 A | 864FS-5d | 100% |  |
| 866 |  | Update and stabilisation of all TC ADO IDs | 14d | 2024-10-21 A | 2024-11-07 A | 864FS-5d | 100% |  |
| 867 |  | Addition and integration of Role tags to reqs in the Role RTTMs | 5d | 2024-10-21 A | 2024-10-25 A | 864FS-5d | 100% |  |
| 868 |  | Update of the RTTM All sheet (porting of the individual RTTMs) | 7d | 2024-10-24 A | 2024-11-01 A | 864FS-2d | 100% |  |
| 869 |  | Define Additional ADO Tags | 1d | 2024-10-23 A | 2024-10-23 A | 864FS-3d | 100% |  |
| 870 |  | Functional RTTM ready for import into ADO | 0d | 2024-11-01 A | 2024-11-01 A | 868 | 100% |  |
| 871 |  | Further Interative Deepdive on the requirements to testcase mapping | 9d | 2024-10-21 A | 2024-10-31 A | 868FS-10d | 100% |  |
| 872 |  | Internal review | 5d | 2024-10-21 A | 2024-10-25 A | 871FS-9d | 100% |  |
| 873 |  | Issue Static RTTM to Code Bodies | 1d? | 2024-10-29 A | 2024-10-29 A | 872FS+1d | 100% |  |
| 874 |  | Code Body Acceptance of RTTM | 5d | 2024-10-30 A | 2024-11-05 A | 873 | 100% |  |
| 875 | 1.4.1.4.2.5.3 | **Cycle 3 Test Evidence Capturing Approach** | 25d? | 2024-09-16 A | 2024-10-18 A |  | 100% |  |
| 876 |  | Define guiding principles and proof of concept | 10d | 2024-09-16 A | 2024-09-27 A |  | 100% | start no earlier than 2024-09-16 |
| 877 |  | Draft proposed test evidence capturing approach | 3d | 2024-09-30 A | 2024-10-02 A | 876 | 100% |  |
| 878 |  | SRO review | 5d | 2024-10-03 A | 2024-10-09 A | 877 | 100% |  |
| 879 |  | Present proposed approach | 1d? | 2024-10-11 A | 2024-10-11 A | 878FS+1d | 100% |  |
| 880 |  | Incorporate feedback | 4d | 2024-10-14 A | 2024-10-17 A | 879 | 100% |  |
| 881 |  | Publish proposed approach ahead of Cycle 3 start | 1d? | 2024-10-18 A | 2024-10-18 A | 880 | 100% |  |
| 882 | 1.4.1.4.2.5.4 | **DITL Cycle 3 Pack Development** | 8d? | 2024-10-08 A | 2024-10-17 A |  | 100% |  |
| 883 |  | Programme Cycle 2 Retro | 1d? | 2024-10-08 A | 2024-10-08 A |  | 100% | start no earlier than 2024-10-08 |
| 884 |  | Post-retro DITL Changes | 3d | 2024-10-09 A | 2024-10-11 A | 883 | 100% |  |
| 885 |  | SRO Review | 2d | 2024-10-14 A | 2024-10-15 A | 884 | 100% |  |
| 886 |  | Post-SRO Review Changes | 1d? | 2024-10-16 A | 2024-10-16 A | 885 | 100% |  |
| 887 |  | Publish Cycle 3 DITL / Cycle 3 DITL Online Sessions for SIT PPs | 1d? | 2024-10-17 A | 2024-10-17 A | 886 | 100% |  |
| 888 | 1.4.1.4.2.5.5 | **Test Script Exit Points** | 85d | 2024-10-14 A | 2025-02-07 A |  | 100% |  |
| 889 |  | Implement exit points for Sprint 5 | 5d | 2024-10-14 A | 2024-10-18 A | 881FS-5d | 100% |  |
| 890 |  | Identify exit points for Sprint 6 | 5d | 2024-11-07 A | 2024-11-13 A | 1513SS | 100% |  |
| 891 |  | Identify exit points for Sprint 7 | 5d | 2024-11-08 A | 2024-11-14 A | 1514SS | 100% | start no earlier than 2024-11-08 |
| 892 |  | Identify exit points for Sprint 8 | 5d | 2024-11-18 A | 2024-11-22 A | 1515SS | 100% |  |
| 893 |  | Identify exit points for Sprint 9 | 5d | 2024-12-02 A | 2024-12-06 A | 1516SS | 100% |  |
| 894 |  | Identify exit points for Sprint 10 | 5d | 2024-12-23 A | 2024-12-27 A | 1517SS | 100% |  |
| 895 |  | Identify exit points for Sprint 11 | 5d | 2025-01-06 A | 2025-01-10 A | 1518SS | 100% |  |
| 896 |  | Identify exit points for Sprint 12 | 5d | 2025-01-20 A | 2025-01-24 A | 1519SS | 100% |  |
| 897 |  | Identify exit points for Sprint 13 | 5d | 2025-02-03 A | 2025-02-07 A | 1520SS | 100% |  |
| 898 |  | Exit point identified and evidence capture flags updated | 0d | 2025-02-07 A | 2025-02-07 A | 897 | 100% |  |
| 899 | 1.4.1.4.2.6 | **Environments (SIT-Staging)** | 10d | 2023-12-04 A | 2023-12-15 A |  | 100% |  |
| 900 | 1.4.1.4.2.6.1 | **SIT Functional pre-requisites** | 10d | 2023-12-04 A | 2023-12-15 A |  | 100% |  |
| 901 | 1.4.1.4.2.6.1.1 | **DCC** | 10d | 2023-12-04 A | 2023-12-15 A |  | 100% |  |
| 902 | 1.4.1.4.2.6.1.1.1 | **CSS** | 10d | 2023-12-04 A | 2023-12-15 A |  | 100% |  |
| 903 |  | SIT participants have requested DCC CSS PKI certificates for access to UIT-B environment | 10d | 2023-12-04 A | 2023-12-15 A |  | 100% | start no earlier than 2023-12-04 |
| 904 |  | SIT participants have received DCC CSS PKI certificates for UIT-B environment | 0d | 2023-12-15 A | 2023-12-15 A | 903 | 100% |  |
| 905 | 1.4.1.4.2.6.1.1.2 | **DSP** | 10d | 2023-12-04 A | 2023-12-15 A |  | 100% |  |
| 906 |  | SIT participants have requested DCC DSP PKI certificates for access to UIT-B environment | 10d | 2023-12-04 A | 2023-12-15 A |  | 100% | start no earlier than 2023-12-04 |
| 907 |  | SIT participants have received DCC DSP PKI certificates for UIT-B environment | 0d | 2023-12-15 A | 2023-12-15 A | 906 | 100% |  |
| 908 | 1.4.1.4.2.7 | **Stand up SIT A Environment** | 25d | 2024-02-05 A | 2024-03-08 A |  | 100% |  |
| 909 | 1.4.1.4.2.7.1 | **SIT Functional Connectivity Proving** | 15d | 2024-02-12 A | 2024-03-01 A |  | 100% |  |
| 910 |  | SIT Functional Connectivity Proving Period | 15d | 2024-02-12 A | 2024-03-01 A |  | 100% | start no earlier than 2024-01-08 |

| ID | WBS | Task | Duration | Start | Finish | Predecessors | Complete | Constraint |
| --- | --- | --- | --- | --- | --- | --- | --- | --- |
| 911 |  | SIT Functional Connectivity Proving Complete | 0d | 2024-03-01 A | 2024-03-01 A | 910 | 100% | start no earlier than 2024-03-01 |
| 912 | 1.4.1.4.2.7.2 | **PP Environments (SIT A)** | 25d | 2024-02-05 A | 2024-03-08 A |  | 100% |  |
| 913 |  | Deployment of MHHS solution code to SIT A environments | 25d | 2024-02-05 A | 2024-03-08 A |  | 100% | start no earlier than 2024-02-05 |
| 914 | 1.4.1.4.2.7.3 | **SI Environments (SIT A)** | 25d | 2024-02-05 A | 2024-03-08 A |  | 100% |  |
| 915 |  | Coordinate deployment of MHHS solution code to SIT Participants' SIT A environments | 25d | 2024-02-05 A | 2024-03-08 A | 913SS | 100% |  |
| 916 | 1.4.1.4.2.8 | **Test data (SIT A)** | 221d? | 2023-12-18 A | 2024-10-21 A |  | 100% |  |
| 917 | 1.4.1.4.2.8.1 | **Cycle 1 Test data (SIT A)** | 55d | 2023-12-18 A | 2024-03-01 A |  | 100% |  |
| 918 |  | Prepare, Generate and Allocate Test Data | 28d | 2023-12-18 A | 2024-01-24 A | 649, 657 | 100% | start no earlier than 2023-12-11 |
| 919 |  | Transmit Data Sets to PPs | 4d | 2024-01-26 A | 2024-01-31 A | 918FS+1d | 100% |  |
| 920 |  | PP's Iterative load and data integrity check | 22d | 2024-02-01 A | 2024-03-01 A | 919 | 100% |  |
| 921 |  | Cycle 1 - PP's confirmation that test data is ready for SIT Functional | 0d | 2024-03-01 A | 2024-03-01 A | 920 | 100% |  |
| 922 | 1.4.1.4.2.8.2 | **Cycle 2 Test data (inc. Settlement Data) (SIT A)** | 57d | 2024-03-28 A | 2024-06-14 A |  | 100% |  |
| 923 |  | Prepare, Generate and Allocate Test Data | 31d | 2024-03-28 A | 2024-05-09 A | 921FS+18d | 100% |  |
| 924 |  | Transmit Data Sets to PPs | 3d | 2024-05-10 A | 2024-05-14 A | 923 | 100% |  |
| 925 |  | PP's Iterative load and data integrity check | 13d | 2024-05-15 A | 2024-05-31 A | 924 | 100% |  |
| 926 |  | Cycle 2 - PP's confirmation that test data is ready for SIT Functional | 0d | 2024-06-14 A | 2024-06-14 A | 925FS+10d | 100% |  |
| 927 | 1.4.1.4.2.8.3 | **Cycle 3 Test data (SIT A) (2)** | 71d? | 2024-07-15 A | 2024-10-21 A |  | 100% |  |
| 928 |  | Cycle 3 data requirments analysis - check Cycle 2 data for gaps Check blocked test cases | 10d? | 2024-07-15 A | 2024-07-26 A |  | 100% | finish no earlier than 2024-07-26 |
| 929 |  | Provide DCC with MPANS for deletion secure file with password | 1d? | 2024-08-12 A | 2024-08-12 A |  | 100% |  |
| 930 |  | Receive MPANS from DCC to exclude | 1d? | 2024-08-09 A | 2024-08-09 A |  | 100% |  |
| 931 |  | Exclude MPANS from allocation | 1d | 2024-08-16 A | 2024-08-16 A |  | 100% |  |
| 932 |  | Allocate Cycle 3 MPANS | 16d? | 2024-08-06 A | 2024-08-27 A |  | 100% |  |
| 933 |  | Generate Cycle 3 Data | 2d? | 2024-08-27 A | 2024-08-28 A |  | 100% |  |
| 934 |  | Check data prior to sending to DCC | 5d? | 2024-08-22 A | 2024-08-28 A |  | 100% |  |
| 935 |  | Share Cycle 3 MPAN data with DCC | 1d? | 2024-08-29 A | 2024-08-29 A |  | 100% |  |
| 936 |  | DCC - load data and create registration Id's for Cycle 3 data | 13d? | 2024-08-27 A | 2024-09-12 A |  | 100% |  |
| 937 |  | Add registration ID's to Cycle 3 Data | 2d? | 2024-09-12 A | 2024-09-13 A |  | 100% |  |
| 938 |  | Share subset of data with St Cls for data load | 2d? | 2024-09-12 A | 2024-09-13 A |  | 100% |  |
| 939 |  | St Clements to run test with Subset of data - MPRS business process checks including Import/Export MPANS | 5d? | 2024-09-16 A | 2024-09-20 A |  | 100% |  |
| 940 |  | Send Cycle 3 data to partcipants for early sight of data | 3d? | 2024-09-25 A | 2024-09-27 A |  | 100% |  |
| 941 |  | St Clements MPRS data load bulk files for Cycle 3 | 15d? | 2024-09-23 A | 2024-10-11 A |  | 100% |  |
| 942 |  | New MPAN creation and load through DCC and St Clements | 1d? | 2024-10-11 A | 2024-10-11 A |  | 100% | start no earlier than 2024-10-11 |
| 943 |  | Share files with PP's and central parties | 1d | 2024-10-11 A | 2024-10-11 A |  | 100% | start no earlier than 2024-10-11 |
| 944 |  | Avanade to load data | 6d | 2024-10-14 A | 2024-10-21 A |  | 100% | start no earlier than 2024-10-14 |
| 945 |  | Helix to load data | 6d | 2024-10-14 A | 2024-10-21 A |  | 100% | start no earlier than 2024-10-14 |
| 946 |  | PP's and central parties to load all Cycle 3 data | 6d | 2024-10-14 A | 2024-10-21 A |  | 100% | start no earlier than 2024-10-14 |
| 947 |  | All parties to finalise data load | 1d? | 2024-10-21 A | 2024-10-21 A |  | 100% | start no earlier than 2024-10-21 |
| 948 | 1.4.1.4.2.9 | **SIT Functional Test Readiness Report** | 45d | 2024-01-01 A | 2024-03-01 A |  | 100% |  |
| 949 | 1.4.1.4.2.9.1 | **PP SIT Functional Test Readiness Report** | 44d | 2024-01-01 A | 2024-02-29 A |  | 100% |  |
| 950 |  | Develop draft Test Readiness Report and submit to Programme for assurance | 21d | 2024-01-01 A | 2024-01-29 A |  | 100% | start no earlier than 2024-01-01 |
| 951 |  | Placing Reliance Stage 2 Review | 34d | 2024-01-15 A | 2024-02-29 A | 950SS+10d | 100% |  |
| 952 |  | Finalise Test Readiness Report and submit to Programme for assurance | 9d | 2024-01-30 A | 2024-02-09 A | 950 | 100% |  |
| 953 | 1.4.1.4.2.9.2 | **SI SIT Functional Test Readiness Report** | 40d | 2024-01-01 A | 2024-02-23 A |  | 100% |  |
| 954 |  | Assure Test Participants' Test Readiness Reports | 35d | 2024-01-01 A | 2024-02-16 A | 950SS, 952FF+5d | 100% |  |
| 955 |  | Develop Overarching SIT Functional Test Readiness Report | 20d | 2024-01-22 A | 2024-02-16 A | 954FF | 100% |  |
| 956 |  | Artefact review (via TMAG) and updates | 5d | 2024-02-19 A | 2024-02-23 A | 955 | 100% |  |
| 957 |  | SIT Functional Testing Preparation Complete | 0d | 2024-03-01 A | 2024-03-01 A | 956FF+5d, 836, 342, 951, 844, 851, 921 | 100% |  |
| 958 | 1.4.1.4.3 | **SIT Migration Testing Preparation** | 595d? | 2022-10-31 A | 2025-02-07 A |  | 100% |  |
| 959 | 1.4.1.4.3.1 | **Test Approach & Plan** | 75d | 2023-09-07 A | 2023-12-20 A |  | 100% |  |
| 960 |  | Develop document with SITWG | 32d | 2023-09-07 A | 2023-10-20 A | 3134 | 100% | finish no earlier than 2023-10-11 |
| 961 |  | Draft document review with Code Bodies | 8d | 2023-10-23 A | 2023-11-01 A | 960 | 100% |  |
| 962 |  | Industry Consultation | 10d | 2023-11-02 A | 2023-11-15 A | 961 | 100% |  |
| 963 |  | Artefact review (via TMAG) and updates | 25d | 2023-11-16 A | 2023-12-20 A | 962 | 100% |  |
| 964 |  | SIT Migration Testing Test Approach & Plan approved | 0d | 2023-12-20 A | 2023-12-20 A | 963 | 100% | finish no earlier than 2023-12-20 |
| 965 | 1.4.1.4.3.2 | **Test Data Approach & Plan** | 35d | 2023-11-02 A | 2023-12-20 A |  | 100% |  |
| 966 |  | Industry Consultation | 10d | 2023-11-02 A | 2023-11-15 A | 962SS | 100% |  |
| 967 |  | Artefact review (via TMAG) and updates | 25d | 2023-11-16 A | 2023-12-20 A | 966 | 100% |  |
| 968 |  | SIT Migration Test Data Test Approach & Plan approved | 0d | 2023-12-20 A | 2023-12-20 A | 967 | 100% |  |
| 969 | 1.4.1.4.3.3 | **Test scenarios & Test Cases** | 297d? | 2023-12-21 A | 2025-02-07 A |  | 100% |  |
| 970 | 1.4.1.4.3.3.1 | **Theme 1** | 65d | 2023-12-21 A | 2024-03-20 A |  | 100% |  |
| 971 |  | Develop Test Scenarios & Test Cases | 25d | 2023-12-21 A | 2024-01-24 A | 964 | 100% |  |
| 972 |  | Industry Review Workshop | 1d | 2024-01-25 A | 2024-01-25 A | 971 | 100% |  |
| 973 |  | Industry Consultation Review | 6d | 2024-02-05 A | 2024-02-12 A | 972FS+6d | 100% |  |
| 974 |  | Review with SIT Working Group | 5d | 2024-02-29 A | 2024-03-06 A | 973FS+12d | 100% |  |
| 975 |  | SIT Migration Test scenarios & Test Cases Approved - Theme 1 | 0d | 2024-03-20 A | 2024-03-20 A | 974FS+10d | 100% |  |
| 976 | 1.4.1.4.3.3.2 | **Theme 2** | 85d | 2023-12-21 A | 2024-04-17 A |  | 100% |  |
| 977 |  | Develop Test Scenarios & Test Cases | 40d | 2023-12-21 A | 2024-02-14 A | 964 | 100% |  |
| 978 |  | Industry Review Workshop | 1d | 2024-02-15 A | 2024-02-15 A | 977 | 100% |  |
| 979 |  | Industry Consultation Review | 6d | 2024-02-26 A | 2024-03-04 A | 978FS+6d | 100% |  |
| 980 |  | Review with SIT Working Group | 5d | 2024-03-28 A | 2024-04-03 A | 979FS+17d | 100% |  |

| ID | WBS | Task | Duration | Start | Finish | Predecessors | Complete | Constraint |
| --- | --- | --- | --- | --- | --- | --- | --- | --- |
| 981 |  | SIT Migration Test scenarios & Test Cases Approved - Theme 2 | 0d | 2024-04-17 A | 2024-04-17 A | 980FS+10d | 100% |  |
| 982 | 1.4.1.4.3.3.3 | **Theme 3** | 85d | 2023-12-21 A | 2024-04-17 A |  | 100% |  |
| 983 |  | Develop Test Scenarios & Test Cases | 55d | 2023-12-21 A | 2024-03-06 A | 964 | 100% |  |
| 984 |  | Industry Review Workshop | 1d | 2024-03-07 A | 2024-03-07 A | 983 | 100% |  |
| 985 |  | Industry Consultation Review | 6d | 2024-03-13 A | 2024-03-20 A | 984FS+3d | 100% |  |
| 986 |  | Review with SIT Working Group | 5d | 2024-03-28 A | 2024-04-03 A | 985FS+5d | 100% |  |
| 987 |  | SIT Migration Test scenarios & Test Cases Approved - Theme 3 | 0d | 2024-04-17 A | 2024-04-17 A | 986FS+10d | 100% |  |
| 988 | 1.4.1.4.3.3.4 | **RTTM Development** | 17d | 2024-08-29 A | 2024-09-20 A |  | 100% |  |
| 989 |  | Develop Manual SIT Migration RTTM | 17d | 2024-08-29 A | 2024-09-20 A |  | 100% | start no earlier than 2024-08-29 |
| 990 |  | Manual SIT Migration RTTM Complete | 0d | 2024-09-20 A | 2024-09-20 A | 989 | 100% |  |
| 991 | 1.4.1.4.3.3.5 | **Gap analysis** | 107d? | 2024-09-12 A | 2025-02-07 A |  | 100% |  |
| 992 |  | Identify gaps in test case coverage following RTTM review. | 12d | 2024-09-12 A | 2024-09-27 A | 989SS+10d | 100% |  |
| 993 |  | Address gaps in test case coverage following RTTM review. | 17d | 2024-09-19 A | 2024-10-11 A | 992SS+5d | 100% |  |
| 994 |  | Gap analysis complete | 0d? | 2024-10-11 A | 2024-10-11 A | 993 | 100% |  |
| 995 |  | Test Script updates identified | 1d? | 2024-10-14 A | 2024-10-14 A | 994 | 100% |  |
| 996 |  | Test Scripts updates | 16d? | 2024-10-14 A | 2024-11-04 A | 995FS-1d | 100% |  |
| 997 |  | RTTM Updated | 1d? | 2024-10-29 A | 2024-10-29 A | 996FS-5d | 100% |  |
| 998 |  | Removal of de-scoped TCs from the RTTMs | 2d | 2024-10-31 A | 2024-11-01 A | 996FS-3d | 100% |  |
| 999 |  | Update and stabilisation of all TC ADO IDs | 2d | 2024-10-31 A | 2024-11-01 A | 996FS-3d | 100% |  |
| 1000 |  | Addition and integration of Role tags to reqs in the Role RTTMs | 3d | 2024-10-30 A | 2024-11-01 A | 996FS-4d | 100% |  |
| 1001 |  | Update of the RTTM All sheet (porting of the individual RTTMs) | 2d | 2024-10-31 A | 2024-11-01 A | 996FS-3d | 100% |  |
| 1002 |  | ADO IDs corrected | 1d? | 2024-11-04 A | 2024-11-04 A | 1001 | 100% | start no earlier than 2024-10-16 |
| 1003 |  | Migration RTTM ready for import into ADO | 0d | 2024-11-04 A | 2024-11-04 A | 1002 | 100% |  |
| 1004 |  | Issue Static RTTM to Code Bodies | 1d? | 2024-11-05 A | 2024-11-05 A | 1003 | 100% |  |
| 1005 |  | Implement Code Bodies feedback on RTTM | 6d | 2024-11-06 A | 2024-11-13 A | 1004 | 100% |  |
| 1006 |  | Code Body Acceptance of RTTM | 0d | 2024-11-13 A | 2024-11-13 A | 1004, 1005 | 100% |  |
| 1007 | 1.4.1.4.3.3.5.16 | **ADO Clean-up** | 17d? | 2024-10-24 | 2024-11-15 A |  | 100% |  |
| 1008 |  | Theme alignment | 1d? | 2024-10-28 A | 2024-10-28 A |  | 100% | start no earlier than 2024-10-28 |
| 1009 |  | Understand Additional suffix Fields in ADO as defined by Kevin | 1d? | 2024-10-25 A | 2024-10-25 A |  | 100% | finish no earlier than 2024-10-25 |
| 1010 |  | Correct Missing Test Case References | 1d? | 2024-10-28 A | 2024-10-28 A |  | 100% | start no earlier than 2024-10-28 |
| 1011 |  | Load Functional RTTMs into ADO | 1d? | 2024-10-28 A | 2024-10-28 A |  | 100% | start no earlier than 2024-10-28 |
| 1012 |  | Load Migration RTTMs into ADO | 1d? | 2024-11-06 A | 2024-11-06 A |  | 100% | start no earlier than 2024-11-06 |
| 1013 |  | Confirm Missing fields in ADO are resolved | 1d? | 2024-11-07 A | 2024-11-07 A |  | 100% | finish no earlier than 2024-11-07 |
| 1014 |  | Reload Functional RTTM into ADO | 1d? | 2024-11-07 A | 2024-11-07 A |  | 100% | start no earlier than 2024-11-07 |
| 1015 | 1.4.1.4.3.3.5.16.8 | **ADO Design Documentation** | 10d? | 2024-11-04 | 2024-11-15 A |  | 100% |  |
| 1016 |  | Produce ADO high Level Design and Data Model | 1d? | 2024-11-15 A | 2024-11-15 A |  | 100% | finish no earlier than 2024-11-15 |
| 1017 |  | Produce Report derivation document | 1d? | 2024-11-15 A | 2024-11-15 A |  | 100% | finish no earlier than 2024-11-15 |
| 1018 | 1.4.1.4.3.3.5.17 | **Test Case Rationalisation (Functional + Migration)** | 67d | 2024-11-07 A | 2025-02-07 A |  | 100% |  |
| 1019 |  | Internal preliminary rationalisation workshop 1 | 1d | 2024-11-07 A | 2024-11-07 A | 1004FS+1d | 100% |  |
| 1020 |  | Baseline RTTMs | 0d | 2024-11-13 A | 2024-11-13 A | 1006, 874 | 100% |  |
| 1021 |  | Baseline test cases | 0d | 2024-11-13 A | 2024-11-13 A | 1006 | 100% |  |
| 1022 |  | Produce requirements / test case analysis doc | 1d | 2024-11-14 A | 2024-11-14 A | 1021 | 100% |  |
| 1023 |  | Internal finalisation rationalisation workshop 2 | 13d | 2024-11-15 A | 2024-12-03 A | 1022 | 100% |  |
| 1024 |  | SRO walkthrough | 1d | 2024-12-04 A | 2024-12-04 A | 1023 | 100% |  |
| 1025 |  | Code Bodies walkthrough | 1d | 2024-12-04 A | 2024-12-04 A | 1023 | 100% |  |
| 1026 |  | Send invites to PPs for walkthrough | 1d | 2024-12-04 A | 2024-12-04 A | 1025FS-1d | 100% |  |
| 1027 |  | PP walkthrough | 1d | 2024-12-17 A | 2024-12-17 A | 1026FS+8d | 100% |  |
| 1028 |  | Update requirements / test case analysis doc | 29d | 2024-12-05 A | 2025-01-14 A | 1026 | 100% |  |
| 1029 |  | SITWG Paper Day | 0d | 2025-01-14 A | 2025-01-14 A | 1028 | 100% |  |
| 1030 |  | SITWG recommendation on requirements / test case analysis doc | 0d | 2025-01-21 A | 2025-01-21 A | 1029FS+5d | 100% |  |
| 1031 |  | Issue to SITAG / SITAG paper day | 0d | 2025-01-22 A | 2025-01-22 A | 1030FS+1d | 100% |  |
| 1032 |  | Prepare ADO update | 6d | 2025-01-22 A | 2025-01-29 A | 1030 | 100% |  |
| 1033 |  | Sign off by SITAG | 0d | 2025-01-29 A | 2025-01-29 A | 1031FS+5d | 100% |  |
| 1034 |  | Update ADO | 7d | 2025-01-30 A | 2025-02-07 A | 1033 | 100% |  |
| 1035 |  | Update all ADO reporting | 7d | 2025-01-30 A | 2025-02-07 A | 1033 | 100% |  |
| 1036 |  | Update test cases | 7d | 2025-01-30 A | 2025-02-07 A | 1033 | 100% |  |
| 1037 |  | Update RTTM | 7d | 2025-01-30 A | 2025-02-07 A | 1033 | 100% |  |
| 1038 |  | Update master test case spreadsheet | 7d | 2025-01-30 A | 2025-02-07 A | 1033 | 100% |  |
| 1039 |  | Test Case Rationalisation complete | 0d | 2025-02-07 A | 2025-02-07 A | 1034, 1035, 1033, 1036, 1037, 1038 | 100% |  |
| 1040 | 1.4.1.4.3.4 | **Environments (SIT B)** | 435d | 2022-10-31 A | 2024-06-28 A |  | 100% |  |
| 1041 | 1.4.1.4.3.4.1 | **PP Environments (SIT B)** | 41d | 2024-05-03 A | 2024-06-28 A |  | 100% |  |
| 1042 |  | PP Environments available | 0d | 2024-05-03 A | 2024-05-03 A | 511 | 100% | start no earlier than 2024-05-03 |
| 1043 |  | PP Onboarding / Smoke test | 35d | 2024-05-13 A | 2024-06-28 A | 1042FS+6d | 100% |  |
| 1044 |  | DTN Connectivity Proving Complete | 5d | 2024-06-10 A | 2024-06-14 A | 1042FS+26d | 100% |  |
| 1045 |  | PP Code Deployment | 0d | 2024-06-14 A | 2024-06-14 A | 1044 | 100% |  |
| 1046 | 1.4.1.4.3.4.2 | **SI Environments (SIT B)** | 425d | 2022-10-31 A | 2024-06-14 A |  | 100% |  |
| 1047 |  | Coordinate SIT Participants' SIT B environment preparation | 420d | 2022-10-31 A | 2024-06-07 A |  | 100% |  |
| 1048 |  | Assure PPs' self-declaration of environment preparation complete (incl. security certificates and security compliance) | 0d | 2024-06-07 A | 2024-06-07 A | 1047 | 100% |  |
| 1049 |  | SIT Participants' SIT B environments ready to start connectivity proving (incl. certificates and security compliance) | 0d | 2024-06-05 A | 2024-06-05 A | 1042FS+24d | 100% |  |
| 1050 |  | Coordinate SIT Participants' SIT B environment connectivity proving | 2d | 2024-06-06 A | 2024-06-07 A | 1049 | 100% |  |

| ID | WBS | Task | Duration | Start | Finish | Predecessors | Complete | Constraint |
| --- | --- | --- | --- | --- | --- | --- | --- | --- |
| 1051 |  | Coordinate deployment of MHHS solution code to SIT Participants' SIT B environments | 0d | 2024-06-14 A | 2024-06-14 A | 1045 | 100% |  |
| 1052 | 1.4.1.4.3.5 | **SIT Migration Test Readiness Report** | 44d | 2024-04-02 A | 2024-05-31 A |  | 100% |  |
| 1053 | 1.4.1.4.3.5.1 | **PP SIT Migration Test Readiness Report** | 44d | 2024-04-02 A | 2024-05-31 A |  | 100% |  |
| 1054 |  | Develop draft Test Readiness Report and submit to Programme for assurance | 20d | 2024-04-02 A | 2024-04-29 A |  | 100% | start no earlier than 2024-04-02 |
| 1055 |  | Placing Reliance Stage 2 Review | 35d | 2024-04-15 A | 2024-05-31 A | 1054SS+9d | 100% |  |
| 1056 |  | Finalise Test Readiness Report and submit to Programme for assurance | 10d | 2024-04-30 A | 2024-05-13 A | 1054 | 100% |  |
| 1057 | 1.4.1.4.3.5.2 | **SI SIT Migration Test Readiness Report** | 40d | 2024-04-02 A | 2024-05-27 A |  | 100% |  |
| 1058 |  | Assure Test Participants' Test Readiness Reports | 35d | 2024-04-02 A | 2024-05-20 A | 1054SS, 1056FF+5d | 100% |  |
| 1059 |  | Develop Overarching SIT Migration Test Readiness Report | 20d | 2024-04-23 A | 2024-05-20 A | 1058FF | 100% |  |
| 1060 |  | Artefact review (via SITAG) and updates | 5d | 2024-05-21 A | 2024-05-27 A | 1059 | 100% |  |
| 1061 |  | SIT Migration Testing Preparation Complete | 0d | 2024-06-03 A | 2024-06-03 A | 1060FF+5d, 964, 359, 1055, 975, 981, 987 | 100% |  |
| 1062 | 1.4.1.4.4 | **SIT Non-Functional Preparation** | 347d? | 2023-11-30 A | 2025-03-28 A |  | 100% |  |
| 1063 | 1.4.1.4.4.1 | **Test Approach & Plan** | 120d | 2023-11-30 A | 2024-05-15 A |  | 100% |  |
| 1064 |  | Develop document with SITWG | 67d | 2023-11-30 A | 2024-03-01 A |  | 100% | must start on 2023-11-30 |
| 1065 |  | Draft document review with Code Bodies | 10d | 2024-03-04 A | 2024-03-15 A | 1064 | 100% |  |
| 1066 |  | Industry Consultation | 10d | 2024-03-18 A | 2024-03-29 A | 1065 | 100% |  |
| 1067 |  | Industry Assurance Review | 5d | 2024-04-11 A | 2024-04-17 A | 1066FS+8d | 100% |  |
| 1068 |  | SIT Non-Functional Testing Test Approach & Plan approved | 0d | 2024-05-15 A | 2024-05-15 A | 1067FS+20d | 100% |  |
| 1069 | 1.4.1.4.4.2 | **Test Data Approach & Plan** | 41d | 2024-03-20 A | 2024-05-15 A |  | 100% |  |
| 1070 |  | Industry Consultation | 14d | 2024-03-20 A | 2024-04-08 A | 1066SS+2d | 100% |  |
| 1071 |  | Artefact review (via SITAG) and updates | 27d | 2024-04-09 A | 2024-05-15 A | 1070 | 100% |  |
| 1072 |  | SIT Non-Functional Testing Test Data Approach & Plan approved | 0d | 2024-05-15 A | 2024-05-15 A | 1068FF, 1071 | 100% |  |
| 1073 | 1.4.1.4.4.3 | **Test scenarios & Test Cases** | 98d? | 2024-03-04 A | 2024-07-17 |  | 100% |  |
| 1074 | 1.4.1.4.4.3.1 | **Theme 1** | 78d | 2024-03-04 A | 2024-06-19 A |  | 100% |  |
| 1075 |  | Develop Test Scenarios & Test Cases | 33d | 2024-03-04 A | 2024-04-17 A | 1064 | 100% |  |
| 1076 |  | Industry Review Workshop | 1d | 2024-04-18 A | 2024-04-18 A | 1075 | 100% |  |
| 1077 |  | Industry Consultation Review | 7d | 2024-05-02 A | 2024-05-10 A | 1076FS+9d | 100% |  |
| 1078 |  | Review with NFT Working Group | 5d | 2024-05-31 A | 2024-06-06 A | 1077FS+14d | 100% |  |
| 1079 |  | SIT NFT Scenarios & Test Cases Approved - Theme 1 | 0d | 2024-06-19 A | 2024-06-19 A | 1078FS+9d | 100% |  |
| 1080 | 1.4.1.4.4.3.2 | **Theme 2** | 98d | 2024-03-04 A | 2024-07-17 A |  | 100% |  |
| 1081 |  | Develop Test Scenarios & Test Cases | 53d | 2024-03-04 A | 2024-05-15 A | 1064 | 100% |  |
| 1082 |  | Industry Review Workshop | 1d | 2024-05-16 A | 2024-05-16 A | 1081 | 100% |  |
| 1083 |  | Industry Consultation Review | 7d | 2024-05-20 A | 2024-05-28 A | 1082FS+1d | 100% |  |
| 1084 |  | Review with NFT Working Group | 5d | 2024-06-28 A | 2024-07-04 A | 1083FS+22d | 100% |  |
| 1085 |  | SIT NFT Scenarios & Test Cases Approved - Theme 2 | 0d | 2024-07-17 A | 2024-07-17 A | 1084FS+9d | 100% |  |
| 1086 | 1.4.1.4.4.3.3 | **Theme 3** | 98d? | 2024-03-04 A | 2024-07-17 |  | 100% |  |
| 1087 |  | Develop Test Scenarios & Test Cases | 63d | 2024-03-04 A | 2024-05-29 A | 1064 | 100% |  |
| 1088 |  | Industry Review Workshop | 1d | 2024-05-30 A | 2024-05-30 A | 1087 | 100% |  |
| 1089 |  | Industry Consultation Review | 6d | 2024-06-10 A | 2024-06-17 A | 1088FS+6d | 100% |  |
| 1090 |  | Review with NFT Working Group | 5d | 2024-06-28 A | 2024-07-04 A | 1089FS+8d | 100% |  |
| 1091 |  | SIT NFT Scenarios & Test Cases Approved - Theme 3 | 0d | 2024-09-18 A | 2024-09-18 A | 1090FS+9d | 100% | start no earlier than 2024-09-18 |
| 1092 | 1.4.1.4.4.4 | **SIT NFT Programme RTTM** | 45d | 2024-09-18 A | 2024-11-19 A |  | 100% |  |
| 1093 |  | Develop Manual SIT NFT RTTM | 30d | 2024-09-18 A | 2024-10-29 A | 1091 | 100% |  |
| 1094 |  | LDP peer review | 10d | 2024-10-30 A | 2024-11-12 A | 1093 | 100% |  |
| 1095 |  | Review with SRO | 5d | 2024-11-13 A | 2024-11-19 A | 1094 | 100% |  |
| 1096 |  | DIP Manager / Code Bodies / Full SRO to review | 5d | 2024-11-13 A | 2024-11-19 A | 1094 | 100% |  |
| 1097 |  | DIP Manager / Code Bodies / Full SRO acceptance of RTTM | 0d | 2024-11-19 A | 2024-11-19 A | 1096 | 100% |  |
| 1098 |  | Manual SIT NFT RTTM Complete | 0d | 2024-11-19 A | 2024-11-19 A | 1095, 1096 | 100% |  |
| 1099 | 1.4.1.4.4.5 | **NFT (Theme 1, 2 and 3) DITL** | 18d | 2025-02-03 A | 2025-02-26 A |  | 100% |  |
| 1100 |  | DITL Development | 10d | 2025-02-03 A | 2025-02-14 A |  | 100% | start no earlier than 2025-02-03 |
| 1101 |  | SRO Review | 5d | 2025-02-17 A | 2025-02-21 A | 1100 | 100% |  |
| 1102 |  | Post-SRO Review Changes | 3d | 2025-02-24 A | 2025-02-26 A | 1101 | 100% |  |
| 1103 |  | Programme DITL walkthrough with PPs on Theme 1, 2 and 3 | 0d | 2025-02-26 A | 2025-02-26 A | 1102 | 100% |  |
| 1104 | 1.4.1.4.4.6 | **NFT Performance Tool Theme 1 Setup** | 268d? | 2024-03-04 A | 2025-03-12 A |  | 100% |  |
| 1105 |  | Theme 1 injection tool initial POC | 85d? | 2024-03-04 A | 2024-06-28 A |  | 100% |  |
| 1106 |  | Theme 1 injection tool configuration and validation against DIP SIM (IR7.1) | 38d | 2024-07-01 A | 2024-08-21 A | 1105 | 100% |  |
| 1107 |  | Theme 1 injection tool configuration and validation against DIP SIM (IR8.1) | 29d | 2024-08-22 A | 2024-10-01 A | 1106 | 100% |  |
| 1108 |  | Theme 1 injection tool configuration and validation againast UIT DIP (IR8.1) | 11d | 2024-10-02 A | 2024-10-16 A | 1107 | 100% |  |
| 1109 |  | Theme 1 injection tool configuration and validation against SIT-B DIP (IR8.4) | 3d? | 2025-03-10 A | 2025-03-12 A | 1557FS+10d | 100% |  |
| 1110 | 1.4.1.4.4.7 | **Environments (SIT B)** | 134d | 2024-08-27 A | 2025-02-28 A |  | 100% |  |
| 1111 | 1.4.1.4.4.7.1 | **PP Environments (SIT B)** | 0d | 2024-08-27 A | 2024-08-27 A |  | 100% |  |
| 1112 |  | Deployment of MHHS solution code to SIT B environments | 0d | 2024-08-27 A | 2024-08-27 A |  | 100% | start no earlier than 2024-08-27 |
| 1113 | 1.4.1.4.4.7.2 | **SI Environments (SIT B)** | 0d | 2024-08-27 A | 2024-08-27 A |  | 100% |  |
| 1114 |  | Coordinate deployment of MHHS solution code to SIT Participants' SIT B environments | 0d | 2024-08-27 A | 2024-08-27 A | 1112SS | 100% |  |
| 1115 | 1.4.1.4.4.7.3 | **Helix and Avanade Environments Upscale** | 5d | 2025-02-24 A | 2025-02-28 A |  | 100% |  |
| 1116 |  | Environment Uplift Window (Technical Check) | 5d | 2025-02-24 A | 2025-02-28 A | 1557 | 100% |  |
| 1117 | 1.4.1.4.4.8 | **SIT Non-Functional Execution Model** | 42d | 2025-01-20 A | 2025-03-18 A |  | 100% |  |
| 1118 | 1.4.1.4.4.8.1 | **Theme 1** | 22d | 2025-01-20 A | 2025-02-18 A |  | 100% |  |
| 1119 |  | Develop execution model Theme 1 | 3d | 2025-01-20 A | 2025-01-22 A |  | 100% | start no earlier than 2025-01-20 |
| 1120 |  | SRO provide feedback | 5d | 2025-01-23 A | 2025-01-29 A | 1119 | 100% |  |

| ID | WBS | Task | Duration | Start | Finish | Predecessors | Complete | Constraint |
| --- | --- | --- | --- | --- | --- | --- | --- | --- |
| 1121 |  | Address SRO feedback on execution model | 2d | 2025-01-30 A | 2025-01-31 A | 1120 | 100% |  |
| 1122 |  | Finalise execution model | 3d | 2025-02-03 A | 2025-02-05 A | 1121 | 100% |  |
| 1123 |  | NFTWG paper day | 0d | 2025-02-11 A | 2025-02-11 A | 1122FS+4d | 100% |  |
| 1124 |  | NFTWG update on execution model | 0d | 2025-02-18 A | 2025-02-18 A | 1123FS+5d | 100% |  |
| 1125 | 1.4.1.4.4.8.2 | **Theme 2 & 3** | 42d | 2025-01-20 A | 2025-03-18 A |  | 100% |  |
| 1126 |  | Develop execution model Theme 2 & 3 | 3d | 2025-01-20 A | 2025-01-22 A |  | 100% | start no earlier than 2025-01-20 |
| 1127 |  | SRO provide feedback | 5d | 2025-01-23 A | 2025-01-29 A | 1126 | 100% |  |
| 1128 |  | Address SRO feedback on execution model | 2d | 2025-01-30 A | 2025-01-31 A | 1127 | 100% |  |
| 1129 |  | Finalise execution model | 3d | 2025-02-03 A | 2025-02-05 A | 1128 | 100% |  |
| 1130 |  | NFTWG paper day | 0d | 2025-03-11 A | 2025-03-11 A | 1129FS+24d | 100% |  |
| 1131 |  | NFTWG update on execution model | 0d | 2025-03-18 A | 2025-03-18 A | 1130FS+5d | 100% |  |
| 1132 | 1.4.1.4.4.9 | **SIT Non-Functional Progress reporting** | 22d | 2025-01-23 A | 2025-02-21 A |  | 100% |  |
| 1133 |  | Determine reporting methodology | 2d | 2025-01-23 A | 2025-01-24 A | 1119, 1126 | 100% |  |
| 1134 |  | Implement reporting | 20d | 2025-01-27 A | 2025-02-21 A | 1133, 836, 376, 1079, 1085, 1091 | 100% |  |
| 1135 | 1.4.1.4.4.10 | **SIT Non-Functional Test Readiness Report** | 48d | 2025-01-21 A | 2025-03-28 A |  | 100% |  |
| 1136 | 1.4.1.4.4.10.1 | **SIT Non-Functional Theme 1 Overarching Test Readiness Report** | 29d | 2025-01-21 A | 2025-02-28 A |  | 100% |  |
| 1137 |  | Develop Overarching SIT Non-Functional Theme 1 Overarching Test Readiness Report | 11d | 2025-01-21 A | 2025-02-04 A | 376 | 100% | finish no earlier than 2025-02-04 |
| 1138 |  | SRO review | 5d | 2025-02-05 A | 2025-02-11 A | 1137 | 100% | finish no earlier than 2025-02-10 |
| 1139 |  | NFTWG paper day | 0d | 2025-02-11 A | 2025-02-11 A | 1138 | 100% | finish no earlier than 2025-02-11 |
| 1140 |  | NFTWG review the Non-Functional Theme 1 Overarching Test Readiness Report | 0d | 2025-02-18 A | 2025-02-18 A | 1139FS+5d | 100% |  |
| 1141 |  | Update Non-Functional Theme 1 Overarching Test Readiness Report following SRO / NFTWG feedback | 6d | 2025-02-19 A | 2025-02-26 A | 1138, 1140 | 100% | finish no earlier than 2025-02-26 |
| 1142 |  | FTIG Recommendation | 0d | 2025-02-21 A | 2025-02-21 A | 1140FS+3d | 100% |  |
| 1143 |  | eSITAG paper day | 0d | 2025-02-26 A | 2025-02-26 A | 1141 | 100% | finish no earlier than 2025-02-21 |
| 1144 |  | eSITAG approve Non-Functional Theme 1 Overarching Test Readiness Report | 0d | 2025-02-28 A | 2025-02-28 A | 1388 | 100% |  |
| 1145 | 1.4.1.4.4.10.2 | **SIT Non-Functional Overarching Test Readiness Report Theme 2 & 3** | 28d | 2025-02-18 A | 2025-03-28 A |  | 100% |  |
| 1146 |  | Develop Overarching SIT Non-Functional Overarching Test Readiness Report Theme 2 & 3 | 11d | 2025-02-18 A | 2025-03-04 A |  | 100% | finish no earlier than 2025-03-04 |
| 1147 |  | SRO review | 5d | 2025-03-05 A | 2025-03-11 A | 1146SS | 100% | start no earlier than 2025-03-05 |
| 1148 |  | NFTWG paper day | 0d | 2025-03-11 A | 2025-03-11 A | 1147 | 100% | finish no earlier than 2025-03-11 |
| 1149 |  | NFTWG review the Non-Functional Overarching Test Readiness Report Theme 2 & 3 | 0d | 2025-03-18 A | 2025-03-18 A | 1148FS+5d | 100% | finish no earlier than 2025-03-18 |
| 1150 |  | Update Non-Functional Overarching Test Readiness Report Theme 2 & 3 following SRO / NFTWG feedback | 6d | 2025-03-19 A | 2025-03-26 A | 1147, 1149 | 100% |  |
| 1151 |  | GLIG Recommendation | 0d | 2025-03-21 A | 2025-03-21 A | 1149FS+3d | 100% |  |
| 1152 |  | eSITAG paper day | 0d | 2025-03-26 A | 2025-03-26 A | 1150, 1151 | 100% | start no earlier than 2025-03-21 |
| 1153 |  | eSITAG approve Non-Functional Overarching Test Readiness Report Theme 2 & 3 | 0d | 2025-03-28 A | 2025-03-28 A | 1152, 1389FS-1d, 1390 | 100% |  |
| 1154 |  | SIT Non-Functional Testing Preparation Complete Theme 1 | 0d | 2025-02-28 A | 2025-02-28 A | 1388 | 100% | start no earlier than 2025-02-28 |
| 1155 |  | SIT Non-Functional Testing Preparation Complete Theme 2 & 3 | 0d | 2025-03-28 A | 2025-03-28 A | 377FS+5d, 1389, 1390, 1131, 1134, 1109, 1103, 1098 | 100% |  |
| 1156 | 1.4.1.4.5 | **SIT Operational Preparation** | 670d? | 2022-10-31 | 2025-05-23 A |  | 100% |  |
| 1157 | 1.4.1.4.5.1 | **Test Approach & Plan** | 75d | 2024-02-01 A | 2024-05-15 A |  | 100% |  |
| 1158 |  | Develop document with SITWG | 25d | 2024-02-01 A | 2024-03-06 A |  | 100% | must start on 2024-02-01 |
| 1159 |  | Draft document review with Code Bodies | 4d | 2024-03-21 A | 2024-03-26 A | 1158FS+10d | 100% |  |
| 1160 |  | Industry Consultation | 10d | 2024-03-27 A | 2024-04-09 A | 1159 | 100% |  |
| 1161 |  | Artefact review (via SITAG) and updates | 26d | 2024-04-10 A | 2024-05-15 A | 1160 | 100% |  |
| 1162 |  | SIT Operational Testing Test Approach & Plan approved | 0d | 2024-05-15 A | 2024-05-15 A | 1161 | 100% |  |
| 1163 | 1.4.1.4.5.2 | **Test Data Approach & Plan** | 36d | 2024-03-27 A | 2024-05-15 A |  | 100% |  |
| 1164 |  | Industry Consultation | 10d | 2024-03-27 A | 2024-04-09 A | 1160SS | 100% |  |
| 1165 |  | Artefact review (via SITAG) and updates | 26d | 2024-04-10 A | 2024-05-15 A | 1164 | 100% |  |
| 1166 |  | SIT Operational Testing Test Data Approach & Plan approved | 0d | 2024-05-15 A | 2024-05-15 A | 1165 | 100% |  |
| 1167 | 1.4.1.4.5.3 | **Theme 1 & 2 Test Cases Approved** | 108d | 2024-04-10 A | 2024-09-06 A |  | 100% |  |
| 1168 | 1.4.1.4.5.3.1 | **Theme 1** | 108d | 2024-04-10 A | 2024-09-06 A |  | 100% |  |
| 1169 |  | Develop Test Scenarios & Test Cases | 53d | 2024-04-10 A | 2024-06-21 A | 1160 | 100% |  |
| 1170 |  | Industry Review Workshop | 1d | 2024-06-24 A | 2024-06-24 A | 1169 | 100% |  |
| 1171 |  | Industry Consultation Review | 6d | 2024-07-02 A | 2024-07-09 A | 1170FS+17d | 100% |  |
| 1172 |  | Review with SIT Working Group | 5d | 2024-08-19 A | 2024-08-23 A | 1171FS+16d | 100% |  |
| 1173 |  | SIT Operational Scenarios & Test Cases Approved - Theme 1 | 0d | 2024-09-06 A | 2024-09-06 A | 1172FS+10d | 100% | start no earlier than 2024-09-06 |
| 1174 | 1.4.1.4.5.3.2 | **Theme 2** | 107d | 2024-04-10 A | 2024-09-06 A |  | 100% |  |
| 1175 |  | Develop Test Scenarios & Test Cases | 53d | 2024-04-10 A | 2024-06-21 A | 1160 | 100% | finish no earlier than 2024-06-21 |
| 1176 |  | Industry Review Workshop | 1d | 2024-06-24 A | 2024-06-24 A | 1175 | 100% |  |
| 1177 |  | Industry Consultation Review | 6d | 2024-07-02 A | 2024-07-09 A | 1176FS+7d | 100% |  |
| 1178 |  | Review with SIT Working Group | 5d | 2024-08-19 A | 2024-08-23 A | 1177FS+11d | 100% |  |
| 1179 |  | SIT Operational Scenarios & Test Cases Approved - Theme 2 | 0d | 2024-09-06 A | 2024-09-06 A | 1178FS+10d | 100% |  |
| 1180 | 1.4.1.4.5.4 | **Environments (SIT B)** | 0d | 2024-10-07 A | 2024-10-07 A |  | 100% |  |
| 1181 | 1.4.1.4.5.4.1 | **PP Environments (SIT B)** | 0d | 2024-10-07 A | 2024-10-07 A |  | 100% |  |
| 1182 |  | Deployment of MHHS solution code to SIT B environments | 0d | 2024-10-07 A | 2024-10-07 A | 141 | 100% | start no earlier than 2024-08-27 |
| 1183 | 1.4.1.4.5.4.2 | **SI Environments (SIT B)** | 0d | 2024-10-07 A | 2024-10-07 A |  | 100% |  |
| 1184 |  | Coordinate deployment of MHHS solution code to SIT Participants' SIT B environments | 0d | 2024-10-07 A | 2024-10-07 A | 1182SS | 100% |  |
| 1185 | 1.4.1.4.5.5 | **SIT Operations Manual** | 590d? | 2022-10-31 | 2025-01-31 A |  | 100% |  |
| 1186 | 1.4.1.4.5.5.1 | **Version 1 SIT Operations Manual** | 35d | 2024-10-07 A | 2024-11-22 A |  | 100% |  |
| 1187 |  | Creation of SIT Operations Manual Template | 8d | 2024-10-07 A | 2024-10-16 A |  | 100% | start no earlier than 2024-10-07 |
| 1188 |  | November TORWG Paper Day | 0d | 2024-11-07 A | 2024-11-07 A | 1187FS+16d | 100% |  |
| 1189 |  | November TORWG (Timeline and Next Steps for SIT Operations Manual) | 0d | 2024-11-14 A | 2024-11-14 A | 1188FS+5d | 100% |  |
| 1190 |  | SIT Operations Manual Version 1 Shared with MHHSP | 0d | 2024-11-11 A | 2024-11-11 A | 1187FS+18d | 100% |  |

| ID | WBS | Task | Duration | Start | Finish | Predecessors | Complete | Constraint |
| --- | --- | --- | --- | --- | --- | --- | --- | --- |
| 1191 |  | MHHSP provide feedback on SIT Operations Manual Version 1 | 9d | 2024-11-12 A | 2024-11-22 A | 1190 | 100% |  |
| 1192 |  | SIT Operations Manual Version 1 Shared with Programme Participants | 0d | 2024-11-13 A | 2024-11-13 A | 1187FS+20d | 100% |  |
| 1193 |  | PPs provide feedback on SIT Operations Manual Version 1 | 7d | 2024-11-14 A | 2024-11-22 A | 1192 | 100% |  |
| 1194 |  | Programme Participants and MHHSP Feedback and Actions Received (SIT Ops Manual Version 1) | 0d | 2024-11-22 A | 2024-11-22 A | 1193, 1191 | 100% |  |
| 1195 | 1.4.1.4.5.5.2 | **Version 2 SIT Operations Manual** | 27d | 2024-11-12 A | 2024-12-18 A |  | 100% |  |
| 1196 |  | Version 2 SIT Operations Manual (Composition) | 12d | 2024-11-12 A | 2024-11-27 A | 1188FS+2d | 100% |  |
| 1197 |  | Version 2 SIT Operations Manual Completed | 0d | 2024-11-27 A | 2024-11-27 A | 1196 | 100% |  |
| 1198 |  | Version 2 SIT Operations Manual Shared with MHHSP & PPs for TORWG (Consultation Starts) | 0d | 2024-11-27 A | 2024-11-27 A | 1197 | 100% |  |
| 1199 |  | Version 2 SIT Ops Manual - PP Consultation (Iterative Feedback Process) | 10d | 2024-11-28 A | 2024-12-11 A | 1198 | 100% |  |
| 1200 |  | Version 2 SIT Ops Manual - PP Consultation Completed | 0d | 2024-12-11 A | 2024-12-11 A | 1199 | 100% |  |
| 1201 |  | December TORWG Paper Day | 0d | 2024-12-04 A | 2024-12-04 A | 1196FS+5d | 100% |  |
| 1202 |  | December TORWG (Initial Feedback, Common Themes and Comments) | 0d | 2024-12-11 A | 2024-12-11 A | 1201FS+5d | 100% |  |
| 1203 |  | December Extraordinary TORWG Paper Day | 0d | 2024-12-11 A | 2024-12-11 A | 1200 | 100% |  |
| 1204 |  | Publication of key themes from consultation to eTORWG | 2d | 2024-12-12 A | 2024-12-13 A | 1203 | 100% |  |
| 1205 |  | December Extraordinary TORWG (Summary of Version 2 Feedback and Response Approach Shared with PPs) | 0d | 2024-12-18 A | 2024-12-18 A | 1204FS+3d | 100% |  |
| 1206 | 1.4.1.4.5.5.3 | **Version 3 (Final) SIT Operations Manual** | 44d | 2024-11-28 A | 2025-01-28 A |  | 100% |  |
| 1207 |  | Update SIT Operations Manual (Final) Version 3 (with Comments Received From Version 2) [Pre-Christmas Furlough] | 17d | 2024-11-28 A | 2024-12-20 A | 1197, 193FF | 100% |  |
| 1208 |  | Update SIT Operations Manual (Final) Version 3 (with Comments Received From Version 2) [Post-Christmas Furlough] | 5d | 2025-01-02 A | 2025-01-08 A | 1207FS+8d | 100% |  |
| 1209 |  | SIT Operations Manual (Final) Version 3 Completed | 0d | 2025-01-08 A | 2025-01-08 A | 1208 | 100% |  |
| 1210 |  | January TORWG Paper Day | 0d | 2025-01-08 A | 2025-01-08 A | 1209 | 100% |  |
| 1211 |  | January TORWG (SIT Operations Manual Agreement) [Assurance Meeting] | 0d | 2025-01-15 A | 2025-01-15 A | 1210FS+5d | 100% |  |
| 1212 |  | January MCAG Paper Day (Final SIT Operations Manual Submitted) | 0d | 2025-01-21 A | 2025-01-21 A | 1211FS+4d | 100% |  |
| 1213 |  | January MCAG (Final SIT Operations Manual Endorsement) [Advisory Group Sign-off] | 0d | 2025-01-28 A | 2025-01-28 A | 1212FS+5d | 100% |  |
| 1214 | 1.4.1.4.5.5.4 | **Elexon / Helix Service Now Test Prep** | 119d? | 2024-08-01 A | 2025-01-14 A |  | 100% |  |
| 1215 | 1.4.1.4.5.5.4.1 | **Incident Management Build** | 75d? | 2024-08-05 A | 2024-11-15 A |  | 100% |  |
| 1216 |  | Build | 40d | 2024-08-05 A | 2024-09-27 A |  | 100% | finish no earlier than 2024-09-27 |
| 1217 |  | Test | 15d | 2024-09-30 A | 2024-10-18 A | 1216 | 100% | finish no earlier than 2024-10-18 |
| 1218 |  | Deploy | 20d | 2024-10-21 A | 2024-11-15 A | 1217 | 100% | finish no earlier than 2024-11-15 |
| 1219 |  | Incident Management Build & Configuration Complete | 0d | 2024-11-15 A | 2024-11-15 A | 1218 | 100% |  |
| 1220 | 1.4.1.4.5.5.4.2 | **Major Incident Management Build & Configuration** | 0d? | 2024-11-15 | 2024-11-15 |  | 100% |  |
| 1221 |  | Build | 40d | 2024-10-02 A | 2024-11-26 A |  | 100% | finish no earlier than 2024-11-26 |
| 1222 |  | Test | 15d | 2024-11-27 A | 2024-12-17 A | 1221 | 100% | finish no earlier than 2024-12-17 |
| 1223 |  | Deploy | 20d | 2024-12-18 A | 2025-01-14 A | 1222 | 100% | finish no earlier than 2025-01-14 |
| 1224 |  | Major Incident Management Build & Configuration Complete | 0d | 2025-01-14 A | 2025-01-14 A | 1223 | 100% |  |
| 1225 | 1.4.1.4.5.5.4.3 | **Knowledge Management Build & Configuration** | 75d? | 2024-10-02 A | 2025-01-14 A |  | 100% |  |
| 1226 |  | Build | 40d | 2024-10-02 A | 2024-11-26 A |  | 100% | finish no earlier than 2024-11-26 |
| 1227 |  | Test | 15d | 2024-11-27 A | 2024-12-17 A | 1226 | 100% | finish no earlier than 2024-12-17 |
| 1228 |  | Deploy | 20d | 2024-12-18 A | 2025-01-14 A | 1227 | 100% | finish no earlier than 2025-01-14 |
| 1229 |  | Knowledge Management Build & Configuration Complete | 0d | 2025-01-14 A | 2025-01-14 A | 1228 | 100% |  |
| 1230 | 1.4.1.4.5.5.4.4 | **Problem Management Build & Configuration** | 1d? | 2024-08-01 | 2024-08-01 |  | 100% |  |
| 1231 |  | Build | 40d | 2024-10-02 A | 2024-11-26 A |  | 100% | finish no earlier than 2024-11-26 |
| 1232 |  | Test | 15d | 2024-11-27 A | 2024-12-17 A | 1231 | 100% | finish no earlier than 2024-12-17 |
| 1233 |  | Deploy | 20d | 2024-12-18 A | 2025-01-14 A | 1232 | 100% | finish no earlier than 2025-01-14 |
| 1234 |  | Problem Management Build & Configuration Complete | 0d | 2025-01-14 A | 2025-01-14 A | 1233 | 100% | start no earlier than 2025-01-14 |
| 1235 | 1.4.1.4.5.5.4.5 | **Change Management Build & Configuration** | 75d? | 2024-10-02 A | 2025-01-14 A |  | 100% |  |
| 1236 |  | Build | 40d | 2024-10-02 A | 2024-11-26 A |  | 100% | finish no earlier than 2024-11-26 |
| 1237 |  | Test | 15d | 2024-11-27 A | 2024-12-17 A | 1236 | 100% | finish no earlier than 2024-12-17 |
| 1238 |  | Deploy | 20d | 2024-12-18 A | 2025-01-14 A | 1237 | 100% | finish no earlier than 2025-01-14 |
| 1239 |  | Change Management Build & Configuration Complete | 0d | 2025-01-14 A | 2025-01-14 A | 1238 | 100% | start no earlier than 2025-01-14 |
| 1240 | 1.4.1.4.5.5.4.6 | **Service Catalogue Management Build & Configuration** | 75d? | 2024-10-02 A | 2025-01-14 A |  | 100% |  |
| 1241 |  | Build | 40d | 2024-10-02 A | 2024-11-26 A |  | 100% | finish no earlier than 2024-11-26 |
| 1242 |  | Test | 15d | 2024-11-27 A | 2024-12-17 A | 1241 | 100% | finish no earlier than 2024-12-17 |
| 1243 |  | Deploy | 20d | 2024-12-18 A | 2025-01-14 A | 1242 | 100% | finish no earlier than 2025-01-14 |
| 1244 |  | Service Catalogue Management Build & Configuration Complete | 0d | 2025-01-14 A | 2025-01-14 A | 1243 | 100% | start no earlier than 2025-01-14 |
| 1245 |  | ServiceNow SIT Ops Available | 0d? | 2025-01-14 A | 2025-01-14 A | 1219, 1224, 1229, 1234, 1239, 1244 | 100% | start no earlier than 2024-09-09 |
| 1246 | 1.4.1.4.5.5.4.8 | **Helix Service Management Documentation (Service Design Pack)** | 115d | 2024-08-01 A | 2025-01-08 A |  | 100% |  |
| 1247 |  | Document Drafting | 95d | 2024-08-01 A | 2024-12-11 A |  | 100% | finish no earlier than 2024-12-11 |
| 1248 |  | Internal Elexon Review | 3d | 2025-01-06 A | 2025-01-08 A | 1247 | 100% | finish no earlier than 2024-12-16 |
| 1249 |  | Elexon Service Panel Sign off | 0d | 2025-01-08 A | 2025-01-08 A | 1248 | 100% | start no earlier than 2024-12-20 |
| 1250 | 1.4.1.4.5.5.5 | **Incident Management Support** | 1d? | 2022-10-31 | 2022-10-31 |  | 100% |  |
| 1251 |  | Identify Relevant Stakeholders to Support Incident Management Process | 10d | 2024-12-02 A | 2024-12-13 A |  | 100% | start no earlier than 2024-12-02 |
| 1252 |  | Schedule Time to Upskill Stakeholders | 5d | 2024-12-16 A | 2024-12-20 A | 1251 | 100% |  |
| 1253 |  | Helix Stakeholders Attendance at MHHS Defect Triage Meetings [Meeting Dates to be Confirmed] | 10d | 2025-01-06 A | 2025-01-17 A | 1252FS+10d | 100% |  |
| 1254 |  | SIT Service Readiness (Elexon & Helix) Completed | 0d | 2025-01-17 A | 2025-01-17 A | 1253 | 100% |  |
| 1255 | 1.4.1.4.5.5.7 | **SIT Service Readiness (External Parties)** | 85d | 2024-10-07 A | 2025-01-31 A |  | 100% |  |
| 1256 | 1.4.1.4.5.5.7.1 | **Helix Engagement & Comms** | 71d | 2024-10-07 A | 2025-01-13 A |  | 100% |  |
| 1257 |  | Engagement Execution | 71d | 2024-10-07 A | 2025-01-13 A |  | 100% | finish no earlier than 2025-01-13 |
| 1258 |  | Information Gathering | 32d | 2024-11-29 A | 2025-01-13 A |  | 100% | finish no earlier than 2025-01-13 |
| 1259 |  | SIT Participants Preparation | 9d | 2024-11-28 A | 2024-12-10 A |  | 100% | start no earlier than 2024-11-28 |
| 1260 |  | SIT Service Readiness (External Parties) Completed | 0d | 2025-01-31 A | 2025-01-31 A | 1257FS+9d, 1258, 1259, 1277 | 100% |  |

| ID | WBS | Task | Duration | Start | Finish | Predecessors | Complete | Constraint |
| --- | --- | --- | --- | --- | --- | --- | --- | --- |
| 1261 | 1.4.1.4.5.5.8 | **ServiceNow Support Portal Onboarding (Helix Suppliers & SIT Participants)** | 78d? | 2024-10-02 A | 2025-01-17 |  | 100% |  |
| 1262 | 1.4.1.4.5.5.8.1 | **ServiceNow Portal Preparation and Planning** | 40d? | 2024-10-02 A | 2024-11-26 A |  | 100% |  |
| 1263 |  | Define Supplier Requirements | 30d? | 2024-10-02 A | 2024-11-12 A |  | 100% | start no earlier than 2024-10-02 |
| 1264 |  | Determine Supplier ServiceNow modules | 10d? | 2024-11-13 A | 2024-11-26 A | 1263 | 100% | finish no earlier than 2024-11-26 |
| 1265 |  | Review compliance requirements, including data privacy and access limitations. | 10d? | 2024-11-13 A | 2024-11-26 A | 1263 | 100% | finish no earlier than 2024-11-26 |
| 1266 |  | Conduct a security assessment to ensure the supplier complies with organisational policies. | 10d? | 2024-11-13 A | 2024-11-26 A | 1263 | 100% | finish no earlier than 2024-11-26 |
| 1267 | 1.4.1.4.5.5.8.2 | **ServiceNow Portal System Configuration** | 48d? | 2024-11-27 A | 2025-01-31 A |  | 100% |  |
| 1268 |  | Create Supplier User Accounts | 48d | 2024-11-27 A | 2025-01-31 A | 1266 | 100% | finish no earlier than 2025-01-31 |
| 1269 |  | Assign appropriate access based on the supplier’s needs and security requirements (e.g., read-only access, submit requests, etc.). | 25d? | 2024-12-30 A | 2025-01-31 A | 1268FF | 100% | finish no earlier than 2024-12-24 |
| 1270 |  | Configure Access Controls | 25d? | 2024-12-30 A | 2025-01-31 A | 1269FF | 100% | finish no earlier than 2025-01-07 |
| 1271 | 1.4.1.4.5.5.8.3 | **ServiceNow Portal Training and Documentation** | 20d? | 2025-01-06 A | 2025-01-31 A |  | 100% |  |
| 1272 |  | Provide Training to the Supplier | 1d | 2025-01-31 A | 2025-01-31 A |  | 100% | finish no earlier than 2025-01-31 |
| 1273 |  | Create Supplier Training Documentation | 20d | 2025-01-06 A | 2025-01-31 A |  | 100% | finish no earlier than 2025-01-31 |
| 1274 | 1.4.1.4.5.5.8.4 | **ServiceNow Portal Testing and Validation** | 18d | 2025-01-08 | 2025-01-31 A |  | 100% |  |
| 1275 |  | Conduct User Acceptance Testing (UAT) | 1d | 2025-01-31 A | 2025-01-31 A | 1272SS | 100% | finish no earlier than 2025-01-17 |
| 1276 |  | Validate Access and Security Controls | 4d | 2025-01-28 A | 2025-01-31 A |  | 100% | finish no earlier than 2025-01-31 |
| 1277 |  | ServiceNow Support Portal Onboarding (Helix Suppliers& SIT Participants) Completed | 0d | 2025-01-31 A | 2025-01-31 A | 1266, 1270, 1273, 1276, 1272 | 100% | start no earlier than 2025-01-17 |
| 1278 |  | Stage 1 - Helix SIT Operational Readiness Completed | 0d | 2025-01-31 A | 2025-01-31 A | 1260, 1245, 1213 | 100% | start no earlier than 2025-01-31 |
| 1279 | 1.4.1.4.5.6 | **Theme 3 Test Cases Approved** | 246d? | 2024-04-10 A | 2025-03-19 A |  | 100% |  |
| 1280 | 1.4.1.4.5.6.1 | **Theme 3 (Batch 2)** | 64d | 2024-09-19 A | 2024-12-18 A |  | 100% |  |
| 1281 |  | Conclude BCDR Scope with SRO, Code Bodies and DIP Manager | 22d | 2024-09-19 A | 2024-10-18 A |  | 100% | start no earlier than 2024-09-19 |
| 1282 |  | Develop BDCR Test Scenarios & Test Cases (Batch 2) | 10d | 2024-10-14 A | 2024-10-25 A | 1281 | 100% |  |
| 1283 |  | Develop DIP Test Scenarios and Test Cases (Batch 2) | 27d | 2024-09-19 A | 2024-10-25 A |  | 100% | start no earlier than 2024-09-19 |
| 1284 |  | SRO Review | 5d | 2024-10-28 A | 2024-11-01 A | 1283 | 100% | start no earlier than 2024-10-28 |
| 1285 |  | Industry Consultation (Batch 2) | 10d | 2024-11-11 A | 2024-11-22 A | 1284 | 100% |  |
| 1286 |  | Review Feedback and Update | 4d | 2024-11-25 A | 2024-11-28 A | 1285 | 100% |  |
| 1287 |  | SITWG paper day | 0d | 2024-11-28 A | 2024-11-28 A | 1286 | 100% |  |
| 1288 |  | Review with SIT WG (Batch 2) | 5d | 2024-11-29 A | 2024-12-05 A | 1287 | 100% |  |
| 1289 |  | SITWG endorse Theme 3 (Batch 2) | 0d | 2024-12-05 A | 2024-12-05 A | 1288 | 100% |  |
| 1290 |  | SITAG paper day | 0d | 2024-12-11 A | 2024-12-11 A | 1289FS+4d | 100% |  |
| 1291 |  | SITAG approve Theme 3 (Batch 2) | 0d | 2024-12-18 A | 2024-12-18 A | 1290FS+5d | 100% |  |
| 1292 | 1.4.1.4.5.6.2 | **Theme 3 (Batch 1)** | 181d? | 2024-04-10 A | 2024-12-18 A |  | 100% |  |
| 1293 |  | Develop Test Scenarios & Test Cases (Batch 1) | 78d | 2024-04-10 A | 2024-07-26 A | 1160 | 100% |  |
| 1294 |  | Conclude Industry Consultation (Batch 1) | 11d | 2024-09-05 A | 2024-09-19 A |  | 100% | start no earlier than 2024-09-05 |
| 1295 |  | Review Feedback and Update | 5d | 2024-09-20 A | 2024-09-26 A | 1294 | 100% |  |
| 1296 |  | Draft Test Cases from Feedback and LLSD | 15d? | 2024-09-30 A | 2024-10-18 A | 1295FS+1d, 1318 | 100% |  |
| 1297 |  | SRO Review | 5d? | 2024-10-21 A | 2024-10-25 A | 1296 | 100% |  |
| 1298 |  | Industry Consultation | 10d? | 2024-10-28 A | 2024-11-08 A | 1297 | 100% |  |
| 1299 |  | Review Feedback and Update | 10d | 2024-11-11 A | 2024-11-22 A | 1298 | 100% |  |
| 1300 |  | SITWG paper day | 0d | 2024-11-28 A | 2024-11-28 A | 1299FS+4d | 100% |  |
| 1301 |  | Review with SITWG (Batch 1) | 5d | 2024-11-29 A | 2024-12-05 A | 1300 | 100% |  |
| 1302 |  | SITWG endorse Theme 3 (Batch 1) | 0d | 2024-12-05 A | 2024-12-05 A | 1301 | 100% |  |
| 1303 |  | SITAG paper day | 0d | 2024-12-11 A | 2024-12-11 A | 1302FS+4d | 100% |  |
| 1304 |  | SITAG approve Theme 3 (Batch 1) | 0d | 2024-12-18 A | 2024-12-18 A | 1303FS+5d | 100% |  |
| 1305 |  | SIT Operational Scenarios & Test Cases Approved - Theme 3 (Batch 1 + 2) | 0d | 2024-12-18 A | 2024-12-18 A | 1318, 1291, 1304 | 100% |  |
| 1306 | 1.4.1.4.5.6.3 | **Theme 3 (Batch 2) Supplementary** | 33d | 2025-02-03 A | 2025-03-19 A |  | 100% |  |
| 1307 |  | Conclude DIP Onboarding / Offboarding Scope with DIP Manager | 5d | 2025-02-03 A | 2025-02-07 A |  | 100% | start no earlier than 2025-02-03 |
| 1308 |  | Develop DIP Onboarding / Offboarding Test Scenarios & Test Cases (Batch 2) Supplementary | 2d | 2025-02-10 A | 2025-02-11 A | 1307 | 100% |  |
| 1309 |  | SRO Review | 5d | 2025-02-12 A | 2025-02-18 A | 1308 | 100% |  |
| 1310 |  | Industry Consultation (Batch 2) Supplementary | 10d | 2025-02-19 A | 2025-03-04 A | 1309 | 100% |  |
| 1311 |  | SITWG Paper Day | 0d | 2025-02-27 A | 2025-02-27 A | 1310SS+7d, 1309FS+7d | 100% |  |
| 1312 |  | Review Feedback and Update | 1d | 2025-03-05 A | 2025-03-05 A | 1310 | 100% |  |
| 1313 |  | SITWG endorse Theme 3 (Batch 2) Supplementary | 0d | 2025-03-06 A | 2025-03-06 A | 1310, 1311, 1312FS+1d | 100% |  |
| 1314 |  | SITAG paper day | 0d | 2025-03-12 A | 2025-03-12 A | 1313FS+4d | 100% |  |
| 1315 |  | SITAG approve Theme 3 (Batch 2) Supplementary | 0d | 2025-03-19 A | 2025-03-19 A | 1314FS+5d | 100% |  |
| 1316 | 1.4.1.4.5.7 | **Helix SDD and LLSD Development and Approval** | 1d | 2024-09-27 A | 2024-09-30 A |  | 100% |  |
| 1317 |  | Development | 0d | 2024-09-27 A | 2024-09-27 A |  | 100% | start no earlier than 2024-09-27 |
| 1318 |  | Approval | 0d | 2024-09-30 A | 2024-09-30 A |  | 100% | start no earlier than 2024-09-30 |
| 1319 | 1.4.1.4.5.8 | **SIT Operational Programme RTTM (Theme 3 (Batch 1))** | 35d | 2024-12-09 A | 2025-01-24 A |  | 100% |  |
| 1320 |  | Develop SIT Operational Theme 3 (Batch 1) RTTM | 25d | 2024-12-09 A | 2025-01-10 A | 1305FF | 100% |  |
| 1321 |  | SRO review of SIT Operational Theme 3 (Batch 1) RTTM | 5d | 2025-01-13 A | 2025-01-17 A | 1320 | 100% |  |
| 1322 |  | DIP Manager / Code Bodies / Full SRO to review | 5d | 2025-01-20 A | 2025-01-24 A | 1321 | 100% |  |
| 1323 |  | DIP Manager / Code Bodies / Full SRO acceptance of Theme 3 (Batch 1) Operational RTTM | 0d | 2025-01-24 A | 2025-01-24 A | 1322 | 100% |  |
| 1324 |  | SIT Operational Theme 3 (Batch 1) RTTM Complete | 0d | 2025-01-24 A | 2025-01-24 A | 1320, 1323 | 100% |  |
| 1325 | 1.4.1.4.5.9 | **SIT Operational Programme RTTM (Theme 1, 2 & 3 (Batch 2))** | 100d | 2025-01-06 A | 2025-05-23 A |  | 100% |  |
| 1326 |  | Develop SIT Operational (Theme 1, 2 & 3 (Batch 2)) RTTM | 36d | 2025-01-06 A | 2025-02-24 A |  | 100% | start no earlier than 2025-01-06 |
| 1327 |  | SRO review of SIT Operational (Theme 1, 2 & 3 (Batch 2)) RTTM | 9d | 2025-02-25 A | 2025-03-07 A | 1326 | 100% |  |
| 1328 |  | DIP Manager / Code Bodies / Full SRO to review | 34d | 2025-03-10 A | 2025-04-24 A | 1327 | 100% |  |
| 1329 |  | Incorporate feedback | 34d | 2025-03-10 A | 2025-04-24 A | 1328FF | 100% |  |
| 1330 |  | DIP Manager / Code Bodies / SRO acceptance of (Theme 1, 2 & 3 (Batch 2)) Operational RTTM | 0d | 2025-04-25 A | 2025-04-25 A | 1328FS+1d | 100% |  |

| ID | WBS | Task | Duration | Start | Finish | Predecessors | Complete | Constraint |
| --- | --- | --- | --- | --- | --- | --- | --- | --- |
| 1331 |  | SIT Operational (Theme 1, 2 & 3 (Batch 2)) RTTM Complete | 0d | 2025-05-23 A | 2025-05-23 A | 1330 | 100% | finish no earlier than 2025-05-23 |
| 1332 | 1.4.1.4.5.10 | **SIT Operational Theme 3 (Batch 1) DITL** | 17d | 2025-01-06 A | 2025-01-28 A |  | 100% |  |
| 1333 |  | DITL + Familiarisation session development | 8d | 2025-01-06 A | 2025-01-15 A |  | 100% | start no earlier than 2025-01-06 |
| 1334 |  | SRO Review | 5d | 2025-01-16 A | 2025-01-22 A | 1333 | 100% |  |
| 1335 |  | Post-SRO Review Changes | 2d | 2025-01-23 A | 2025-01-24 A | 1334 | 100% |  |
| 1336 |  | Familiarisation session Service Management test case schedule + mapping | 0d | 2025-01-24 A | 2025-01-24 A | 1335 | 100% |  |
| 1337 |  | Publish Cycle 3 DITL / Cycle 3 DITL Online Sessions for SIT PPs | 0d | 2025-01-28 A | 2025-01-28 A | 1336FS+2d | 100% |  |
| 1338 | 1.4.1.4.5.11 | **SIT Operational Theme 1, 2 & 3 (Batch 2) DITL** | 23d | 2025-02-24 A | 2025-03-26 A |  | 100% |  |
| 1339 |  | DITL + Familiarisation session development | 15d | 2025-02-24 A | 2025-03-14 A |  | 100% | start no earlier than 2025-02-24 |
| 1340 |  | SRO Review | 5d | 2025-03-17 A | 2025-03-21 A | 1339 | 100% |  |
| 1341 |  | Post-SRO Review Changes | 3d | 2025-03-24 A | 2025-03-26 A | 1340 | 100% |  |
| 1342 |  | Familiarisation session Service Management test case schedule + mapping | 0d | 2025-03-26 A | 2025-03-26 A | 1341 | 100% |  |
| 1343 |  | Publish Cycle 3 DITL / Cycle 3 DITL Online Sessions for SIT PPs | 0d | 2025-03-26 A | 2025-03-26 A | 1342 | 100% |  |
| 1344 | 1.4.1.4.5.12 | **SIT Operational Defect Management** | 15d? | 2025-01-06 A | 2025-01-24 A |  | 100% |  |
| 1345 |  | Develop defect management approach | 10d? | 2025-01-06 A | 2025-01-17 A |  | 100% | start no earlier than 2025-01-06 |
| 1346 |  | Defect management approach agreed | 5d? | 2025-01-20 A | 2025-01-24 A | 1345 | 100% |  |
| 1347 | 1.4.1.4.5.13 | **SIT Operational Execution Model** | 43d? | 2024-08-05 | 2024-10-02 |  | 100% |  |
| 1348 | 1.4.1.4.5.13.1 | **Theme 3 (Batch 1)** | 27d | 2024-08-05 | 2024-09-10 |  | 100% |  |
| 1349 |  | Develop execution model Theme 3 (Batch 1) | 3d | 2024-12-16 A | 2024-12-18 A | 1305FF | 100% |  |
| 1350 |  | SRO provide feedback | 14d | 2024-12-19 A | 2025-01-07 A | 1349 | 100% |  |
| 1351 |  | Address SRO feedback on execution model | 2d | 2025-01-08 A | 2025-01-09 A | 1350 | 100% |  |
| 1352 |  | Finalise execution model | 3d | 2025-01-10 A | 2025-01-14 A | 1351 | 100% |  |
| 1353 |  | SITWG paper day | 0d | 2025-01-14 A | 2025-01-14 A | 1352 | 100% |  |
| 1354 |  | SITWG update on execution model | 0d | 2025-01-21 A | 2025-01-21 A | 1353FS+5d | 100% |  |
| 1355 | 1.4.1.4.5.13.2 | **Theme 1, 2 and 3 (Batch 2)** | 23d? | 2024-08-05 | 2024-09-04 |  | 100% |  |
| 1356 |  | Develop execution model Theme 1, 2 and 3 (Batch 2) | 10d | 2025-02-03 A | 2025-02-14 A | 1305 | 100% | start no earlier than 2025-02-03 |
| 1357 |  | SRO provide feedback | 5d | 2025-02-25 A | 2025-03-03 A | 1356 | 100% | finish no earlier than 2025-01-21 |
| 1358 |  | Address SRO feedback on execution model | 5d | 2025-03-04 A | 2025-03-10 A | 1357 | 100% |  |
| 1359 |  | Finalise execution model | 5d | 2025-03-11 A | 2025-03-17 A | 1358 | 100% |  |
| 1360 |  | Execution Model shared with industry | 0d | 2025-03-17 A | 2025-03-17 A | 1359 | 100% |  |
| 1361 | 1.4.1.4.5.13.3 | **SIT Operational Theme 3 (Batch 1) progress reporting** | 29d? | 2024-12-19 A | 2025-01-28 |  | 100% |  |
| 1362 |  | Determine reporting methodology | 2d? | 2024-12-19 A | 2024-12-20 A |  | 100% |  |
| 1363 |  | Implement reporting | 25d | 2024-12-23 A | 2025-01-24 A | 1362 | 100% |  |
| 1364 | 1.4.1.4.5.14 | **SIT Operational Overarching Test Readiness Reports** | 33d? | 2024-08-05 | 2024-09-18 |  | 100% |  |
| 1365 | 1.4.1.4.5.14.1 | **SI SIT Operational Theme 3 (Batch 1) Overarching Test Readiness Report** | 31d? | 2024-12-18 A | 2025-01-29 A |  | 100% |  |
| 1366 |  | Develop Overarching SIT Operational Theme 3 (Batch 1) Overarching Test Readiness Report | 20d | 2024-12-18 A | 2025-01-14 A | 393FF | 100% | finish no earlier than 2025-01-14 |
| 1367 |  | SRO review | 5d | 2025-01-08 A | 2025-01-14 A | 1366FF | 100% | finish no earlier than 2025-01-13 |
| 1368 |  | SITWG Paper day | 0d | 2025-01-14 A | 2025-01-14 A | 1367 | 100% | finish no earlier than 2025-01-14 |
| 1369 |  | SITWG review the Operational Theme 3 (Batch 1) Overarching Test Readiness Report | 0d | 2025-01-21 A | 2025-01-21 A | 1368FS+5d | 100% | finish no earlier than 2025-01-21 |
| 1370 |  | Update Operational Theme 3 (Batch 1) Overarching Test Readiness Report following SRO / SITWG feedback | 1d | 2025-01-22 A | 2025-01-22 A | 1369 | 100% | start no earlier than 2025-01-22 |
| 1371 |  | SITAG paper day | 0d | 2025-01-22 A | 2025-01-22 A | 1370 | 100% | finish no earlier than 2025-01-22 |
| 1372 |  | FTIG recommendation | 0d | 2025-01-24 A | 2025-01-24 A | 1370FS+2d | 100% |  |
| 1373 |  | Republish Operational Theme 3 (Batch 1) Overarching Test Readiness Report with latest data and evidence | 1d? | 2025-01-27 A | 2025-01-27 A | 1371FS+2d | 100% |  |
| 1374 |  | SITAG approve Theme 3 (Batch 1) Test Readiness Report | 0d | 2025-01-29 A | 2025-01-29 A | 1371FS+5d, 1213, 1373 | 100% | finish no earlier than 2025-01-29 |
| 1375 | 1.4.1.4.5.14.2 | **SI SIT Operational Theme 1, 2 and 3 (Batch 2) Overarching Test Readiness Report** | 45d | 2025-01-27 A | 2025-03-28 A |  | 100% |  |
| 1376 |  | Develop Overarching SIT Operational Theme 1, 2 and 3 (Batch 2) Overarching Test Readiness Report | 20d | 2025-01-27 A | 2025-02-21 A | 376FS+25d | 100% | start no earlier than 2025-01-20 |
| 1377 |  | SRO review | 5d | 2025-02-24 A | 2025-02-28 A | 1376 | 100% |  |
| 1378 |  | SITWG Paper day | 0d | 2025-02-27 A | 2025-02-27 A |  | 100% | finish no earlier than 2025-02-27 |
| 1379 |  | SITWG review the Operational Theme 1, 2 and 3 (Batch 2) Overarching Test Readiness Report | 0d | 2025-03-06 A | 2025-03-06 A | 1378SS+5d | 100% |  |
| 1380 |  | Update Operational Theme 1, 2 and 3 (Batch 2) Overarching Test Readiness Report following SRO feedback | 13d | 2025-03-07 A | 2025-03-25 A | 1379 | 100% | start no earlier than 2025-03-07 |
| 1381 |  | GLIG recommendation | 0d | 2025-03-21 A | 2025-03-21 A | 1379FS+11d | 100% |  |
| 1382 |  | eSITAG paper day | 0d | 2025-03-26 A | 2025-03-26 A | 1380 | 100% | finish no earlier than 2025-03-26 |
| 1383 |  | eSITAG approve Operational Theme 1, 2 and 3 (Batch 2) Overarching Test Readiness Report | 0d | 2025-03-28 A | 2025-03-28 A | 1381, 1391, 1392 | 100% |  |
| 1384 |  | SIT Operational Theme 3 (Batch 1) Testing Preparation Complete | 0d | 2025-01-31 A | 2025-01-31 A | 1374, 1277 | 100% |  |
| 1385 |  | SIT Operational Theme 1, 2, 3 (Batch 2) Testing Preparation Complete | 0d | 2025-03-28 A | 2025-03-28 A | 394, 1173, 1179, 1305, 1383, 1363, 1343, 1315 | 100% | finish no earlier than 2024-10-04 |
| 1386 | 1.4.1.4.5.17 | **Test Data - Non-Functional and Operational (SIT B)** | 25d? | 2025-02-24 A | 2025-03-28 A |  | 100% |  |
| 1387 | 1.4.1.4.5.17.1 | **Data Load** | 25d? | 2025-02-24 A | 2025-03-28 A |  | 100% |  |
| 1388 |  | Non-Functional Theme 1 (Avenade) Data Load | 5d? | 2025-02-24 A | 2025-02-28 A | 1557 | 100% |  |
| 1389 |  | Non-Functional Theme 2 & 3 (Helix, Avenade & PPs) Data Load | 5d | 2025-03-24 A | 2025-03-28 A | 1625 | 100% |  |
| 1390 |  | Non-Functional Themes 2 & 3 (LDSO's) Data Load | 15d | 2025-03-03 A | 2025-03-21 A | 1116 | 100% |  |
| 1391 |  | Operational Themes 1, 2 & 3 (Batch 2) (LDSO's) Data Load | 20d? | 2025-03-03 A | 2025-03-28 A | 1116 | 100% | start no earlier than 2025-01-06 |
| 1392 |  | Operational Themes 1, 2 & 3 (Batch 2) (Helix, Avenade & PPs) Data Load | 5d | 2025-03-24 A | 2025-03-28 A | 1625 | 100% |  |
| 1393 |  | Non-Functional and Operational Test Data Preparation Complete | 0d | 2025-03-28 A | 2025-03-28 A | 1392 | 100% |  |
| 1394 | 1.4.1.4.6 | **Regression Test Preparation** | 2d? | 2024-11-18 A | 2024-11-19 |  | 100% |  |
| 1395 | 1.4.1.4.6.1 | **Regression Test Approach** | 10d | 2024-11-18 A | 2024-11-29 |  | 100% |  |
| 1396 |  | Develop approach doc | 45d | 2024-11-18 A | 2025-01-17 A |  | 100% | start no earlier than 2024-09-16 |
| 1397 |  | SRO / LDP review of approach doc | 5d | 2025-01-20 A | 2025-01-24 A | 1396 | 100% |  |
| 1398 |  | Incorporate SRO feedback into approach doc | 5d | 2025-01-20 A | 2025-01-24 A | 1397FF | 100% |  |
| 1399 |  | Industry review of approach | 10d | 2025-01-27 A | 2025-02-07 A | 1398 | 100% |  |
| 1400 |  | Updates to approach doc on back of industry feedback | 2d | 2025-02-10 A | 2025-02-11 A | 1399 | 100% |  |

| ID | WBS | Task | Duration | Start | Finish | Predecessors | Complete | Constraint |
| --- | --- | --- | --- | --- | --- | --- | --- | --- |
| 1401 |  | eSITWG paper day | 0d | 2025-02-11 A | 2025-02-11 A | 1400 | 100% |  |
| 1402 |  | eSITWG Recommendation | 0d | 2025-02-18 A | 2025-02-18 A | 1401FS+5d | 100% | start no earlier than 2025-01-20 |
| 1403 |  | Incorporate eSITWG feedback into approach doc | 2d | 2025-02-19 A | 2025-02-20 A | 1402 | 100% |  |
| 1404 |  | eSITAG paper day | 0d | 2025-02-20 A | 2025-02-20 A | 1403 | 100% |  |
| 1405 |  | eSITAG (inc SRO) Approval | 0d | 2025-02-28 A | 2025-02-28 A | 1404FS+5d | 100% | finish no earlier than 2025-02-28 |
| 1406 |  | SIT Regression Testing Approach and Plan Approval | 0d | 2025-02-28 A | 2025-02-28 A | 1405 | 100% |  |
| 1407 | 1.4.1.4.6.2 | **Regression Core Test Pack** | 52d? | 2025-02-12 A | 2025-04-24 A |  | 100% |  |
| 1408 |  | Build Regression Core Pack | 17d | 2025-02-12 A | 2025-03-06 A | 1401, 1411FF | 100% | start no earlier than 2025-02-12 |
| 1409 |  | Build Regression Framework | 12d | 2025-02-12 A | 2025-02-27 A | 1401 | 100% |  |
| 1410 |  | SITWG paper day | 0d | 2025-02-27 A | 2025-02-27 A | 1409 | 100% | start no earlier than 2025-02-27 |
| 1411 |  | SITWG provides feedback on Regression Framework approach | 0d | 2025-03-06 A | 2025-03-06 A | 1410FS+5d | 100% |  |
| 1412 |  | LDP walkthrough of Regression Core Pack | 3d | 2025-02-27 A | 2025-03-03 A | 1408SS | 100% | start no earlier than 2025-02-27 |
| 1413 |  | SRO Review of Regression Core Pack | 6d | 2025-03-07 A | 2025-03-14 A | 1408SS | 100% | start no earlier than 2025-03-07 |
| 1414 |  | Incorporate SRO feedback into Regression Core Pack | 6d | 2025-03-07 A | 2025-03-14 A | 1413SS | 100% |  |
| 1415 |  | Industry review of Regression Core Pack | 10d | 2025-03-17 A | 2025-03-28 A | 1414, 1408 | 100% | start no earlier than 2025-03-13 |
| 1416 |  | Regression Test Framework Core Pack - PP Walkthrough | 1d? | 2025-03-20 A | 2025-03-20 A | 1415SS | 100% | start no earlier than 2025-03-20 |
| 1417 |  | Regression Test Framework Core Pack - Q&A Drop in session | 1d? | 2025-03-27 A | 2025-03-27 A | 1415SS | 100% | start no earlier than 2025-03-27 |
| 1418 |  | Incorporate Industry feedback into Regression Core Pack | 3d | 2025-03-31 A | 2025-04-02 A | 1415, 1416, 1417 | 100% |  |
| 1419 |  | Second industry review of Regression Core Pack | 5d | 2025-04-03 A | 2025-04-09 A | 1418 | 100% |  |
| 1420 |  | Incorporate industry feedback into regression Core Pack | 1d | 2025-04-10 A | 2025-04-10 A | 1419 | 100% |  |
| 1421 |  | SITWG paper day | 0d | 2025-04-08 A | 2025-04-08 A |  | 100% | finish no earlier than 2025-04-08 |
| 1422 |  | SITWG endorses regression Core Pack | 0d | 2025-04-15 A | 2025-04-15 A | 1421FS+3d | 100% | finish no earlier than 2025-04-15 |
| 1423 |  | Incorporate SITWG feedback into regression Core Pack | 2d | 2025-04-16 A | 2025-04-17 A | 1422 | 100% | start no earlier than 2025-04-16 |
| 1424 |  | Regression Test Approach and Plan Uplift | 0d | 2025-04-16 A | 2025-04-16 A | 1422 | 100% | start no earlier than 2025-04-16 |
| 1425 |  | Industry Review on the Uplifted Test Approach and Plan | 5d | 2025-04-17 A | 2025-04-23 A | 1424 | 100% | finish no earlier than 2025-04-23 |
| 1426 |  | SITAG paper day | 0d | 2025-04-17 A | 2025-04-17 A |  | 100% | finish no earlier than 2025-04-17 |
| 1427 |  | SITAG (inc SRO) Approval of regression Core Pack | 0d | 2025-04-24 A | 2025-04-24 A | 1426FS+5d, 1425 | 100% | start no earlier than 2025-04-24 |
| 1428 |  | SIT Regression Approval | 0d | 2025-04-24 A | 2025-04-24 A | 1427 | 100% |  |
| 1429 | 1.4.1.4.6.3 | **Regression Test Data Load Window (SIT Functional and Migration) - SIT A** | 1d? | 2025-04-28 | 2025-04-29 |  | 100% |  |
| 1430 |  | Data Load preparation activities | 20d | 2025-03-31 A | 2025-04-25 A | 1389 | 100% | start no earlier than 2025-03-17 |
| 1431 |  | Regression Test Data Load Start | 0d | 2025-04-28 A | 2025-04-28 A | 1617, 1525FS+1d, 1621FS+1d, 1430, 1428 | 100% |  |
| 1432 |  | Regression Test Data Load Window | 14d | 2025-04-29 A | 2025-05-16 A | 1431 | 100% | start no earlier than 2025-04-28 |
| 1433 | 1.4.1.4.7 | **Single Instance ADO** | 32d? | 2024-08-21 A | 2024-10-03 A |  | 100% |  |
| 1434 | 1.4.1.4.7.1 | **Single ADO Project for all Cohorts - Implementation and Test Phase** | 30d? | 2024-08-21 A | 2024-10-01 A |  | 100% |  |
| 1435 |  | Create test plans and suites in master project | 2d? | 2024-08-21 A | 2024-08-22 A |  | 100% | finish no earlier than 2024-08-22 |
| 1436 |  | Create area paths / iterations | 2d? | 2024-08-21 A | 2024-08-22 A |  | 100% | finish no earlier than 2024-08-22 |
| 1437 |  | Create IAM roles | 2d? | 2024-08-21 A | 2024-08-22 A |  | 100% | finish no earlier than 2024-08-22 |
| 1438 |  | Add users to roles | 1d? | 2024-08-23 A | 2024-08-23 A |  | 100% | start no earlier than 2024-08-23 |
| 1439 | 1.4.1.4.7.1.5 | **Testing permissions** | 2d? | 2024-08-27 A | 2024-08-28 A |  | 100% |  |
| 1440 |  | Adding tests | 2d? | 2024-08-27 A | 2024-08-28 A |  | 100% | finish no earlier than 2024-08-28 |
| 1441 |  | Deleting tests | 2d? | 2024-08-27 A | 2024-08-28 A |  | 100% | finish no earlier than 2024-08-28 |
| 1442 |  | Adding tests to incorrect Cohort | 2d? | 2024-08-27 A | 2024-08-28 A |  | 100% | finish no earlier than 2024-08-28 |
| 1443 |  | Add / delete defects | 2d? | 2024-08-27 A | 2024-08-28 A |  | 100% | finish no earlier than 2024-08-28 |
| 1444 |  | Migrate defects from cohort project to master - Option 2 | 3d | 2024-09-23 A | 2024-09-25 A |  | 100% | start no earlier than 2024-09-23 |
| 1445 |  | Testing Permissions - Evidence attachment security | 10d? | 2024-09-18 A | 2024-10-01 A |  | 100% | finish no earlier than 2024-10-01 |
| 1446 | 1.4.1.4.7.2 | **ADO Dashboard Updates** | 20d? | 2024-09-03 A | 2024-09-30 A |  | 100% |  |
| 1447 |  | Update reporting dashboards in ADO | 3d | 2024-09-03 A | 2024-09-05 A |  | 100% | start no earlier than 2024-09-03 |
| 1448 |  | Review dashboards with SI LDP leads | 16d | 2024-09-06 A | 2024-09-27 A |  | 100% | start no earlier than 2024-09-06 |
| 1449 |  | Review dashboards with SRO | 16d | 2024-09-09 A | 2024-09-30 A |  | 100% | start no earlier than 2024-09-09 |
| 1450 |  | Update dashboards following review | 2d | 2024-09-12 A | 2024-09-13 A |  | 100% | start no earlier than 2024-09-12 |
| 1451 |  | Document changes to dashboard creation process | 4d | 2024-09-16 A | 2024-09-19 A |  | 100% | start no earlier than 2024-09-16 |
| 1452 |  | Update SIT Dashboards for Sprints 4.1 & 4.2 across all Cohorts | 1d? | 2024-09-03 A | 2024-09-03 A |  | 100% | start no earlier than 2024-09-03 |
| 1453 | 1.4.1.4.7.3 | **Reporting Changes - PowerBI & QIP** | 23d? | 2024-08-23 A | 2024-09-24 A |  | 100% |  |
| 1454 |  | Design, Create and ETL ADO Entities into PowerBI Data Model | 1d? | 2024-08-23 A | 2024-08-23 A |  | 100% | start no earlier than 2024-08-23 |
| 1455 |  | Determine Relationships between ADO Entities & Attributes | 1d? | 2024-08-27 A | 2024-08-27 A |  | 100% | start no earlier than 2024-08-27 |
| 1456 |  | Create Relevant Dax Measures | 1d? | 2024-08-28 A | 2024-08-28 A |  | 100% | start no earlier than 2024-08-28 |
| 1457 |  | Design & Build Visualisations (Graphs) | 1d? | 2024-08-29 A | 2024-08-29 A |  | 100% | start no earlier than 2024-08-29 |
| 1458 |  | Implement Filters | 1d? | 2024-09-23 A | 2024-09-23 A |  | 100% | start no earlier than 2024-09-23 |
| 1459 |  | Check Data Quality & Integrity | 1d? | 2024-09-24 A | 2024-09-24 A |  | 100% | start no earlier than 2024-09-24 |
| 1460 |  | Performance Optimisation | 1d? | 2024-09-24 A | 2024-09-24 A |  | 100% | start no earlier than 2024-09-24 |
| 1461 | 1.4.1.4.7.4 | **Reporting Changes - Daily Excel Extract & PDF** | 2d | 2024-09-05 A | 2024-09-06 A |  | 100% |  |
| 1462 |  | Excel Daily Report changes (Refer to above) | 2d | 2024-09-05 A | 2024-09-06 A |  | 100% | start no earlier than 2024-09-05 |
| 1463 |  | PDF Daily Report changes (Refer to Above) | 2d | 2024-09-05 A | 2024-09-06 A |  | 100% | start no earlier than 2024-09-05 |
| 1464 | 1.4.1.4.7.5 | **Documentation Updates** | 23d? | 2024-09-02 A | 2024-10-02 A |  | 100% |  |
| 1465 |  | Changes to onboarding process (security) | 10d | 2024-09-02 A | 2024-09-13 A |  | 100% | start no earlier than 2024-09-02 |
| 1466 |  | Update the documents on loading tests into ADO? | 10d | 2024-09-02 A | 2024-09-13 A |  | 100% | start no earlier than 2024-09-02 |
| 1467 |  | Update ADO Training material | 10d | 2024-09-02 A | 2024-09-13 A |  | 100% | start no earlier than 2024-09-02 |
| 1468 |  | Update ADO User Guide | 10d | 2024-09-02 A | 2024-09-13 A |  | 100% | start no earlier than 2024-09-02 |
| 1469 |  | Update ADO Configuration document | 10d | 2024-09-02 A | 2024-09-13 A |  | 100% | start no earlier than 2024-09-02 |
| 1470 |  | Update ADO Training Material and User Guide following SRO review | 1d? | 2024-10-02 A | 2024-10-02 A |  | 100% | start no earlier than 2024-10-02 |

| ID | WBS | Task | Duration | Start | Finish | Predecessors | Complete | Constraint |
| --- | --- | --- | --- | --- | --- | --- | --- | --- |
| 1471 | 1.4.1.4.7.6 | **ADO Changes - Review Stage** | 19d? | 2024-09-09 A | 2024-10-03 A |  | 100% |  |
| 1472 |  | Review implementation with SI LDP leads | 1d? | 2024-09-27 A | 2024-09-27 A |  | 100% | start no earlier than 2024-09-27 |
| 1473 |  | Review implementation with SRO | 1d? | 2024-09-30 A | 2024-09-30 A |  | 100% | start no earlier than 2024-09-30 |
| 1474 |  | LDP Review - ADO User Guide, Training Materials | 5d | 2024-09-09 A | 2024-09-13 A |  | 100% | start no earlier than 2024-09-09 |
| 1475 |  | SRO Review - ADO User Guide, Training Materials | 1d? | 2024-09-30 A | 2024-09-30 A |  | 100% | start no earlier than 2024-09-30 |
| 1476 |  | LDP Review - Config doc | 1d? | 2024-09-30 A | 2024-09-30 A |  | 100% | start no earlier than 2024-09-30 |
| 1477 |  | SRO Review - Config doc | 1d? | 2024-09-30 A | 2024-09-30 A |  | 100% | start no earlier than 2024-09-30 |
| 1478 |  | SRO Sign-off of all changes | 1d? | 2024-10-03 A | 2024-10-03 A |  | 100% | start no earlier than 2024-10-03 |
| 1479 | 1.4.1.4.7.7 | **Azure DevOps Changes - Final Implementation** | 1d? | 2024-10-03 A | 2024-10-03 A |  | 100% |  |
| 1480 |  | Final task rollout | 1d? | 2024-10-03 A | 2024-10-03 A |  | 100% | start no earlier than 2024-10-03 |
| 1481 |  | ADO Training Drop-in Session ahead of Cycle 3 | 1d? | 2024-10-03 A | 2024-10-03 A |  | 100% | start no earlier than 2024-10-03 |
| 1482 | 1.4.2 | **SIT Execution** | 495d? | 2023-10-30 A | 2025-09-19 A |  | 100% |  |
| 1483 |  | System Integration Testing Start (M9) | 0d | 2023-10-30 A | 2023-10-30 A | 674FS+5d, 588 | 100% | must start on 2023-10-30 |
| 1484 | 1.4.2.2 | **SIT Component Integration Testing** | 96d | 2023-10-30 A | 2024-03-11 A |  | 100% |  |
| 1485 |  | SIT Component Integration Testing Start | 0d | 2023-10-30 A | 2023-10-30 A | 1483 | 100% |  |
| 1486 |  | Component Integration Testing Interval 1 Start | 0d | 2023-10-30 A | 2023-10-30 A | 674SS+1d, 595, 599, 603, 114 | 100% |  |
| 1487 |  | Component Integration Testing Interval 2 Start | 0d | 2023-11-13 A | 2023-11-13 A | 701SS+5d, 595, 603, 599, 114 | 100% |  |
| 1488 |  | Component Integration Testing Interval 3 Start | 0d | 2023-11-27 A | 2023-11-27 A | 733SS+5d, 595, 599, 603, 114 | 100% |  |
| 1489 |  | Component Integration Testing Interval 4 Start | 0d | 2023-12-11 A | 2023-12-11 A | 765SS+5d, 595, 599, 603, 114 | 100% |  |
| 1490 |  | Component Integration Testing Interval 5 Start | 0d | 2024-01-15 A | 2024-01-15 A | 797SS+5d, 595, 599, 603, 114 | 100% |  |
| 1491 |  | Component Integration Testing Interval 6 Start | 0d | 2024-01-29 A | 2024-01-29 A | 595, 599, 603, 829, 114, 641 | 100% | must start on 2024-01-29 |
| 1492 |  | SIT Component Integration Testing Execution | 85d | 2023-10-30 A | 2024-02-23 A | 1486SS | 100% | must start on 2023-10-30 |
| 1493 |  | SIT Component Integration Testing End (incl. confirmation that PPs have submitted their Test Completion Reports to Programme for assurance) | 0d | 2024-02-23 A | 2024-02-23 A | 1492FF | 100% | finish no earlier than 2024-02-23 |
| 1494 |  | Assurance of PPs Test Completion Reports | 30d | 2024-01-22 A | 2024-03-01 A | 1493FF+5d | 100% |  |
| 1495 | 1.4.2.2.11 | **SIT CI Test Completion Report** | 18d | 2024-02-07 A | 2024-03-01 A |  | 100% |  |
| 1496 |  | Develop document | 13d | 2024-02-07 A | 2024-02-23 A | 1493FF | 100% |  |
| 1497 |  | Review & agree document | 5d | 2024-02-26 A | 2024-03-01 A | 1496, 1494FF | 100% |  |
| 1498 |  | SIT Component Integration Testing Test Completion Report Approved | 0d | 2024-03-11 A | 2024-03-11 A | 1497FS+6d | 100% |  |
| 1499 | 1.4.2.3 | **SIT** | 400d? | 2024-03-11 A | 2025-09-19 A |  | 100% |  |
| 1500 | 1.4.2.3.1 | **SIT Functional Testing (MVC)** | 400d? | 2024-03-11 A | 2025-09-19 A |  | 100% |  |
| 1501 |  | SIT Functional Testing Start | 0d | 2024-03-11 A | 2024-03-11 A | 1498, 957FS+5d, 836, 844, 845, 846, 853 | 100% |  |
| 1502 | 1.4.2.3.1.2 | **SIT Functional Testing Execution (Minimum Viable Cohort)** | 295d? | 2024-03-11 A | 2025-04-28 A |  | 100% |  |
| 1503 | 1.4.2.3.1.2.1 | **Cycle 1 (Full Cycle)** | 70d | 2024-03-11 A | 2024-06-14 A |  | 100% |  |
| 1504 |  | Test Execution | 55d | 2024-03-11 A | 2024-05-24 A | 1501SS-1d, 921 | 100% |  |
| 1505 |  | Defect resolution, assurance, review, data & environments maintenance | 15d | 2024-05-27 A | 2024-06-14 A | 1504 | 100% |  |
| 1506 | 1.4.2.3.1.2.2 | **Cycle 2 (Defect retests and targeted regression testing)** | 80d | 2024-06-17 A | 2024-10-04 A |  | 100% |  |
| 1507 |  | Test Execution | 70d | 2024-06-17 A | 2024-09-20 A | 1505, 926 | 100% |  |
| 1508 |  | Defect resolution, assurance, review, data & environments maintenance | 10d | 2024-09-23 A | 2024-10-04 A | 1507 | 100% |  |
| 1509 | 1.4.2.3.1.2.3 | **SIT Functional Testing back-up progress risk-assessment** | 7d? | 2024-10-07 A | 2024-10-15 A |  | 100% |  |
| 1510 |  | Back-up risk-assessment of SIT Functional progress to assess whether Qualification Execution can start early | 1d? | 2024-10-07 A | 2024-10-07 A | 1508 | 100% |  |
| 1511 |  | Back-up SITAG decision on early Qualification Testing Execution start | 1d? | 2024-10-15 A | 2024-10-15 A | 1510FS+5d | 100% |  |
| 1512 | 1.4.2.3.1.2.4 | **Cycle 3 (Defect retests and targeted regression testing)** | 105d? | 2024-10-21 A | 2025-03-14 |  | 100% |  |
| 1513 |  | Sprint 5 | 10d? | 2024-10-21 A | 2024-11-01 A | 140SS-1d | 100% |  |
| 1514 |  | Sprint 6 | 10d? | 2024-11-04 A | 2024-11-15 A | 1513 | 100% |  |
| 1515 |  | Sprint 7 | 10d? | 2024-11-18 A | 2024-11-29 A | 1514 | 100% |  |
| 1516 |  | Sprint 8 | 15d? | 2024-12-02 A | 2024-12-20 A | 1515 | 100% |  |
| 1517 |  | Christmas downtime | 10d? | 2024-12-23 A | 2025-01-03 A | 1516 | 100% |  |
| 1518 |  | Sprint 9 | 10d? | 2025-01-06 A | 2025-01-17 A | 1517 | 100% |  |
| 1519 |  | Sprint 10 | 10d? | 2025-01-20 A | 2025-01-31 A | 1518 | 100% |  |
| 1520 |  | Sprint 11 | 10d? | 2025-02-03 A | 2025-02-14 A | 1519 | 100% |  |
| 1521 |  | Sprint 12 | 10d? | 2025-02-17 A | 2025-02-28 A | 1520 | 100% |  |
| 1522 |  | Sprint 13 (RTTM Gap Analysis + CR056) | 10d? | 2025-03-03 A | 2025-03-14 A | 1521 | 100% |  |
| 1523 |  | Sprint 14 (RTTM Gap Analysis + CR056) | 10d? | 2025-03-17 A | 2025-03-28 A | 1522 | 100% |  |
| 1524 |  | Sprint 15 (Contingency 1) | 10d? | 2025-03-31 A | 2025-04-11 A | 1523 | 100% |  |
| 1525 |  | Sprint 16 (Contingency 2) | 10d? | 2025-04-14 A | 2025-04-25 A | 1524 | 100% |  |
| 1526 |  | SIT Functional Cycle 3 Complete | 0d | 2025-04-28 A | 2025-04-28 A | 1525 | 100% |  |
| 1527 | 1.4.2.3.1.3 | **SIT Scope Traceability** | 64d | 2025-01-27 A | 2025-04-24 A |  | 100% |  |
| 1528 |  | Draft Scope Tracability document | 10d | 2025-01-27 A | 2025-02-07 A |  | 100% | start no earlier than 2025-01-27 |
| 1529 |  | LDP review | 2d | 2025-02-10 A | 2025-02-11 A | 1528 | 100% |  |
| 1530 |  | SRO review | 5d | 2025-02-12 A | 2025-02-18 A | 1529 | 100% |  |
| 1531 |  | Updates to reflect SRO feedback | 5d | 2025-02-12 A | 2025-02-18 A | 1530FF | 100% |  |
| 1532 |  | Industry Review | 10d | 2025-02-19 A | 2025-03-04 A | 1531 | 100% |  |
| 1533 |  | SITWG paper day | 0d | 2025-04-08 A | 2025-04-08 A | 1531FS+35d | 100% | start no earlier than 2025-04-08 |
| 1534 |  | SITWG recommends Scope Tracability document | 0d | 2025-04-15 A | 2025-04-15 A | 1533FS+5d | 100% |  |
| 1535 |  | Update document to reflect industry consultation views | 8d | 2025-03-05 A | 2025-03-14 A | 1532 | 100% |  |
| 1536 |  | SITAG paper day | 0d | 2025-04-17 A | 2025-04-17 A | 1534FS+2d, 1535 | 100% |  |
| 1537 |  | SITAG approve SIT Scope Traceability document | 0d | 2025-04-24 A | 2025-04-24 A | 1536FS+5d | 100% |  |
| 1538 |  | SIT Scope Traceability Approved | 0d | 2025-04-24 A | 2025-04-24 A | 1537 | 100% |  |
| 1539 | 1.4.2.3.1.4 | **SIT Functional Settlement Testing** | 230d? | 2024-06-17 | 2025-05-02 |  | 100% |  |
| 1540 |  | SIT-B Settlement Testing Cycle 2 | 70d | 2025-03-10 A | 2025-06-13 A | 1557FS+10d | 100% | start no earlier than 2024-06-17 |

| ID | WBS | Task | Duration | Start | Finish | Predecessors | Complete | Constraint |
| --- | --- | --- | --- | --- | --- | --- | --- | --- |
| 1541 | 1.4.2.3.1.4.2 | **SIT-B Settlement Testing Cycle 3** | 100d? | 2024-10-07 A | 2025-02-21 A |  | 100% |  |
| 1542 |  | Sprint 5 | 20d? | 2024-10-07 A | 2024-11-01 A | 1184 | 100% |  |
| 1543 |  | Sprint 5 Review (Flexibility Window Checkpoint) | 0d | 2024-11-04 A | 2024-11-04 A | 1542SS+21d | 100% |  |
| 1544 |  | Sprint 6 | 10d? | 2024-11-04 A | 2024-11-15 A | 1542 | 100% |  |
| 1545 |  | Sprint 6 Review (Pre Christmas Contingency Decision Point) | 0d | 2024-11-18 A | 2024-11-18 A | 1544SS+11d | 100% |  |
| 1546 |  | Sprint 7 | 10d? | 2024-11-18 A | 2024-11-29 A | 1544 | 100% |  |
| 1547 |  | Sprint 7 Review (Post Christmas Contingency Decision Point) | 0d | 2024-12-02 A | 2024-12-02 A | 1546SS+11d | 100% |  |
| 1548 |  | Sprint 8 | 15d | 2024-12-02 A | 2024-12-20 A | 1546 | 100% |  |
| 1549 |  | Post-Christmas Stabilisation | 5d | 2025-01-06 A | 2025-01-10 A | 1548FS+10d | 100% |  |
| 1550 |  | Sprint 9 | 10d | 2025-01-06 A | 2025-01-17 A | 1548FS+10d | 100% |  |
| 1551 |  | Sprint 9 Review | 0d | 2025-01-20 A | 2025-01-20 A | 1550FS+1d | 100% |  |
| 1552 |  | Sprint 10 | 10d | 2025-01-20 A | 2025-01-31 A | 1550 | 100% |  |
| 1553 |  | Sprint 10 Review | 0d | 2025-02-03 A | 2025-02-03 A | 1552FS+1d | 100% |  |
| 1554 |  | Sprint 11 | 10d | 2025-02-03 A | 2025-02-14 A | 1552 | 100% |  |
| 1555 |  | Sprint 11 Review | 0d | 2025-02-14 A | 2025-02-14 A | 1554 | 100% |  |
| 1556 |  | Sprint 12 | 5d | 2025-02-17 A | 2025-02-21 A | 1555 | 100% |  |
| 1557 |  | End of Settlement Testing Cycle 3 | 0d | 2025-02-21 A | 2025-02-21 A | 1556 | 100% |  |
| 1558 | 1.4.2.3.1.4.3 | **SIT-A Settlement Testing** | 30d | 2025-05-19 A | 2025-06-27 A |  | 100% |  |
| 1559 |  | SIT-A Settlement Testing Start | 0d | 2025-05-19 A | 2025-05-19 A | 1432FS+1d | 100% |  |
| 1560 |  | SIT-A Settlement Testing | 30d | 2025-05-19 A | 2025-06-27 A | 1559 | 100% |  |
| 1561 |  | eSITAG decision point on end of SIT A testing | 0d | 2025-06-26 A | 2025-06-26 A |  | 100% | finish no earlier than 2025-06-26 |
| 1562 |  | SIT-A Settlement Decision Point Exit Criteria | 0d | 2025-06-27 A | 2025-06-27 A | 1560FS-1d | 100% |  |
| 1563 |  | SIT-A Settlement Testing Completed | 0d | 2025-06-27 A | 2025-06-27 A | 1562 | 100% |  |
| 1564 | 1.4.2.3.1.4.4 | **SIT Functional & Migration Regression Testing (code freeze)** | 55d? | 2025-06-30 A | 2025-09-12 A |  | 100% |  |
| 1565 |  | Regression Test Execution Start | 0d | 2025-06-30 A | 2025-06-30 A | 1432FS+2d, 1563FS+2d | 100% |  |
| 1566 |  | Regression Execution | 5d | 2025-06-30 A | 2025-07-04 A | 1565FS-1d | 100% |  |
| 1567 |  | Regression Sprint 1 | 10d? | 2025-07-07 A | 2025-07-18 A | 1566 | 100% |  |
| 1568 |  | Regression Sprint 2 | 15d | 2025-07-21 A | 2025-08-08 A | 1567 | 100% |  |
| 1569 |  | Cycle 1 SAT Regression | 10d | 2025-07-21 A | 2025-08-01 A | 1568SS, 2279 | 100% |  |
| 1570 |  | Supplementary Regression Testing | 20d | 2025-07-21 A | 2025-08-15 A | 1569SS | 100% |  |
| 1571 |  | Cycle 2 SAT Regression | 5d | 2025-08-04 A | 2025-08-08 A | 1568SS, 2289 | 100% | start no earlier than 2025-08-04 |
| 1572 |  | Regression Sprint 3 | 10d | 2025-08-11 A | 2025-08-22 A | 1568 | 100% |  |
| 1573 |  | Regression Sprint 4 | 15d | 2025-08-25 A | 2025-09-12 A | 1572 | 100% |  |
| 1574 | 1.4.2.3.1.4.5 | **SIT Functional & Migration Overarching Exit Report** | 59d | 2025-04-28 A | 2025-07-17 A |  | 100% |  |
| 1575 |  | Programme drafts Functional & Migration PP Exit Report | 32d | 2025-04-28 A | 2025-06-10 A | 1526 | 100% |  |
| 1576 |  | SRO Review PP Exit Reports | 10d | 2025-05-22 A | 2025-06-04 A | 1575SS | 100% | start no earlier than 2025-05-22 |
| 1577 |  | Functional & Migration PP Exit Reports shared with PPs | 0d | 2025-06-10 A | 2025-06-10 A | 1575 | 100% | finish no earlier than 2025-05-23 |
| 1578 |  | PPs review Exit Report and sign Functional & Migration Exit Declaration | 10d | 2025-06-11 A | 2025-06-24 A | 1577 | 100% | start no earlier than 2025-05-26 |
| 1579 |  | Programme drafts SI SIT Functional & Migration Overarching Exit Report | 13d | 2025-06-11 A | 2025-06-27 A | 1577 | 100% | start no earlier than 2025-05-26 |
| 1580 |  | SRO/Code Bodies Review SI SIT Funcational & Migration Overarching Exit Report | 5d | 2025-06-26 A | 2025-07-02 A | 1579SS | 100% | finish no earlier than 2025-07-02 |
| 1581 |  | SITWG Review status of SI SIT Functional & Migration Overarching Exit Report | 0d | 2025-07-03 A | 2025-07-03 A | 1579FS+4d, 1580 | 100% | start no earlier than 2025-06-05 |
| 1582 |  | SI SIT Functional & Migration Overarching Exit Report Industry Review | 10d | 2025-07-04 A | 2025-07-17 A | 1581 | 100% |  |
| 1583 | 1.4.2.3.1.4.6 | **SIT Settlement and Regression Test Exit Report** | 55d | 2025-07-07 A | 2025-09-19 A |  | 100% |  |
| 1584 |  | Programme drafts Settlement and Regression Pathway 2 PP Exit Reports | 13d | 2025-07-07 A | 2025-07-23 A | 1567SS | 100% | start no earlier than 2025-07-07 |
| 1585 |  | SRO Review Settlement and Regression Pathway 2 PP Exit Reports | 5d | 2025-07-17 A | 2025-07-23 A | 1584SS | 100% | finish no earlier than 2025-07-23 |
| 1586 |  | Pathway 2 PPs review and sign off Regression Exit Declaration | 6d | 2025-07-21 A | 2025-07-28 A | 1584SS | 100% | start no earlier than 2025-07-21 |
| 1587 |  | Programme drafts Settlement and Regression Pathway 3 PP Exit Reports | 13d | 2025-07-28 A | 2025-08-13 A | 1568SS | 100% | start no earlier than 2025-07-28 |
| 1588 |  | SRO Review Settlement and Regression Pathway 3 PP Exit Reports | 5d | 2025-08-07 A | 2025-08-13 A | 1587SS | 100% | finish no earlier than 2025-08-13 |
| 1589 |  | Pathway 3 PPs review and sign off Exit Reports | 5d | 2025-08-11 A | 2025-08-15 A | 1587SS | 100% | start no earlier than 2025-08-11 |
| 1590 |  | Programme drafts Settlement and Regression Pathway 4, 5 & 6 PP Exit Reports | 25d | 2025-08-18 A | 2025-09-19 A | 1572SS | 100% | start no earlier than 2025-08-18 |
| 1591 |  | Programme drafts SI SIT Settlement and Regression Addendum | 15d | 2025-07-21 A | 2025-08-08 A |  | 100% | start no earlier than 2025-07-21 |
| 1592 |  | SRO/Code Bodies Review SI SIT Settlement and Regression Addendum | 5d | 2025-08-04 A | 2025-08-08 A | 1591SS | 100% | start no earlier than 2025-08-04 |
| 1593 |  | SI SIT Migration Testing Test Exit Report Approved | 0d | 2025-08-15 A | 2025-08-15 A |  | 100% | start no earlier than 2025-08-15 |
| 1594 |  | SI SIT Functional Testing Test Exit Report Approved | 0d | 2025-08-15 A | 2025-08-15 A | 1591, 1568 | 100% | finish no earlier than 2025-08-15 |
| 1595 |  | eSITAG Approves SI SIT Functional & Migration (Post-Regression) Overarching Test Exit Report | 0d | 2025-08-15 A | 2025-08-15 A | 1591, 1568, 1582 | 100% | start no earlier than 2025-08-15 |
| 1596 | 1.4.2.3.2 | **SIT Migration Testing** | 295d? | 2024-03-11 A | 2025-04-25 A |  | 100% |  |
| 1597 |  | SIT Migration Testing Start | 0d? | 2024-03-11 A | 2024-03-11 A |  | 100% | start no earlier than 2024-03-11 |
| 1598 | 1.4.2.3.2.2 | **SIT Migration Testing Execution** | 295d? | 2024-03-11 A | 2025-04-25 A |  | 100% |  |
| 1599 | 1.4.2.3.2.2.1 | **Cycle 1 (Full Cycle)** | 70d? | 2024-03-11 A | 2024-06-14 A |  | 100% |  |
| 1600 |  | Test Execution | 55d? | 2024-03-11 A | 2024-05-24 A |  | 100% | start no earlier than 2024-03-11 |
| 1601 |  | Defect resolution, assurance, review, data& environments maintenance | 15d? | 2024-05-27 A | 2024-06-14 A |  | 100% | finish no earlier than 2024-06-14 |
| 1602 | 1.4.2.3.2.2.2 | **Cycle 2 (Defect retests and targeted regression testing)** | 80d? | 2024-03-11 | 2024-06-28 |  | 100% |  |
| 1603 |  | Test Execution | 70d? | 2024-06-17 A | 2024-09-20 A | 1601 | 100% | start no earlier than 2024-06-17 |
| 1604 |  | Defect resolution, assurance, review, data & environments maintenance | 10d? | 2024-09-23 A | 2024-10-04 A | 1603 | 100% | finish no earlier than 2024-10-04 |
| 1605 | 1.4.2.3.2.2.3 | **SIT Migration Testing back-up progress risk-assessment** | 70d? | 2024-06-17 | 2024-09-20 |  | 100% |  |
| 1606 |  | Back-up risk-assessment of SIT Migration progress to assess whether Qualification Execution can start early | 15d? | 2024-10-07 A | 2024-10-25 A | 1604 | 100% | finish no earlier than 2024-10-04 |
| 1607 |  | Back-up SITAG decision on early Qualification Testing Execution start | 0d? | 2024-11-01 A | 2024-11-01 A | 1606FS+5d | 100% |  |
| 1608 | 1.4.2.3.2.2.4 | **Cycle 3 (Defect retests and targeted regression testing)** | 135d? | 2024-10-21 A | 2025-04-25 A |  | 100% |  |
| 1609 |  | Sprint 5 | 10d | 2024-10-21 A | 2024-11-01 A | 140FS-1d | 100% | start no earlier than 2024-10-21 |
| 1610 |  | Sprint 6 | 10d | 2024-11-04 A | 2024-11-15 A | 1609 | 100% | start no earlier than 2024-11-04 |

| ID | WBS | Task | Duration | Start | Finish | Predecessors | Complete | Total float | Constraint |
| --- | --- | --- | --- | --- | --- | --- | --- | --- | --- |
| 1611 |  | Sprint 7 | 10d | 2024-11-18 A | 2024-11-29 A | 1610 | 100% |  |  |
| 1612 |  | Sprint 8 | 15d | 2024-12-02 A | 2024-12-20 A | 1611 | 100% |  | finish no earlier than 2024-11-15 |
| 1613 |  | Christmas downtime | 10d | 2024-12-23 A | 2025-01-03 A | 1612 | 100% |  | finish no earlier than 2024-11-29 |
| 1614 |  | Sprint 9 | 10d | 2025-01-06 A | 2025-01-17 A | 1613 | 100% |  | finish no earlier than 2024-12-20 |
| 1615 |  | Sprint 10 | 10d | 2025-01-20 A | 2025-01-31 A | 1614 | 100% |  | finish no earlier than 2025-01-03 |
| 1616 |  | Sprint 11 | 10d | 2025-02-03 A | 2025-02-14 A | 1615 | 100% |  | finish no earlier than 2025-01-17 |
| 1617 |  | Sprint 12 | 10d | 2025-02-17 A | 2025-02-28 A | 1616 | 100% |  | finish no earlier than 2025-01-31 |
| 1618 |  | Sprint 13 | 10d | 2025-03-03 A | 2025-03-14 A | 1617 | 100% |  |  |
| 1619 |  | Sprint 14 (RTTM Gap Analysis + CR056) | 10d? | 2025-03-17 A | 2025-03-28 A | 1618 | 100% |  |  |
| 1620 |  | Sprint 15 (Contingency 1) | 10d? | 2025-03-31 A | 2025-04-11 A | 1619 | 100% |  |  |
| 1621 |  | Sprint 16 (Contingency 2) | 10d? | 2025-04-14 A | 2025-04-25 A | 1620 | 100% |  |  |
| 1622 |  | SIT Migration Cycle 3 Complete | 0d | 2025-04-25 A | 2025-04-25 A | 1621 | 100% |  |  |
| 1623 | 1.4.2.3.3 | **SIT Non-Functional Testing (all SIT PPs)** | 112d? | 2025-03-03 A | 2025-08-06 A |  | 100% |  |  |
| 1624 |  | Theme 1 (Helix and DIP Volume Testing) Start | 0d? | 2025-03-03 A | 2025-03-03 A | 1144FS+1d, 1388 | 100% |  | finish no earlier than 2025-01-13 |
| 1625 |  | Theme 1 (Helix and DIP Volume Testing) Execution | 15d? | 2025-03-03 A | 2025-03-21 A | 1624FS-1d | 100% |  | start no earlier than 2025-01-13 |
| 1626 |  | Theme 2 & 3 SIT Non-Functional Testing Start | 0d | 2025-03-31 A | 2025-03-31 A | 1507, 1068, 1072, 1079, 1085, 1091, 1557, 1153FS+2d, 1390, 1134 | 100% |  |  |
| 1627 |  | Theme 2 & 3 SIT Non-Functional Testing Execution | 40d | 2025-03-31 A | 2025-05-23 A | 1626SS-1d | 100% |  |  |
| 1628 |  | SIT Non-Functional Testing Execution End (all SIT PPs) | 0d | 2025-05-23 A | 2025-05-23 A | 1627FF | 100% |  | start no earlier than 2025-05-23 |
| 1629 | 1.4.2.3.3.6 | **SIT Non-Functional Testing Test Exit Report (all SIT PPs)** | 52d | 2025-05-26 A | 2025-08-06 A |  | 100% |  |  |
| 1630 |  | Programme drafts Non-Functional PP Exit Report | 25d | 2025-05-26 A | 2025-06-27 A | 1628 | 100% |  |  |
| 1631 |  | Non-Functional PP Exit Reports shared with PPs | 0d | 2025-06-27 A | 2025-06-27 A | 1630 | 100% |  | start no earlier than 2025-06-09 |
| 1632 |  | PPs review Exit Report and Sign PP Exit Declaration | 11d | 2025-06-27 A | 2025-07-11 A | 1630SS | 100% |  | start no earlier than 2025-06-27 |
| 1633 |  | Programme drafts SI SIT Non-Functional Overarching Exit Report | 16d | 2025-06-27 A | 2025-07-18 A | 1624, 1625, 1626, 1627, 1628 | 100% |  | start no earlier than 2025-06-16 |
| 1634 |  | Draft of SI SIT Non-Functional Overarching Exit Report available for SRO review | 5d | 2025-07-07 A | 2025-07-11 A | 1633SS | 100% |  | start no earlier than 2025-07-07 |
| 1635 |  | SRO / Code Bodies / DIP Manager formal review SI SIT Non-Functional Overarching Exit Report | 5d | 2025-07-14 A | 2025-07-18 A | 1634 | 100% |  |  |
| 1636 |  | eSITWG Review status of SI SIT Non-Functional Overarching Exit Report | 0d | 2025-07-18 A | 2025-07-18 A | 1633 | 100% |  | start no earlier than 2025-07-03 |
| 1637 |  | SI SIT Non-Functional Overarching Exit Report published to PPs for industry review | 0d | 2025-07-18 A | 2025-07-18 A | 1636 | 100% |  |  |
| 1638 |  | SI SIT Non-Functional Overarching Exit Report industry review | 10d | 2025-07-21 A | 2025-08-01 A | 1637 | 100% |  |  |
| 1639 |  | SIT Non-Functional Testing Test Exit Report (all SIT PPs) Approved | 0d | 2025-08-06 A | 2025-08-06 A | 1633FS+3d, 1638 | 100% |  | start no earlier than 2025-08-06 |
| 1640 |  | eSITAG Approves SI SIT Non-Functional Overarching Test Exit Report | 0d | 2025-08-06 A | 2025-08-06 A | 1633FS+3d, 1639 | 100% |  | start no earlier than 2025-07-16 |
| 1641 | 1.4.2.3.4 | **SIT Operational Testing (all SIT PPs)** | 150d? | 2025-02-03 A | 2025-08-29 A |  | 100% |  |  |
| 1642 | 1.4.2.3.4.1 | **Non-SIT B Testing** | 25d? | 2025-02-03 A | 2025-03-07 A |  | 100% |  |  |
| 1643 |  | SIT Operational Testing Start (Theme 3 - Batch 1 (Service Management)) | 0d? | 2025-02-03 A | 2025-02-03 A | 1305, 1245, 1246 | 100% |  | start no earlier than 2025-02-03 |
| 1644 |  | SIT Operational Testing Execution Window (Theme 3 - Batch 1 (Service Management)) | 25d? | 2025-02-03 A | 2025-03-07 A | 1643 | 100% |  | start no earlier than 2025-01-06 |
| 1645 | 1.4.2.3.4.2 | **SIT B Testing** | 70d | 2025-03-31 A | 2025-07-04 A |  | 100% |  |  |
| 1646 |  | SIT Operational Testing Start (SIT B) | 0d | 2025-03-31 A | 2025-03-31 A | 1385, 1162, 1166, 1173, 1179, 1305, 1383FS+1d, 1391, 1392 | 100% |  |  |
| 1647 |  | SIT Operational Testing Execution Theme 1 | 70d | 2025-03-31 A | 2025-07-04 A | 1646FS-1d | 100% |  | finish no earlier than 2025-07-04 |
| 1648 |  | SIT Operational Testing Execution Theme 2 | 45d | 2025-05-05 A | 2025-07-04 A | 1646 | 100% |  | finish no earlier than 2025-07-04 |
| 1649 |  | SIT Operational Testing Execution Theme 3 Batch 2 | 20d | 2025-06-09 A | 2025-07-04 A | 1646 | 100% |  | start no earlier than 2025-06-09 |
| 1650 | 1.4.2.3.4.2.5 | **SIT Operational Testing Re-test Theme 3 (Batch 1)** | 30d | 2025-05-05 A | 2025-06-13 A |  | 100% |  |  |
| 1651 |  | SRO Review of re-testing approach | 10d | 2025-05-05 A | 2025-05-16 A |  | 100% |  | start no earlier than 2025-05-05 |
| 1652 |  | Scripts uploaded to ADO / Project Created | 5d | 2025-05-19 A | 2025-05-23 A | 1651 | 100% |  |  |
| 1653 |  | SIT Operational Testing Re-test Execution Theme 3 (Batch 1) | 5d | 2025-06-09 A | 2025-06-13 A | 1652 | 100% |  | start no earlier than 2025-06-09 |
| 1654 |  | SIT Operational Testing End (all SIT PPs) (incl. confirmation that PPs have submitted their Test Completion Reports to Programme for assurance) | 0d | 2025-07-04 A | 2025-07-04 A | 1644, 1647, 1648, 1649, 1653 | 100% |  |  |
| 1655 | 1.4.2.3.4.4 | **SIT Operational Testing Test Exit Report (all SIT PPs)** | 50d | 2025-06-23 A | 2025-08-29 A |  | 100% |  |  |
| 1656 |  | Programme drafts Pathway 2 PP Exit Report (when Participant completes Operational testing) | 15d | 2025-06-30 A | 2025-07-18 A | 1647SS, 1648SS | 100% |  | start no earlier than 2025-06-30 |
| 1657 |  | All Pathway 2 Operational Exit Reports and Exit Declarations shared with PPs | 0d | 2025-07-21 A | 2025-07-21 A | 1656FS+1d | 100% |  |  |
| 1658 |  | Pathway 2 PPs have reviewed Exit Report and signed Exit Declaration | 5d | 2025-07-21 A | 2025-07-25 A | 1656 | 100% |  | start no earlier than 2025-06-13 |
| 1659 |  | Programme drafts Pathway 3 PP Exit Report (when Participant completes Operational testing) | 15d | 2025-07-21 A | 2025-08-08 A | 1656 | 100% |  | start no earlier than 2025-07-21 |
| 1660 |  | All Pathway 3 Operational Exit Reports and Exit Declarations shared with PPs | 0d | 2025-08-08 A | 2025-08-08 A | 1656, 1659 | 100% |  |  |
| 1661 |  | Pathway 3 PPs have reviewed Exit Report and signed Exit Declaration | 5d | 2025-08-11 A | 2025-08-15 A | 1660 | 100% |  |  |
| 1662 |  | Programme drafts Pathway 4 PP Exit Report (when Participant completes Operational testing) | 10d | 2025-08-04 A | 2025-08-15 A | 1667 | 100% |  |  |
| 1663 |  | All Pathway 4 Operational Exit Reports and Exit Declarations shared with PPs | 0d | 2025-08-15 A | 2025-08-15 A | 1662 | 100% |  |  |
| 1664 |  | Pathway 4 PPs have reviewed Exit Report and signed Exit Declaration | 5d | 2025-08-18 A | 2025-08-22 A | 1663 | 100% |  |  |
| 1665 |  | Programme drafts Pathway 5 & 6 PP Exit Report (when Participant completes Operational testing) | 15d | 2025-08-11 A | 2025-08-29 A | 1659 | 100% |  |  |
| 1666 |  | Programme drafts SI SIT Operational Overarching Exit Report | 30d | 2025-06-23 A | 2025-08-01 A |  | 100% |  | start no earlier than 2025-06-23 |
| 1667 |  | SRO/Code Bodies/DIP Manager Review SI SIT Operational Overarching Exit Report | 5d | 2025-07-28 A | 2025-08-01 A | 1666SS | 100% |  | finish no earlier than 2025-08-01 |
| 1668 |  | eSITWG Review SI SIT Operational Overarching Exit Report | 0d | 2025-08-01 A | 2025-08-01 A |  | 100% |  | finish no earlier than 2025-08-01 |
| 1669 |  | SI SIT Operational Overarching Exit Report industry review | 6d | 2025-08-05 A | 2025-08-12 A | 1668 | 100% |  |  |
| 1670 |  | SIT Operational Testing Test Exit Report (all SIT PPs) Approved | 0d | 2025-08-15 A | 2025-08-15 A | 1666FS+3d | 100% |  | finish no earlier than 2025-08-15 |
| 1671 |  | eSITAG Approves SI SIT Operational Testing Test Exit Report | 0d | 2025-08-15 A | 2025-08-15 A | 1666FS+3d | 100% |  | finish no earlier than 2025-08-15 |
| 1672 |  | SIT Complete (SIT Test Exit Report Approved) | 0d | 2025-08-22 A | 2025-08-22 A | 1498, 1639, 1640, 1593, 1594 | 100% |  | finish no earlier than 2025-08-22 |
| 1673 | 1.4.3 | **UIT Environment Preparation** | 988d | 2022-11-16 A | 2026-08-28 |  | 95% | 31917d |  |
| 1674 | 1.4.3.1 | **Test Artefact Development** | 602d | 2023-03-01 A | 2025-06-19 A |  | 100% |  |  |
| 1675 | 1.4.3.1.1 | **E2E Sandbox Guidance** | 602d | 2023-03-01 A | 2025-06-19 A |  | 100% |  |  |
| 1676 |  | Develop document | 83d | 2023-03-01 A | 2023-06-23 A |  | 100% |  | start no earlier than 2023-03-01 |
| 1677 |  | Artefact review (via SITAG) and updates | 25d | 2023-06-26 A | 2023-07-28 A | 1676 | 100% |  |  |
| 1678 |  | E2E Sandbox Guidance approved | 0d | 2024-07-18 A | 2024-07-18 A | 1677FF+5d | 100% |  | start no earlier than 2024-07-18 |
| 1679 |  | Update E2E Sandbox guidance to reflect CR055 | 45d | 2025-03-17 A | 2025-05-16 A |  | 100% |  | finish no earlier than 2025-05-16 |
| 1680 |  | Internal SI review | 5d | 2025-05-19 A | 2025-05-23 A | 1679 | 100% |  | start no earlier than 2025-03-17 |

| ID | WBS | Task | Duration | Start | Finish | Predecessors | Complete | Total float | Constraint |
| --- | --- | --- | --- | --- | --- | --- | --- | --- | --- |
| 1681 |  | SRO / Code Bodies review | 5d | 2025-05-19 A | 2025-05-23 A |  | 100% |  | finish no earlier than 2025-05-23 |
| 1682 |  | Submit version to QWG | 0d | 2025-06-03 A | 2025-06-03 A |  | 100% |  | finish no earlier than 2025-06-03 |
| 1683 |  | Artefact Recommendation for Approval (via QWG) | 0d | 2025-06-10 A | 2025-06-10 A | 1682 | 100% |  | finish no earlier than 2025-06-10 |
| 1684 |  | Final Document updates post QWG review | 0d | 2025-06-11 A | 2025-06-11 A | 1683 | 100% |  | finish no earlier than 2025-06-11 |
| 1685 |  | Submit final version to QAG | 0d | 2025-06-12 A | 2025-06-12 A |  | 100% |  | finish no earlier than 2025-06-12 |
| 1686 |  | E2E Sandbox guidance update approved at QAG | 0d | 2025-06-19 A | 2025-06-19 A | 1685FS+3d | 100% |  | finish no earlier than 2025-06-19 |
| 1687 | 1.4.3.1.2 | **E2E Sandbox Test Data Approach & Plan** | 73d | 2025-03-10 A | 2025-06-19 A |  | 100% |  |  |
| 1688 |  | Discussion at QWG to reconfirm value provided from E2E Sandbox (UIT) | 0d | 2025-03-11 A | 2025-03-11 A |  | 100% |  | finish no earlier than 2025-03-11 |
| 1689 |  | Create PPIR to request PP responses on subject to gather views | 5d | 2025-03-10 A | 2025-03-14 A |  | 100% |  | finish no earlier than 2025-03-14 |
| 1690 |  | PPIR shared to industry | 9d | 2025-03-24 A | 2025-04-03 A | 1689 | 100% |  | start no earlier than 2025-03-24 |
| 1691 |  | Evaluate PPIR responses | 2d | 2025-04-04 A | 2025-04-07 A |  | 100% |  | start no earlier than 2025-04-04 |
| 1692 |  | Discuss PPIR results at QWG | 1d | 2025-04-08 A | 2025-04-08 A | 1691SF-5d | 100% |  | finish no earlier than 2025-04-08 |
| 1693 |  | Develop document | 27d | 2025-04-10 A | 2025-05-16 A | 1676SS+199d | 100% |  | finish no earlier than 2025-05-16 |
| 1694 |  | Internal SI review and updates | 5d | 2025-05-19 A | 2025-05-23 A | 1693 | 100% |  |  |
| 1695 |  | SRO / Code Bodies review | 5d | 2025-05-19 A | 2025-05-23 A | 1694SS | 100% |  |  |
| 1696 |  | Final updates prior to consultation | 1d | 2025-05-26 A | 2025-05-26 A | 1695 | 100% |  |  |
| 1697 |  | Industry Consultation for E2E Sandbox Test Data Approach and Plan document | 9d | 2025-05-27 A | 2025-06-06 A | 1696SS | 100% |  |  |
| 1698 |  | Document updates post Industry Consultation | 2d | 2025-06-06 A | 2025-06-09 A | 1697SS | 100% |  | finish no earlier than 2025-06-09 |
| 1699 |  | Submit Proposed Version to QWG | 0d | 2025-06-10 A | 2025-06-10 A |  | 100% |  | finish no earlier than 2025-06-10 |
| 1700 |  | Artefact Approval (via QWG) | 0d | 2025-06-10 A | 2025-06-10 A | 1699 | 100% |  | finish no earlier than 2025-06-10 |
| 1701 |  | Final Document updates post QWG review | 0d | 2025-06-11 A | 2025-06-11 A | 1700FS+1d | 100% |  | start no earlier than 2024-05-01 |
| 1702 |  | Submit final version to QAG | 0d | 2025-06-12 A | 2025-06-12 A | 1701FS+1d, 1698 | 100% |  | start no earlier than 2024-05-02 |
| 1703 |  | E2E Sandbox Test Data Approach and Plan Approved at QAG | 0d | 2025-06-19 A | 2025-06-19 A | 1702 | 100% |  | start no earlier than 2025-06-19 |
| 1704 | 1.4.3.2 | **UIT Stub Specification and Delivery** | 260d | 2023-12-04 A | 2024-11-29 A |  | 100% |  |  |
| 1705 | 1.4.3.2.1 | **Qualification Test Stubs** | 260d | 2023-12-04 A | 2024-11-29 A |  | 100% |  |  |
| 1706 |  | Specify | 44d | 2023-12-04 A | 2024-02-01 A | 515FS+13d | 100% |  |  |
| 1707 |  | Build & Test | 141d | 2024-02-02 A | 2024-08-16 A | 1706 | 100% |  |  |
| 1708 |  | Prepare for release | 75d | 2024-08-19 A | 2024-11-29 A | 1707 | 100% |  |  |
| 1709 |  | Non-SIT LDSO Test Harness Released | 0d | 2024-11-29 A | 2024-11-29 A | 1708 | 100% |  |  |
| 1710 | 1.4.3.3 | **Environments (UIT)** | 489d | 2022-11-16 A | 2024-09-30 A |  | 100% |  |  |
| 1711 | 1.4.3.3.1 | **Central Party (Avanade) Environments (UIT)** | 488d | 2022-11-16 A | 2024-09-27 A |  | 100% |  |  |
| 1712 |  | Central Party (Avandae) environment preparation (incl. security certificates and security compliance) | 447d | 2022-11-16 A | 2024-08-01 A | 511 | 100% |  |  |
| 1713 |  | Submit self-declaration of environment preparation complete (incl. security certificates and security compliance) to Programme for assurance | 447d | 2022-11-16 A | 2024-08-01 A | 1712SS | 100% |  |  |
| 1714 |  | Central Party (Avanade) UIT environment connectivity proving | 25d | 2024-08-26 A | 2024-09-27 A | 1720 | 100% |  |  |
| 1715 |  | Deployment of MHHS solution code to UIT environments | 2d | 2024-07-29 A | 2024-07-30 A |  | 100% |  | start no earlier than 2024-07-29 |
| 1716 |  | Central Party (Avanade) UIT environment Regression Testing | 1d | 2024-07-31 A | 2024-07-31 A | 1715 | 100% |  |  |
| 1717 | 1.4.3.3.2 | **SI Environments (UIT)** | 489d | 2022-11-16 A | 2024-09-30 A |  | 100% |  |  |
| 1718 |  | Coordinate Central Parties' UIT environment preparation | 447d | 2022-11-16 A | 2024-08-01 A | 1712SS | 100% |  |  |
| 1719 |  | Assure Central Parties' self-declaration of environment preparation complete (incl. security certificates and security compliance) | 463d | 2022-11-16 A | 2024-08-23 A | 1713SS | 100% |  |  |
| 1720 |  | Central Parties' UIT environments ready to start connectivity proving (incl. certificates and security compliance) | 0d | 2024-08-23 A | 2024-08-23 A | 1709 | 100% |  |  |
| 1721 |  | Coordinate Central Parties' UIT environment connectivity proving | 26d | 2024-08-26 A | 2024-09-30 A | 1714SS | 100% |  |  |
| 1722 |  | Coordinate deployment of MHHS solution code to Central Parties' UIT environments | 2d | 2024-07-29 A | 2024-07-30 A | 1715SS | 100% |  |  |
| 1723 |  | Coordinate Central Parties' UIT environment Regression Testing | 1d | 2024-07-31 A | 2024-07-31 A | 1722 | 100% |  |  |
| 1724 | 1.4.3.4 | **Onboarding and Test Data (Sandbox UIT)** | 325d | 2025-06-02 A | 2026-08-28 |  | 67% | 31917d |  |
| 1725 |  | LDSO Onboarding and Test Data Creation and Support | 169d | 2025-06-02 A | 2026-01-22 A |  | 100% |  | start no earlier than 2025-06-02 |
| 1726 |  | Supplier & Agent Onboarding and Test Data Creation and Support | 260d | 2025-09-01 A | 2026-08-28 |  | 45% | 31917d | start no earlier than 2025-09-01 |
| 1727 | 1.4.4 | **Sandbox Execution** | 330d | 2025-05-26 A | 2026-08-28 |  | 71% | 31917d |  |
| 1728 | 1.4.4.1 | **SIT PPs Early Sandbox Testing Execution (SIT-A)** | 56d | 2025-08-08 A | 2025-10-24 A |  | 100% |  |  |
| 1729 |  | SIT PPs E2E Sandbox Testing Start | 0d | 2025-08-08 A | 2025-08-08 A | 1568 | 100% |  | start no earlier than 2025-07-21 |
| 1730 |  | SIT PPs E2E Sandbox Testing Execution | 56d | 2025-08-08 A | 2025-10-24 A | 1729SS-1d | 100% |  | start no earlier than 2025-07-21 |
| 1731 |  | SIT PPs E2E Sandbox Testing End | 0d | 2025-10-24 A | 2025-10-24 A | 1730 | 100% |  |  |
| 1732 | 1.4.4.2 | **Sandbox Testing Execution (UIT) - LDSO Participants** | 174d | 2025-05-26 A | 2026-01-22 A |  | 100% |  |  |
| 1733 |  | UIT E2E Sandbox Preparation Complete | 0d | 2025-05-26 A | 2025-05-26 A |  | 100% |  | start no earlier than 2025-05-26 |
| 1734 |  | Sandbox Testing Start (UIT) - LDSO Participants | 0d | 2025-06-02 A | 2025-06-02 A | 1733 | 100% |  | finish no earlier than 2025-06-02 |
| 1735 |  | Sandbox Testing Execution (UIT) - LDSO Participants | 169d | 2025-06-02 A | 2026-01-22 A | 1734SS-1d | 100% |  | start no earlier than 2024-11-04 |
| 1736 |  | Sandbox Testing End (UIT) - LDSO Participants | 0d | 2026-01-22 A | 2026-01-22 A | 1735 | 100% |  |  |
| 1737 | 1.4.4.3 | **Sandbox Testing Execution (UIT) - Supplier & Agent Participants** | 260d | 2025-09-01 A | 2026-08-28 |  | 45% | 31917d |  |
| 1738 |  | UIT E2E Sandbox Preparation Complete - Supplier and Agent | 0d | 2025-09-01 A | 2025-09-01 A |  | 100% |  | finish no earlier than 2025-09-01 |
| 1739 |  | Sandbox Testing Start (UIT) - Supplier & Agent Participants | 0d | 2025-09-01 A | 2025-09-01 A | 1672, 2710FS+5d, 1738 | 100% |  | start no earlier than 2025-02-10 |
| 1740 |  | Sandbox Testing Execution (UIT) - Supplier & Agent Participants | 260d | 2025-09-01 A | 2026-08-28 | 1739SS-1d | 45% | 31917d | start no earlier than 2024-11-04 |
| 1741 |  | Sandbox Testing End (UIT) - Supplier & Agent Participants | 0d | 2026-08-28 | 2026-08-28 | 1740 |  | 31917d |  |
| 1742 | 1.4.5 | **System Integration Testing - Tier 1 Milestones** | 411d? | 2024-05-28 A | 2025-12-24 A |  | 100% |  |  |
| 1743 | 1.4.5.1 | **M10 Checkpoint 1** | 63d? | 2025-01-06 A | 2025-04-02 A |  | 100% |  |  |
| 1744 | 1.4.5.1.1 | **M10 Readiness** | 50d? | 2025-01-06 A | 2025-03-14 A |  | 100% |  |  |
| 1745 |  | Define guiding principles and approach | 15d? | 2025-01-06 A | 2025-01-24 A |  | 100% |  | start no earlier than 2025-01-06 |
| 1746 |  | Engage IPA | 10d | 2025-01-13 A | 2025-01-24 A |  | 100% |  | start no earlier than 2025-01-13 |
| 1747 |  | Mobilise Get to Go-Live Group | 10d | 2025-01-27 A | 2025-02-07 A | 1745, 1746 | 100% |  |  |
| 1748 |  | Progress against the M10 Readiness Criteria | 25d? | 2025-02-10 A | 2025-03-14 A | 1747 | 100% |  |  |
| 1749 | 1.4.5.1.2 | **Downstream milestone feasibility assessment** | 50d? | 2025-01-06 A | 2025-03-14 A |  | 100% |  |  |
| 1750 |  | Define guiding principles and approach to addressing points 1 - 3 | 20d? | 2025-01-06 A | 2025-01-31 A |  | 100% |  | start no earlier than 2025-01-06 |

| ID | WBS | Task | Duration | Start | Finish | Predecessors | Complete | Constraint |
| --- | --- | --- | --- | --- | --- | --- | --- | --- |
| 1751 |  | Assess capacity within migration envelopes (Point 1 - Bringing M15 forwards) | 20d | 2025-01-20 A | 2025-02-14 A | 1750FF | 100% | start no earlier than 2025-01-20 |
| 1752 |  | Review M16 process (Point 3 - Bringing M16 forwards) | 25d? | 2025-01-20 A | 2025-02-21 A | 1750FF | 100% | start no earlier than 2025-01-20 |
| 1753 |  | Develop M16 process review findings | 10d | 2025-02-24 A | 2025-03-07 A | 1752 | 100% |  |
| 1754 |  | Agree M16 process review findings with Code Bodies | 5d | 2025-03-10 A | 2025-03-14 A | 1753 | 100% |  |
| 1755 |  | Agree M16 process review findings with PAB | 5d | 2025-03-10 A | 2025-03-14 A | 1753 | 100% |  |
| 1756 |  | Run PPIR with impacted parties (Point 2 - Bringing M14 forwards) | 10d | 2025-03-03 A | 2025-03-14 A | 1751FS+10d | 100% |  |
| 1757 | 1.4.5.1.3 | **Checkpoint governance** | 21d | 2025-03-05 A | 2025-04-02 A |  | 100% |  |
| 1758 |  | PSG Updated on progress | 0d | 2025-03-05 A | 2025-03-05 A | 1748SS | 100% | start no earlier than 2025-03-05 |
| 1759 |  | Review final M10 Readiness outputs with IPA | 5d | 2025-03-17 A | 2025-03-21 A | 1754, 1755, 1756, 1748 | 100% |  |
| 1760 |  | Review final M10 Readiness outputs with Ofgem | 8d | 2025-03-17 A | 2025-03-26 A | 1754, 1755, 1756, 1748, 1759SS | 100% |  |
| 1761 |  | QAG paper day | 0d | 2025-03-13 A | 2025-03-13 A | 1748SS | 100% | start no earlier than 2025-03-13 |
| 1762 |  | QAG recommend M10 Checkpoint | 0d | 2025-03-20 A | 2025-03-20 A | 1761FS+6d | 100% |  |
| 1763 |  | MCAG paper day | 0d | 2025-03-24 A | 2025-03-24 A | 1748FS+6d | 100% |  |
| 1764 |  | MCAG recommend M10 Checkpoint | 0d | 2025-04-01 A | 2025-04-01 A | 1763FS+6d | 100% |  |
| 1765 |  | PSG paper day | 0d | 2025-03-26 A | 2025-03-26 A | 1760 | 100% |  |
| 1766 |  | PSG M10 Checkpoint Meeting | 0d | 2025-04-02 A | 2025-04-02 A | 1765FS+5d, 1764, 1762, 1759, 1760 | 100% |  |
| 1767 |  | M10 Checkpoint 1 complete | 0d | 2025-04-02 A | 2025-04-02 A | 1766 | 100% |  |
| 1768 |  | M10 Checkpoint 2 Complete | 0d | 2025-07-02 A | 2025-07-02 A |  | 100% | finish no earlier than 2025-07-02 |
| 1769 | 1.4.5.3 | **M10 Acceptance Criteria** | 358d | 2024-05-28 A | 2025-10-10 A |  | 100% |  |
| 1770 |  | End of SIT MVC testing | 0d | 2025-08-22 A | 2025-08-22 A |  | 100% | finish no earlier than 2025-08-22 |
| 1771 |  | IPA M10 Assurance Report developed and agreed | 0d | 2025-09-19 A | 2025-09-19 A |  | 100% | finish no earlier than 2025-09-19 |
| 1772 |  | Non-SIT LDSO Qualification Testing complete | 0d | 2025-05-16 A | 2025-05-16 A | 1922 | 100% | finish no earlier than 2025-05-16 |
| 1773 |  | A minimum of 1 supplier & required contracted agents are qualified and ready to operate under new MHHS arrangements | 0d | 2025-09-12 A | 2025-09-12 A |  | 100% | finish no earlier than 2025-09-12 |
| 1774 |  | All LDSOs qualified | 0d | 2025-09-10 A | 2025-09-10 A |  | 100% | finish no earlier than 2025-09-10 |
| 1775 |  | All pre-migration data cleanse activities complete | 0d | 2025-09-22 A | 2025-09-22 A |  | 100% | start no earlier than 2025-09-22 |
| 1776 |  | All data migration activities set out in the cutover plan complete | 0d | 2025-09-24 A | 2025-09-24 A |  | 100% | finish no earlier than 2025-09-24 |
| 1777 |  | ISD fully populated by Elexon | 0d | 2025-09-22 A | 2025-09-22 A |  | 100% | finish no earlier than 2025-09-22 |
| 1778 |  | Significant Code Review Powers (SCR) enacted by Ofgem (M7) and updates to regulatory code ready to be implemented at M8 | 0d | 2024-12-11 A | 2024-12-11 A | 3002 | 100% | finish no earlier than 2024-12-11 |
| 1779 |  | Migration Schedule approved | 0d | 2025-08-19 A | 2025-08-19 A | 3075 | 100% | finish no earlier than 2025-08-19 |
| 1780 |  | Migration Framework approved | 0d | 2025-04-30 A | 2025-04-30 A |  | 100% | finish no earlier than 2025-04-30 |
| 1781 |  | Migration Control Centre (MCC) delegation of authority approved | 0d | 2025-04-30 A | 2025-04-30 A |  | 100% | finish no earlier than 2025-04-30 |
| 1782 |  | Migration incentives implemented | 0d | 2025-04-30 A | 2025-04-30 A |  | 100% | finish no earlier than 2025-04-30 |
| 1783 |  | MCC tested and ready to operate | 0d | 2025-09-19 A | 2025-09-19 A | 3111 | 100% | finish no earlier than 2025-09-19 |
| 1784 |  | Service Delivery Operating Model in place | 0d | 2025-09-19 A | 2025-09-19 A |  | 100% | finish no earlier than 2025-09-19 |
| 1785 |  | Service Delivery Operating Model in place (Self-Certification) | 0d | 2025-07-03 A | 2025-07-03 A |  | 100% | finish no earlier than 2025-07-03 |
| 1786 |  | Early Life Support Model defined | 0d | 2025-04-29 A | 2025-04-29 A | 3470 | 100% | finish no earlier than 2025-03-31 |
| 1787 |  | Early Life Support Model arrangements in place and operational | 0d | 2025-09-12 A | 2025-09-12 A |  | 100% | finish no earlier than 2025-09-12 |
| 1788 |  | Early Life Support Model arrangements in place and operational (Self-Certification) | 0d | 2025-09-12 A | 2025-09-12 A |  | 100% | finish no earlier than 2025-09-12 |
| 1789 |  | M10/M11 Cutover Plan in place | 0d | 2024-05-28 A | 2024-05-28 A |  | 100% | finish no earlier than 2024-05-28 |
| 1790 |  | Central Programme Party Cutover Plans in place | 0d | 2025-07-15 A | 2025-07-15 A |  | 100% | finish no earlier than 2025-07-15 |
| 1791 |  | Production environment in place for LDSOs and Central Parties | 0d | 2025-09-22 A | 2025-09-22 A |  | 100% | finish no earlier than 2025-09-22 |
| 1792 |  | Service activation complete to DIP Production environment for Central Parties and LDSOs | 0d | 2025-10-10 A | 2025-10-10 A |  | 100% | finish no earlier than 2025-10-10 |
| 1793 |  | Cutover Plan executed | 0d | 2025-09-23 A | 2025-09-23 A |  | 100% | finish no earlier than 2025-09-23 |
| 1794 |  | M10 Risk Assessment undertaken | 0d | 2025-09-03 A | 2025-09-03 A |  | 100% | finish no earlier than 2025-09-03 |
| 1795 |  | Roles and responsibilities post-M10 agreed and accepted | 0d | 2025-09-19 A | 2025-09-19 A |  | 100% | finish no earlier than 2025-09-19 |
| 1796 |  | M10 Work off plan agreed (if required) | 0d | 2025-09-19 A | 2025-09-19 A |  | 100% | finish no earlier than 2025-09-19 |
| 1797 |  | Qualification Operating Model in place and operational for all post-M10 activities | 0d | 2025-09-19 A | 2025-09-19 A |  | 100% | finish no earlier than 2025-09-19 |
| 1798 |  | Programme Governance updated to reflect required changes to support Programme delivery post-M10. | 0d | 2025-09-03 A | 2025-09-03 A |  | 100% | start no earlier than 2025-09-03 |
| 1799 |  | All Suppliers and Agents have made the necessary changes to support losing an MPAN via the Forward Migration Process and gaining an MPAN via the Reverse Migration Process. | 0d | 2025-09-19 A | 2025-09-19 A |  | 100% | finish no earlier than 2025-09-19 |
| 1800 |  | Performance Assurance measures are understood and in place to maintain BAU performance during the Migration period. | 0d | 2025-09-12 A | 2025-09-12 A |  | 100% | finish no earlier than 2025-09-12 |
| 1801 |  | Programme monitoring, assurance and escalation process for beyond M10 is in place and operational | 0d | 2025-09-12 A | 2025-09-12 A |  | 100% | finish no earlier than 2025-09-12 |
| 1802 |  | Central systems ready for migrating MPANs (M10) | 0d | 2025-09-22 A | 2025-09-22 A | 1672, 3259, 3266, 2307, 3303 | 100% | start no earlier than 2025-09-22 |
| 1803 |  | M10 Acceptance Criteria Ratification | 0d | 2025-09-24 A | 2025-09-24 A | 1802FS+2d | 100% |  |
| 1804 |  | Central systems ready for migrating MPANs (M10*) - Late Exit | 0d | 2025-12-24 A | 2025-12-24 A | 1802FS+67d | 100% |  |
| 1805 | 1.4.6 | **External Programme Dependency Management** | 174d | 2022-10-31 A | 2023-06-30 A |  | 100% |  |
| 1806 | 1.4.6.1 | **BSC CP1558** | 173d | 2022-10-31 A | 2023-06-29 A |  | 100% |  |
| 1807 |  | Monitor progress to implementation date | 173d | 2022-10-31 A | 2023-06-28 A |  | 100% |  |
| 1808 |  | BSC CP1558 Implementation Date | 0d | 2023-06-29 A | 2023-06-29 A | 1807 | 100% | must start on 2023-06-29 |
| 1809 | 1.4.6.2 | **REC CP R0032** | 174d | 2022-10-31 A | 2023-06-30 A |  | 100% |  |
| 1810 |  | Monitor progress to implementation date | 174d | 2022-10-31 A | 2023-06-29 A |  | 100% |  |
| 1811 |  | REC CP R0032 Implementation Date | 0d | 2023-06-30 A | 2023-06-30 A | 1810 | 100% | must start on 2023-06-30 |
| 1812 | 1.4.6.3 | **REC CP R0044** | 173d | 2022-10-31 A | 2023-06-29 A |  | 100% |  |
| 1813 |  | Monitor progress to implementation date | 173d | 2022-10-31 A | 2023-06-28 A |  | 100% |  |
| 1814 |  | REC CP R0044 Implementation Date | 0d | 2023-06-29 A | 2023-06-29 A | 1813 | 100% | must start on 2023-06-29 |
| 1815 | 1.5 | **NON SIT LDSO QUALIFICATION** | 469d? | 2023-11-07 A | 2025-08-22 A |  | 100% |  |
| 1816 | 1.5.1 | **Approach Planning** | 208d | 2023-11-07 A | 2024-08-22 A |  | 100% |  |
| 1817 |  | Develop Draft Testing Approach & Plan | 61d | 2023-11-07 A | 2024-01-30 A |  | 100% | start no earlier than 2023-11-07 |
| 1818 |  | Draft Testing Approach & Plan Issued to LDSO for Review | 1d | 2024-01-31 A | 2024-01-31 A | 1817 | 100% |  |
| 1819 |  | LDSO Review Complete | 10d | 2024-02-01 A | 2024-02-14 A | 1818 | 100% |  |
| 1820 |  | Update Following LDSO Review | 14d | 2024-02-15 A | 2024-03-05 A | 1819 | 100% |  |

| ID | WBS | Task | Duration | Start | Finish | Predecessors | Complete | Constraint |
| --- | --- | --- | --- | --- | --- | --- | --- | --- |
| 1821 |  | QWG Review of Approach & Plan | 1d | 2024-03-12 A | 2024-03-12 A | 1820FS+4d | 100% |  |
| 1822 |  | QAG Approval for Approach & Plan | 0d | 2024-03-21 A | 2024-03-21 A | 1821FS+7d | 100% |  |
| 1823 |  | Confirmation of Participants for Non-SIT LDSO Qualification Testing | 0d | 2024-03-21 A | 2024-03-21 A | 1822 | 100% |  |
| 1824 |  | Update to Annex 1 for internal review (NF, Not Operational) | 15d | 2024-03-18 A | 2024-04-05 A | 1065 | 100% |  |
| 1825 |  | Non-Functional, Operational & Migration Approaches Socialised with Code Bodies & LDSO & Feedback Actioned | 86d | 2024-04-08 A | 2024-08-05 A | 1824 | 100% |  |
| 1826 |  | QWG Review Operational, Non-Functional & Migration Annexes of Approach & Plan | 1d | 2024-08-13 A | 2024-08-13 A | 1825FS+5d | 100% |  |
| 1827 |  | Update Following QWG Review | 6d | 2024-08-14 A | 2024-08-21 A | 1826 | 100% |  |
| 1828 |  | QAG Approval for Operational, Non-Functional & Migration Annexes of Approach & Plan | 0d | 2024-08-22 A | 2024-08-22 A | 1827FS+1d, 1823, 1068 | 100% |  |
| 1829 | 1.5.2 | **Functional Test Cases & Scenarios** | 58d | 2024-01-30 A | 2024-04-18 A |  | 100% |  |
| 1830 | 1.5.2.1 | **Functional Test Cases & Scenarios Batch 1** | 8d | 2024-01-30 A | 2024-02-08 A |  | 100% |  |
| 1831 |  | Walkthrough Test Cases & Scenarios Batch 1 with Code Bodies | 1d | 2024-01-30 A | 2024-01-30 A | 1817SS+60d | 100% |  |
| 1832 |  | Walkthrough Test Cases & Scenarios Batch 1 with LDSO | 1d | 2024-02-01 A | 2024-02-01 A | 1831 | 100% |  |
| 1833 |  | Action Feedback on Test Cases & Scenarios Batch 1 | 5d | 2024-02-02 A | 2024-02-08 A | 1832 | 100% |  |
| 1834 | 1.5.2.2 | **Functional Test Cases & Scenarios Batch 2** | 14d | 2024-02-20 A | 2024-03-08 A |  | 100% |  |
| 1835 |  | Walkthrough Test Cases & Scenarios Batch 2 with Code Bodies | 1d | 2024-02-20 A | 2024-02-20 A | 1817SS+75d | 100% |  |
| 1836 |  | Walkthrough Test Cases & Scenarios Batch 2 with LDSO | 1d | 2024-03-01 A | 2024-03-01 A | 1835FS+7d | 100% |  |
| 1837 |  | Action Feedback on Test Cases & Scenarios Batch 2 | 5d | 2024-03-04 A | 2024-03-08 A | 1836 | 100% |  |
| 1838 | 1.5.2.3 | **Functional Test Cases & Scenarios Batch 3** | 13d | 2024-03-20 A | 2024-04-05 A |  | 100% |  |
| 1839 |  | Walkthrough Test Cases & Scenarios Batch 3 with Code Bodies | 1d | 2024-03-20 A | 2024-03-20 A | 1817SS+96d | 100% |  |
| 1840 |  | Walkthrough Test Cases & Scenarios Batch 3 with LDSO | 1d | 2024-03-28 A | 2024-03-28 A | 1839FS+5d | 100% |  |
| 1841 |  | Action Feedback on Test Cases & Scenarios Batch 3 | 6d | 2024-03-29 A | 2024-04-05 A | 1840 | 100% |  |
| 1842 |  | Test Cases & Scenarios Batch 1-3 Discussion at QWG | 1d | 2024-04-09 A | 2024-04-09 A | 1833, 1837, 1841FS+1d | 100% |  |
| 1843 |  | Action QWG Feedback on Test Cases & Scenarios Batch 1-3 | 2d | 2024-04-10 A | 2024-04-11 A | 1842 | 100% |  |
| 1844 |  | Batch 1-3 Non-SIT LDSO QT Functional Test Scenarios and Test Cases approved | 0d | 2024-04-18 A | 2024-04-18 A | 1843FS+5d | 100% |  |
| 1845 | 1.5.3 | **Test Execution Schedule** | 161d | 2024-04-19 A | 2024-11-29 A |  | 100% |  |
| 1846 |  | Draft Test Delivery Schedule for Functional and Operational Testing | 20d | 2024-04-19 A | 2024-05-16 A | 1844 | 100% |  |
| 1847 |  | Socialise Test Delivery Schedule with Code Bodies & LDSO for Review & Action Feedback | 37d | 2024-05-17 A | 2024-07-08 A | 1846 | 100% |  |
| 1848 |  | Agree Test Execution Timetable Format at QWG, Including Anonymisation Requirements | 1d | 2024-07-09 A | 2024-07-09 A | 1847 | 100% |  |
| 1849 |  | Action QWG Feedback | 3d | 2024-07-10 A | 2024-07-12 A | 1848 | 100% |  |
| 1850 |  | Agree Test Execution Timetable Format at QAG, Including Anonymisation Requirements | 0d | 2024-07-18 A | 2024-07-18 A | 1849FS+4d | 100% |  |
| 1851 |  | Qualification Testing for Non-SIT LDSOs (Functional, Migration, NFT, Operational) Test Execution Schedule Complete | 0d | 2024-11-29 A | 2024-11-29 A | 1828 | 100% | finish no earlier than 2024-11-29 |
| 1852 | 1.5.4 | **Functional, Non-Functional, Operational & Migration Test Scenarios & Cases** | 110d | 2024-03-22 A | 2024-08-22 A |  | 100% |  |
| 1853 |  | Test Scenarios & Cases - Functional - Drafted, Reviewed | 14d | 2024-04-01 A | 2024-04-18 A | 1822 | 100% |  |
| 1854 |  | Test Scenarios & Cases- Functional - Approved at QAG | 0d | 2024-04-18 A | 2024-04-18 A | 1853 | 100% |  |
| 1855 |  | Test Scenarios & Cases - Non-Functional - Drafted, Reviewed | 110d | 2024-03-22 A | 2024-08-22 A | 1822, 1085FF | 100% |  |
| 1856 |  | Test Scenarios & Cases - Non-Functional - Approved at QAG | 0d | 2024-08-22 A | 2024-08-22 A | 1855 | 100% |  |
| 1857 |  | Test Scenarios & Cases - Migration - Drafted, Reviewed | 45d | 2024-03-22 A | 2024-05-23 A | 1822 | 100% |  |
| 1858 |  | Test Scenarios & Cases - Migration - Approved at QAG | 0d | 2024-05-23 A | 2024-05-23 A | 1857 | 100% |  |
| 1859 |  | Test Scenarios & Cases - Operational - Drafted, Reviewed | 59d | 2024-06-03 A | 2024-08-22 A | 1822FS+51d | 100% |  |
| 1860 |  | Test Scenarios & Cases - Operational - Approved at QAG | 0d | 2024-08-22 A | 2024-08-22 A | 1859, 1085FF | 100% |  |
| 1861 | 1.5.5 | **Test Data** | 345d | 2024-01-22 A | 2025-05-16 A |  | 100% |  |
| 1862 |  | Test Data Plan Drafted & Reviewed | 89d | 2024-01-22 A | 2024-05-23 A | 1817 | 100% |  |
| 1863 |  | Non-SIT LDSO QT Test Data Plan Approved by QAG | 0d | 2024-05-23 A | 2024-05-23 A | 1862 | 100% |  |
| 1864 |  | Develop Test Data Matrices | 10d | 2024-05-24 A | 2024-06-06 A | 1863 | 100% |  |
| 1865 |  | Test Data Cut | 17d | 2024-05-24 A | 2024-06-17 A | 1863 | 100% |  |
| 1866 |  | Test Data Cut Complete | 0d | 2024-06-17 A | 2024-06-17 A | 1865, 1864 | 100% |  |
| 1867 |  | Test Data Reviewed by the Programme | 39d | 2024-06-18 A | 2024-08-09 A | 1866 | 100% |  |
| 1868 |  | Test Data Loaded | 85d | 2024-08-12 A | 2024-12-06 A | 1867 | 100% |  |
| 1869 |  | Test Data Signed Off | 0d | 2024-12-06 A | 2024-12-06 A | 1868 | 100% |  |
| 1870 |  | Test Execution Data Support | 115d | 2024-12-09 A | 2025-05-16 A | 1869 | 100% |  |
| 1871 | 1.5.6 | **Tooling** | 148d | 2024-01-31 A | 2024-08-23 A |  | 100% |  |
| 1872 |  | Design Approach & Set-Up ADO Tool for Test & Defect Management Tool | 53d | 2024-01-31 A | 2024-04-12 A | 1817 | 100% |  |
| 1873 |  | Develop Training Requirements & Materials Inc. Day in the Life | 87d | 2024-04-15 A | 2024-08-13 A | 1872 | 100% |  |
| 1874 |  | ADO Launch complete | 1d | 2024-08-23 A | 2024-08-23 A | 1873, 1854, 1858, 1860 | 100% |  |
| 1875 | 1.5.7 | **Pre-Integration Testing** | 263d | 2024-01-31 A | 2025-01-31 A |  | 100% |  |
| 1876 |  | PIT Guidance & Templates & Approach & Plans Developed | 106d | 2024-02-05 A | 2024-07-01 A | 1817FS+3d | 100% |  |
| 1877 |  | PIT Test Approach & Plan Deadline for Submission for Non-SIT LDSO​ QT | 0d | 2024-07-01 A | 2024-07-01 A | 1876 | 100% |  |
| 1878 |  | Develop and agree PIT Test Scenarios | 20d | 2024-07-02 A | 2024-07-29 A | 1877 | 100% |  |
| 1879 |  | PIT Execution (Functional and Migration) | 45d | 2024-09-30 A | 2024-11-29 A | 1878 | 100% | start no earlier than 2024-09-30 |
| 1880 |  | PIT Execution (Non-Functional and Operational) | 95d | 2024-09-23 A | 2025-01-31 A | 1878 | 100% | finish no earlier than 2025-01-31 |
| 1881 |  | Non-SIT LDSO Participants have submitted functional PIT Test Completion Report & evidence for QT Entry​ | 0d | 2024-11-29 A | 2024-11-29 A | 1879 | 100% |  |
| 1882 |  | Non-SIT LDSO Participants have submitted non-functional PIT Test Completion Report | 0d | 2025-01-31 A | 2025-01-31 A | 1880 | 100% |  |
| 1883 | 1.5.7.8 | **Placing Reliance - Code Body & LDSO Functional and Migration** | 147d | 2024-01-31 A | 2024-08-22 A |  | 100% |  |
| 1884 |  | Placing Reliance Submitted & Reviewed | 21d | 2024-01-31 A | 2024-02-28 A | 1817 | 100% |  |
| 1885 |  | Define & Agree QT Testing for Each LDSO | 22d | 2024-02-29 A | 2024-03-29 A | 1884 | 100% |  |
| 1886 |  | Develop Test Scope & Reliance Submissions | 20d | 2024-04-01 A | 2024-04-26 A | 1885 | 100% |  |
| 1887 |  | Review and Consultation | 84d | 2024-04-29 A | 2024-08-22 A | 1886, 1828FF | 100% |  |
| 1888 | 1.5.7.9 | **Placing Reliance - Code Body & LDSO Non Functional and Operational** | 49d | 2024-06-17 A | 2024-08-22 A |  | 100% |  |
| 1889 |  | Placing Reliance Submitted & Reviewed | 32d | 2024-06-17 A | 2024-07-30 A | 1826FF-10d | 100% |  |
| 1890 |  | Review and Consultation | 17d | 2024-07-31 A | 2024-08-22 A | 1889 | 100% |  |

| ID | WBS | Task | Duration | Start | Finish | Predecessors | Complete | Constraint |
| --- | --- | --- | --- | --- | --- | --- | --- | --- |
| 1891 |  | PP Test Scope Presented at QAG | 0d | 2024-08-22 A | 2024-08-22 A | 1890, 1887 | 100% |  |
| 1892 | 1.5.8 | **LDSO Test Readiness Reporting** | 71d | 2024-04-19 A | 2024-07-26 A |  | 100% |  |
| 1893 |  | Interim Test Readiness Report & Plan Developed & Reviewed | 71d | 2024-04-19 A | 2024-07-26 A | 1844 | 100% |  |
| 1894 |  | Test Plan Submission to MHHS Programme For Review | 0d | 2024-07-26 A | 2024-07-26 A | 1893 | 100% |  |
| 1895 | 1.5.9 | **Test Environment** | 163d | 2024-04-17 A | 2024-11-29 A |  | 100% |  |
| 1896 |  | Define Test Harness Requirements and Sign-Off with SRO | 13d | 2024-04-17 A | 2024-05-03 A | 516 | 100% |  |
| 1897 |  | Central System (DIP Env & Helix Test Harness) Test Environment DBT | 163d | 2024-04-17 A | 2024-11-29 A | 516 | 100% | finish no earlier than 2024-11-29 |
| 1898 |  | Coordinate LDSO Environment Preparation | 101d | 2024-07-12 A | 2024-11-29 A | 1897FF | 100% |  |
| 1899 |  | DIP available for Onboarding | 1d | 2024-08-01 A | 2024-08-01 A |  | 100% | start no earlier than 2024-08-01 |
| 1900 |  | Qualification Testing for Non-SIT LDSOs Participants' environments) Ready to start DIP onboarding (incl. certificates and security compliance) | 0d | 2024-08-05 A | 2024-08-05 A | 1899FS+2d | 100% |  |
| 1901 |  | LDSO Test Environments Connection Confirmed to UIT Environment | 0d | 2024-11-29 A | 2024-11-29 A | 1900FS+32d, 1898 | 100% |  |
| 1902 | 1.5.10 | **Test Readiness** | 124d | 2024-07-02 A | 2024-12-20 A |  | 100% |  |
| 1903 |  | Preparation for Interim Test Readiness Report | 19d | 2024-07-02 A | 2024-07-26 A | 1877 | 100% |  |
| 1904 |  | Interim Test Readiness Report Submission to MHHS Programme for Review | 0d | 2024-07-26 A | 2024-07-26 A | 1903 | 100% |  |
| 1905 |  | LDSO Update Readiness Report & Final Assurance by Programme | 99d | 2024-07-29 A | 2024-12-12 A | 1904 | 100% |  |
| 1906 |  | Final Test Readiness Report Submitted to MHHS Programme | 1d | 2024-12-13 A | 2024-12-13 A | 1905 | 100% |  |
| 1907 |  | Final Programme Assurance of LDSO Test Readiness | 6d | 2024-12-13 A | 2024-12-20 A | 1905 | 100% |  |
| 1908 |  | Qualification Testing for Non-SIT LDSOs (Functional, Migration, NFT, Operational) Programme Test Readiness confirmed | 0d | 2024-12-20 A | 2024-12-20 A | 1906FS+5d, 1881, 1854, 1856, 1858, 1896 | 100% |  |
| 1909 |  | Qualification Testing for Non-SIT LDSOs (Functional, Migration, NFT, Operational) Test Readiness Confirmed (Final Test Readiness Review for LDSO) | 0d | 2024-12-20 A | 2024-12-20 A | 1905, 1907 | 100% |  |
| 1910 | 1.5.11 | **Test Window** | 165d? | 2025-01-06 A | 2025-08-22 A |  | 100% |  |
| 1911 | 1.5.11.1 | **All Non-SIT LDSOs Qualification Testing** | 94d | 2025-01-06 A | 2025-05-16 A | 1909, 1901 | 100% |  |
| 1912 |  | Non-SIT LDSO QT Test Execution Starts | 0d | 2025-01-06 A | 2025-01-06 A | 1909FS+11d | 100% | start no earlier than 2024-11-01 |
| 1913 |  | LDSO Alpha | 86d | 2025-01-06 A | 2025-05-05 A | 1912FS-1d | 100% |  |
| 1914 |  | LDSO Bravo | 86d | 2025-01-06 A | 2025-05-05 A | 1912FS-1d | 100% | finish no earlier than 2025-05-05 |
| 1915 |  | LDSO Charlie | 88d | 2025-01-06 A | 2025-05-07 A | 1912FS-1d | 100% |  |
| 1916 |  | LDSO Delta | 83d | 2025-01-06 A | 2025-04-30 A | 1912FS-1d | 100% |  |
| 1917 |  | LDSO Echo | 69d | 2025-01-06 A | 2025-04-10 A | 1912FS-1d | 100% |  |
| 1918 |  | LDSO Foxtrot | 84d | 2025-01-20 A | 2025-05-15 A | 1912FS+9d | 100% | finish no earlier than 2025-05-15 |
| 1919 |  | LDSO Golf | 80d | 2025-01-06 A | 2025-04-25 A | 1912FS-1d | 100% | finish no earlier than 2025-04-25 |
| 1920 |  | LDSO Hotel | 86d | 2025-01-06 A | 2025-05-05 A | 1912FS-1d | 100% | finish no earlier than 2025-05-05 |
| 1921 |  | LDSO India | 86d | 2025-01-06 A | 2025-05-05 A | 1912FS-1d | 100% |  |
| 1922 |  | Qualification Testing for Non-SIT LDSOs (Functional, Migration, NFT, Operational) 1 End | 0d | 2025-05-16 A | 2025-05-16 A | 1913, 1914, 1915, 1916, 1917, 1918, 1919, 1920, 1921 | 100% | start no earlier than 2025-05-16 |
| 1923 |  | Potential for non-SIT LDSO QT Regression for Qualification | 70d? | 2025-05-19 A | 2025-08-22 A | 1922FS+1d | 100% |  |
| 1924 | 1.5.12 | **Test Result Assurance** | 30d | 2025-04-04 A | 2025-05-16 A |  | 100% |  |
| 1925 |  | Test Reports Reviewed By MHHS & Code Bodies & Finalised | 30d | 2025-04-04 A | 2025-05-16 A | 1922FF | 100% |  |
| 1926 |  | Non-SIT LDSOs submission deadline for their QT Test Completion Report to MHHS Programme | 0d | 2025-05-16 A | 2025-05-16 A | 1925, 1911, 1922 | 100% |  |
| 1927 | 1.5.13 | **Non-SIT LDSO Qualification Closure** | 31d | 2025-05-16 A | 2025-06-27 A |  | 100% |  |
| 1928 |  | Non-SIT LDSO Qualification Learned Captured | 10d | 2025-05-16 A | 2025-05-29 A | 1926 | 100% | start no earlier than 2025-04-16 |
| 1929 |  | Non-SIT LDSO Regression Testing | 26d | 2025-05-16 A | 2025-06-20 A | 1926 | 100% |  |
| 1930 |  | Non-SIT LDSO Qualification Closure Down | 5d | 2025-06-23 A | 2025-06-27 A | 1929 | 100% | finish no earlier than 2025-06-26 |
| 1931 | 1.6 | **HELIX / ELEXON M10 READINESS** | 837d? | 2022-10-31 | 2026-01-13 A |  | 100% |  |
| 1932 | 1.6.1 | **Service Management - M10 Readiness** | 147d | 2025-03-03 A | 2025-09-24 A |  | 100% |  |
| 1933 | 1.6.1.1 | **Service Model Design (Cross Party Service Desk)** | 135d | 2025-03-03 A | 2025-09-05 A |  | 100% |  |
| 1934 | 1.6.1.1.1 | **Cross Party Service Desk** | 55d | 2025-03-03 A | 2025-05-19 A |  | 100% |  |
| 1935 |  | Cross Party Service Desk Definition and Design | 24d | 2025-03-03 A | 2025-04-03 A |  | 100% |  |
| 1936 |  | Cross Party Service Desk Design Document MHHS Review | 0d | 2025-04-03 A | 2025-04-03 A | 1935 | 100% | start no earlier than 2025-04-03 |
| 1937 |  | Cross Party Service Desk Model Issued | 0d | 2025-04-07 A | 2025-04-07 A | 1936 | 100% | start no earlier than 2025-04-07 |
| 1938 |  | Cross Party Service Desk Model Reissued | 0d | 2025-04-15 A | 2025-04-15 A | 1937 | 100% | start no earlier than 2025-04-15 |
| 1939 | 1.6.1.1.1.5 | **Cross Party Service Desk Consultation** | 30d | 2025-04-07 A | 2025-05-19 A |  | 100% |  |
| 1940 |  | Cross Party Service Desk Consultation | 16d | 2025-04-07 A | 2025-04-28 A | 1936, 1938FF | 100% | finish no earlier than 2025-04-28 |
| 1941 |  | Cross Party Service Desk Consultation Completed | 0d | 2025-04-28 A | 2025-04-28 A | 1940 | 100% | start no earlier than 2025-03-28 |
| 1942 |  | Cross Party Service Desk Model Updates (Feedback Review) | 8d | 2025-04-29 A | 2025-05-08 A | 1941 | 100% | start no earlier than 2025-04-23 |
| 1943 |  | Cross Party Service Desk Model Spotlight at Elexon Service Management Steering Group | 0d | 2025-05-07 A | 2025-05-07 A | 1942FF-1d | 100% | start no earlier than 2025-05-07 |
| 1944 |  | Updated Consultation Documents Shared with MHHS and Industry | 0d | 2025-05-08 A | 2025-05-08 A | 1942 | 100% | start no earlier than 2025-04-14 |
| 1945 |  | TORWG Post-Consultation Update (CPSD) | 0d | 2025-05-14 A | 2025-05-14 A | 1944 | 100% | start no earlier than 2025-05-14 |
| 1946 |  | Updated Consultation Documents Released to Industry for eTORWG | 0d | 2025-05-16 A | 2025-05-16 A | 1945FS+3d | 100% |  |
| 1947 |  | CPSD, Operating Hours & Triage Updates Endorsement (eTORWG) | 0d | 2025-05-19 A | 2025-05-19 A | 1946 | 100% | start no earlier than 2025-05-19 |
| 1948 |  | Cross Party Service Desk Model Completed | 0d | 2025-05-19 A | 2025-05-19 A | 1947 | 100% | start no earlier than 2025-03-28 |
| 1949 | 1.6.1.1.2 | **Service Documentation** | 77d | 2025-04-29 A | 2025-08-13 A |  | 100% |  |
| 1950 |  | Operations Manual Updates Post-Consultation | 13d | 2025-04-29 A | 2025-05-15 A | 1941 | 100% | start no earlier than 2025-04-23 |
| 1951 |  | Operations Manual Version 1.3 (TORWG) | 0d | 2025-05-15 A | 2025-05-15 A | 1950 | 100% |  |
| 1952 |  | Operations Manual Updates Pre-ORT | 14d | 2025-05-16 A | 2025-06-04 A | 1951 | 100% | start no earlier than 2025-05-16 |
| 1953 |  | Operations Manual version 1.4 (ORT) (TORWG Paper Day) | 0d | 2025-06-04 A | 2025-06-04 A |  | 100% | start no earlier than 2025-06-04 |
| 1954 |  | Service User LLSD Updates Post Consultation | 13d | 2025-05-19 A | 2025-06-04 A |  | 100% | start no earlier than 2025-05-19 |
| 1955 |  | Service User LLSD Version 1.2 (ORT) (TORWG Paper Day) | 0d | 2025-06-04 A | 2025-06-04 A | 1953 | 100% |  |
| 1956 |  | CPSD Scenarios and Runbook | 19d | 2025-04-29 A | 2025-05-23 A |  | 100% | start no earlier than 2025-04-29 |
| 1957 |  | CPSD Scenarios and Runbook Shared with MHHS Team for Review | 0d | 2025-05-23 A | 2025-05-23 A | 1956 | 100% |  |
| 1958 |  | CPSD Scenarios and Runbook Review Window | 8d | 2025-05-26 A | 2025-06-04 A | 1957 | 100% |  |
| 1959 |  | CPSD Scenarios and Runbook Released for TORWG (Paper Day) | 0d | 2025-06-04 A | 2025-06-04 A | 1958 | 100% |  |
| 1960 |  | Parent/Child Industry Engagement Session | 0d | 2025-06-06 A | 2025-06-06 A | 1959 | 100% | start no earlier than 2025-06-06 |

| ID | WBS | Task | Duration | Start | Finish | Predecessors | Complete | Constraint |
| --- | --- | --- | --- | --- | --- | --- | --- | --- |
| 1961 |  | CPSD Runbook Completed | 0d | 2025-06-11 A | 2025-06-11 A | 1959FS+5d | 100% |  |
| 1962 | 1.6.1.1.2.13 | **Service Documentation V2** | 23d | 2025-07-14 A | 2025-08-13 A |  | 100% |  |
| 1963 |  | Post-ORT Operations Manual and LLSD Updates | 3d | 2025-07-14 A | 2025-07-16 A | 1951, 2019 | 100% | start no earlier than 2025-07-14 |
| 1964 |  | M10 Operations Manual Version 2.0 & LLSD Issued for Consultation | 0d | 2025-07-16 A | 2025-07-16 A | 1963 | 100% | start no earlier than 2025-04-01 |
| 1965 |  | Operations Manual and LLSD v2 Consultation | 10d | 2025-07-17 A | 2025-07-30 A | 1964 | 100% |  |
| 1966 |  | Operations Manual and LLSD v2 Consultation Completed | 0d | 2025-07-30 A | 2025-07-30 A | 1965 | 100% |  |
| 1967 |  | Consultation Feedback Implemented Operations Manual and LLSD v2 | 5d | 2025-07-31 A | 2025-08-06 A | 1966 | 100% |  |
| 1968 |  | Operations Manual and LLSD v2 Feedback Implemented | 0d | 2025-08-06 A | 2025-08-06 A | 1967 | 100% |  |
| 1969 |  | TORWG Paper Day | 0d | 2025-08-06 A | 2025-08-06 A | 1968 | 100% |  |
| 1970 |  | TORWG Operations Manual and LLSD v2 Approval | 0d | 2025-08-13 A | 2025-08-13 A | 1969FS+5d | 100% |  |
| 1971 |  | Operations Manual and LLSD v2 Approved and Completed | 0d | 2025-08-13 A | 2025-08-13 A | 1970 | 100% |  |
| 1972 | 1.6.1.1.3 | **LDSO Onboarding - Phase 1** | 28d | 2025-06-23 A | 2025-07-30 A |  | 100% |  |
| 1973 |  | LDSO Communication and Information Gathering - Phase 1 | 18d | 2025-06-23 A | 2025-07-16 A |  | 100% | start no earlier than 2025-06-23 |
| 1974 |  | LDSO Communication and Information Gathering Completed - Phase 1 | 0d | 2025-07-16 A | 2025-07-16 A |  | 100% | start no earlier than 2025-07-16 |
| 1975 |  | LDSO ServiceNow Configuration - Phase 1/2 | 10d | 2025-07-10 A | 2025-07-23 A | 1973SS+13d | 100% |  |
| 1976 |  | LDSO ServiceNow Configuration Completed - Phase 1/2 | 0d | 2025-07-16 A | 2025-07-16 A |  | 100% | finish no earlier than 2025-07-16 |
| 1977 |  | LDSO Testing and Further Communication - Phase 1 | 6d | 2025-07-23 A | 2025-07-30 A | 1975SS+9d | 100% |  |
| 1978 |  | LDSO Testing and Further Communication Completed - Phase 1 | 0d | 2025-07-30 A | 2025-07-30 A |  | 100% | start no earlier than 2025-07-30 |
| 1979 |  | LDSOs Onboarded into Elexon ServiceNow - Phase 1 | 0d | 2025-07-30 A | 2025-07-30 A | 1977 | 100% |  |
| 1980 | 1.6.1.1.4 | **LDSO Onboarding - Phase 2** | 27d | 2025-07-31 A | 2025-09-05 A |  | 100% |  |
| 1981 |  | LDSO Resources Enrolled in Authenticator - Phase 2 | 20d | 2025-07-31 A | 2025-08-27 A |  | 100% | start no earlier than 2025-07-31 |
| 1982 |  | LDSO Resources Enrolled in Authenticator Completed - Phase 2 | 0d | 2025-08-27 A | 2025-08-27 A |  | 100% | start no earlier than 2025-08-27 |
| 1983 |  | Elexon Phase 2 Resources Setup in Portal - Phase 2 | 7d | 2025-08-28 A | 2025-09-05 A | 1981 | 100% |  |
| 1984 |  | Elexon Phase 2 Resources Setup in Portal Completed - Phase 2 | 0d | 2025-09-05 A | 2025-09-05 A | 1983 | 100% |  |
| 1985 | 1.6.1.2 | **Operational Readiness Testing** | 116d | 2025-03-03 A | 2025-08-12 A |  | 100% |  |
| 1986 | 1.6.1.2.1 | **ORT Design** | 72d | 2025-03-03 A | 2025-06-10 A |  | 100% |  |
| 1987 |  | ORT Test Scope and Approach | 25d | 2025-03-03 A | 2025-04-04 A | 1935FF | 100% | start no earlier than 2025-03-03 |
| 1988 |  | ORT Test Approach Shared with MHHS (Initial Review) | 0d | 2025-04-02 A | 2025-04-02 A | 1987FS-3d | 100% | start no earlier than 2025-04-02 |
| 1989 |  | ORT Test Scenarios Shared with MHHS (Initial Review) | 0d | 2025-04-02 A | 2025-04-02 A | 1987FS-3d | 100% | start no earlier than 2025-04-02 |
| 1990 |  | ORT Test Scope and Approach Documents Shared with Industry | 0d | 2025-04-07 A | 2025-04-07 A | 1989 | 100% | start no earlier than 2025-04-07 |
| 1991 | 1.6.1.2.1.5 | **ORT Test Scope and Approach Consultation (Test Scope and Approach & Test Scripts)** | 29d | 2025-04-08 A | 2025-05-19 A |  | 100% |  |
| 1992 |  | ORT Test Scope and Approach Consultation | 15d | 2025-04-08 A | 2025-04-28 A | 1990 | 100% | finish no earlier than 2025-04-28 |
| 1993 |  | ORT Test Scope and Approach Consultation Completed | 0d | 2025-04-28 A | 2025-04-28 A | 1992 | 100% | start no earlier than 2025-03-28 |
| 1994 |  | ORT Test Scope and Approach Updates (Feedback Review) | 8d | 2025-04-29 A | 2025-05-08 A | 1993 | 100% | start no earlier than 2025-04-14 |
| 1995 |  | Updated ORT Test Scope and Approach Documents Shared with MHHS and Industry | 0d | 2025-05-08 A | 2025-05-08 A | 1994 | 100% | start no earlier than 2025-04-14 |
| 1996 |  | TORWG Post-Consultation Update (ORT Approach) | 0d | 2025-05-14 A | 2025-05-14 A | 1995 | 100% | start no earlier than 2025-05-14 |
| 1997 |  | Updated ORT Test Scope and Approach Documents Released to Industry for eSITWG | 0d | 2025-05-16 A | 2025-05-16 A | 1995, 1996 | 100% | start no earlier than 2025-05-16 |
| 1998 |  | ORT Test Scope and Approach Endorsement (eSITWG) | 0d | 2025-05-19 A | 2025-05-19 A | 1997 | 100% | start no earlier than 2025-05-19 |
| 1999 |  | ORT Test Script Production and Updates | 23d | 2025-04-08 A | 2025-05-08 A | 1993FF, 1994FF, 1940FF | 100% | start no earlier than 2025-04-07 |
| 2000 |  | ORT Test Scripts Shared | 0d | 2025-05-08 A | 2025-05-08 A | 1999 | 100% | start no earlier than 2025-05-07 |
| 2001 | 1.6.1.2.1.8 | **ORT Test Scripts Consultation** | 25d | 2025-05-07 A | 2025-06-10 A |  | 100% |  |
| 2002 |  | ORT Spotlight (Test Approach) at Elexon Service Management Helix Steering Group | 0d | 2025-05-07 A | 2025-05-07 A |  | 100% | start no earlier than 2025-05-07 |
| 2003 |  | ORT Test Scripts Consultation | 6d | 2025-05-09 A | 2025-05-16 A | 1999, 2000 | 100% | start no earlier than 2025-05-01 |
| 2004 |  | ORT Test Scripts Consultation Completed | 0d | 2025-05-16 A | 2025-05-16 A | 2003 | 100% | start no earlier than 2025-03-28 |
| 2005 |  | ORT Test Scripts Updates (Feedback Review) | 4d | 2025-05-19 A | 2025-05-22 A | 2004 | 100% | start no earlier than 2025-04-02 |
| 2006 |  | ORT Test Scipts Updates Shared with MHHS and Industry | 0d | 2025-05-22 A | 2025-05-22 A | 2005 | 100% | start no earlier than 2025-04-14 |
| 2007 |  | Industry Assurance Review Session Post-Consultation Update (ORT Test Scripts) | 0d | 2025-05-30 A | 2025-05-30 A | 2006FS+6d | 100% | start no earlier than 2025-04-14 |
| 2008 |  | Updated ORT Test Script Consultation Documents Released to industry for eSITWG | 0d | 2025-06-03 A | 2025-06-03 A | 2007FS+2d | 100% | start no earlier than 2025-04-04 |
| 2009 |  | ORT Test Scripts and Readiness Spotlight at Elexon Service Management Steering Group | 0d | 2025-06-04 A | 2025-06-04 A | 2008FS+1d | 100% | start no earlier than 2025-04-22 |
| 2010 |  | ORT Test Scipt Updates Endorsement (eSITWG) | 0d | 2025-06-10 A | 2025-06-10 A | 2008FS+5d | 100% | start no earlier than 2025-04-14 |
| 2011 | 1.6.1.2.2 | **ORT Preparation** | 32d | 2025-05-01 A | 2025-06-13 A |  | 100% |  |
| 2012 |  | ORT Participant/User Scheduling | 24d | 2025-05-01 A | 2025-06-03 A |  | 100% | start no earlier than 2025-05-01 |
| 2013 |  | ORT Participant/User Scheduling Completed | 0d | 2025-06-03 A | 2025-06-03 A | 2012 | 100% | start no earlier than 2025-03-28 |
| 2014 |  | ORT Training and Preparation | 6d | 2025-06-04 A | 2025-06-11 A | 1992, 1999, 2002, 2006 | 100% | start no earlier than 2025-06-04 |
| 2015 |  | ORT DITL Session | 0d | 2025-06-12 A | 2025-06-12 A | 2004FS+2d, 2007 | 100% | start no earlier than 2025-06-12 |
| 2016 |  | ORT Orientation (JiT) | 0d | 2025-06-13 A | 2025-06-13 A | 2014FS+2d | 100% | start no earlier than 2025-05-30 |
| 2017 | 1.6.1.2.3 | **ORT Execution** | 20d | 2025-06-16 A | 2025-07-11 A |  | 100% |  |
| 2018 |  | ORT Execution | 20d | 2025-06-16 A | 2025-07-11 A | 2014, 2016, 1998 | 100% | start no earlier than 2025-06-02 |
| 2019 |  | ORT Execution Completed | 0d | 2025-07-11 A | 2025-07-11 A | 2018 | 100% | start no earlier than 2025-03-28 |
| 2020 | 1.6.1.2.4 | **ORT Exit** | 14d | 2025-07-14 A | 2025-07-31 A | 1998, 2005, 2008, 2012 | 100% |  |
| 2021 |  | ORT Wrap Up | 5d | 2025-07-14 A | 2025-07-18 A | 2019 | 100% | start no earlier than 2025-04-22 |
| 2022 |  | ORT Exit Report | 10d | 2025-07-14 A | 2025-07-25 A | 2019 | 100% | start no earlier than 2025-04-02 |
| 2023 |  | ORT Exit Report Shared with Participants | 0d | 2025-07-25 A | 2025-07-25 A | 2022 | 100% | start no earlier than 2025-04-22 |
| 2024 |  | ORT eSITWG Exit Report Endorsement | 0d | 2025-07-31 A | 2025-07-31 A | 2023FS+4d | 100% | start no earlier than 2025-04-02 |
| 2025 | 1.6.1.2.5 | **Codification of Service** | 67d | 2025-05-09 A | 2025-08-12 A |  | 100% |  |
| 2026 |  | OFGEM Review Meeting | 0d | 2025-05-09 A | 2025-05-09 A |  | 100% | start no earlier than 2025-04-04 |
| 2027 |  | Codification Update at TORWG | 0d | 2025-05-14 A | 2025-05-14 A | 2026 | 100% | start no earlier than 2025-05-14 |
| 2028 |  | DIP Code Change Presented at DCAB | 0d | 2025-08-12 A | 2025-08-12 A |  | 100% | start no earlier than 2025-08-12 |
| 2029 | 1.6.1.3 | **Service Go-Live** | 32d | 2025-07-31 A | 2025-09-15 A |  | 100% |  |
| 2030 |  | Service Management Ready (inc. Partners) | 0d | 2025-07-31 A | 2025-07-31 A |  | 100% |  |

| ID | WBS | Task | Duration | Start | Finish | Predecessors | Complete | Constraint |
| --- | --- | --- | --- | --- | --- | --- | --- | --- |
| 2031 |  | Helix Service Management Live for LDSO DIP Onboarding | 0d | 2025-08-04 A | 2025-08-04 A | 1979 | 100% | start no earlier than 2025-08-04 |
| 2032 |  | Helix Service Management Live for MHHS Enduring Arrangements | 0d | 2025-09-15 A | 2025-09-15 A | 2039 | 100% | start no earlier than 2025-09-15 |
| 2033 | 1.6.1.4 | **Non-LDSO SIT PPs ServiceNow Onboarding** | 12d | 2025-09-05 A | 2025-09-24 A |  | 100% |  |
| 2034 |  | Pathway 2 | 0d | 2025-09-05 A | 2025-09-05 A |  | 100% | finish no earlier than 2025-09-05 |
| 2035 |  | Pathway 3 | 0d | 2025-09-09 A | 2025-09-09 A |  | 100% | start no earlier than 2025-09-09 |
| 2036 |  | Pathway 4 | 0d | 2025-09-24 A | 2025-09-24 A |  | 100% | start no earlier than 2025-09-24 |
| 2037 | 1.6.2 | **Business Readiness (inc DIP)** | 140d? | 2025-04-07 A | 2025-10-17 A |  | 100% |  |
| 2038 |  | Knowledge Transfer triage | 35d? | 2025-04-28 A | 2025-06-13 A |  | 100% | start no earlier than 2025-04-28 |
| 2039 |  | Elexon Leading Triage | 56d | 2025-06-16 A | 2025-09-01 A | 2038 | 100% | start no earlier than 2025-06-16 |
| 2040 |  | MHHS Transition (Knowledge Transfer) | 64d | 2025-05-06 A | 2025-08-01 A |  | 100% | start no earlier than 2025-05-06 |
| 2041 |  | Artefact Handshake with MHHS | 0d | 2025-09-01 A | 2025-09-01 A | 2040 | 100% | finish no earlier than 2025-09-01 |
| 2042 |  | Operational Control Centre (OCC) Development | 85d | 2025-04-07 A | 2025-08-01 A |  | 100% | start no earlier than 2025-04-07 |
| 2043 |  | Operational Control Centre (OCC) Live (Service and ULT Triage) | 0d | 2025-08-04 A | 2025-08-04 A | 2042FS+1d | 100% |  |
| 2044 |  | Operational Control Centre (OCC) Live | 0d | 2025-08-29 A | 2025-08-29 A |  | 100% | finish no earlier than 2025-08-29 |
| 2045 | 1.6.2.8 | **DIP Guidance Notes** | 55d | 2025-05-05 A | 2025-07-18 A |  | 100% |  |
| 2046 |  | GN/LWI creation & publication | 55d | 2025-05-05 A | 2025-07-18 A |  | 100% | start no earlier than 2025-05-05 |
| 2047 |  | Tranche 1 GN/LWI created & published (critical for M10) | 0d | 2025-06-20 A | 2025-06-20 A |  | 100% | start no earlier than 2025-06-20 |
| 2048 |  | Tranche 2 GN/LWI created & published | 0d | 2025-07-04 A | 2025-07-04 A |  | 100% | start no earlier than 2025-07-04 |
| 2049 |  | Tranche 3 GN/LWI created & published | 0d | 2025-07-18 A | 2025-07-18 A |  | 100% | start no earlier than 2025-07-18 |
| 2050 |  | DIP Reporting (M11) | 115d | 2025-05-12 A | 2025-10-17 A |  | 100% | start no earlier than 2025-05-12 |
| 2051 |  | Functional Training Execution | 95d | 2025-05-05 A | 2025-09-12 A |  | 100% | start no earlier than 2025-05-05 |
| 2052 | 1.6.3 | **DIP UIT Onboarding** | 837d? | 2022-10-31 | 2026-01-13 A |  | 100% |  |
| 2053 | 1.6.3.1 | **LDSOs** | 0d | 2025-07-25 A | 2025-07-25 A |  | 100% |  |
| 2054 |  | Date to be Onboarded by | 0d | 2025-07-25 A | 2025-07-25 A |  | 100% | start no earlier than 2025-07-25 |
| 2055 | 1.6.3.2 | **Pathway 2** | 23d | 2025-07-25 A | 2025-08-27 A |  | 100% |  |
| 2056 |  | Proforma Issued | 0d | 2025-07-25 A | 2025-07-25 A |  | 100% | start no earlier than 2025-07-25 |
| 2057 |  | Invite to Onbaord Issued | 0d | 2025-08-08 A | 2025-08-08 A |  | 100% | start no earlier than 2025-08-08 |
| 2058 |  | Date to be Onboarded by | 0d | 2025-08-27 A | 2025-08-27 A |  | 100% | start no earlier than 2025-08-27 |
| 2059 | 1.6.3.3 | **Pathway 3** | 0d | 2022-10-31 | 2022-10-31 |  | 100% |  |
| 2060 |  | Proforma Issued | 0d | 2025-08-04 A | 2025-08-04 A |  | 100% | start no earlier than 2025-08-04 |
| 2061 |  | Invite to Onbaord Issued | 0d | 2025-08-18 A | 2025-08-18 A |  | 100% | start no earlier than 2025-08-18 |
| 2062 |  | Date to be Onboarded by | 0d | 2025-09-09 A | 2025-09-09 A |  | 100% | start no earlier than 2025-09-09 |
| 2063 | 1.6.3.4 | **Pathway 4** | 0d | 2022-10-31 | 2022-10-31 |  | 100% |  |
| 2064 |  | Proforma Issued | 0d | 2025-08-22 A | 2025-08-22 A |  | 100% | start no earlier than 2025-08-22 |
| 2065 |  | Invite to Onbaord Issued | 0d | 2025-09-05 A | 2025-09-05 A |  | 100% | start no earlier than 2025-09-05 |
| 2066 |  | Date to be Onboarded by | 0d | 2025-09-24 A | 2025-09-24 A |  | 100% | start no earlier than 2025-09-24 |
| 2067 | 1.6.3.5 | **Operational Readiness E2E Testing** | 64d | 2025-05-13 | 2025-08-08 |  | 100% |  |
| 2068 |  | Phase 1 Test Execution (Service Activation and Participant Management) | 66d | 2025-05-14 A | 2025-08-13 A |  | 100% | finish no earlier than 2025-07-18 |
| 2069 |  | Phase 2 Test Execution (S&I) | 45d | 2025-06-11 A | 2025-08-20 A |  | 100% | finish no earlier than 2025-07-11 |
| 2070 |  | Phase 3 Test Execution (Assurance & mop-up) | 25d | 2025-07-21 A | 2025-08-22 A |  | 100% | start no earlier than 2025-07-21 |
| 2071 |  | E2E Operational Testing Completed | 0d | 2025-09-05 A | 2025-09-05 A | 2068, 2069, 2070 | 100% | finish no earlier than 2025-09-05 |
| 2072 | 1.6.3.6 | **Service Activation Readiness** | 466d? | 2024-04-02 A | 2026-01-13 A |  | 100% |  |
| 2073 | 1.6.3.6.1 | **Phase 1 - Preparation** | 374d? | 2024-04-02 A | 2025-09-05 A |  | 100% |  |
| 2074 | 1.6.3.6.1.1 | **Business Service Activation Governance, Planning & Scope** | 128d | 2024-04-04 A | 2024-09-30 A |  | 100% |  |
| 2075 |  | Create and Confirm SA Scope | 9d | 2024-06-03 A | 2024-06-13 A |  | 100% | finish no earlier than 2024-06-13 |
| 2076 |  | POAP Service Activation | 13d | 2024-06-03 A | 2024-06-19 A |  | 100% | finish no earlier than 2024-06-19 |
| 2077 |  | Service Activation Working Group | 62d | 2024-04-04 A | 2024-06-28 A |  | 100% | finish no earlier than 2024-06-28 |
| 2078 |  | Business Readiness Governance Framework | 42d | 2024-08-02 A | 2024-09-30 A |  | 100% | finish no earlier than 2024-09-30 |
| 2079 |  | Service Activation Governance Framework Completed | 0d | 2024-09-30 A | 2024-09-30 A | 2075, 2076, 2077, 2078 | 100% | finish no earlier than 2024-06-28 |
| 2080 | 1.6.3.6.1.2 | **Service Activation High Level Process Models** | 109d | 2024-04-02 A | 2024-08-31 A |  | 100% |  |
| 2081 |  | Transition Process Model | 70d | 2024-04-02 A | 2024-07-08 A |  | 100% | finish no earlier than 2024-07-08 |
| 2082 |  | Migration Process Model | 14d | 2024-08-13 A | 2024-08-30 A |  | 100% | finish no earlier than 2024-08-31 |
| 2083 |  | Enduring Process Model | 44d | 2024-06-03 A | 2024-08-01 A |  | 100% | start no earlier than 2024-06-01 |
| 2084 |  | Service Activation High Level Process Models Completed | 0d | 2024-08-31 A | 2024-08-31 A | 2081, 2082, 2083 | 100% | start no earlier than 2024-08-31 |
| 2085 | 1.6.3.6.1.3 | **Target Operating Model for Service Activation** | 83d | 2024-06-21 A | 2024-10-15 A |  | 100% |  |
| 2086 |  | MHHSP Engagement Team understanding | 25d | 2024-06-21 A | 2024-07-25 A |  | 100% | finish no earlier than 2024-07-25 |
| 2087 |  | Define and produce organisation model for Service Activation in Elexon | 83d | 2024-06-21 A | 2024-10-15 A |  | 100% | finish no earlier than 2024-10-15 |
| 2088 |  | Implement Target Operating model | 1d | 2024-10-15 A | 2024-10-15 A |  | 100% | start no earlier than 2024-10-15 |
| 2089 |  | Target Operating Model for Service Activation Completed | 0d | 2024-10-15 A | 2024-10-15 A | 2086, 2087, 2088 | 100% | start no earlier than 2024-10-15 |
| 2090 | 1.6.3.6.1.4 | **SIT Operational Testing for Service Activation** | 5d? | 2024-08-12 A | 2024-08-16 A |  | 100% |  |
| 2091 |  | Review and validate test cases | 5d | 2024-08-12 A | 2024-08-16 A |  | 100% | finish no earlier than 2024-08-16 |
| 2092 |  | SIT Operational Testing for Service Activation Completed | 1d? | 2024-08-16 A | 2024-08-16 A |  | 100% | start no earlier than 2024-08-16 |
| 2093 | 1.6.3.6.1.5 | **Operational Training for Service Activation** | 73d | 2025-05-15 A | 2025-08-25 A |  | 100% |  |
| 2094 |  | Training Execution [Placeholder] | 73d | 2025-05-15 A | 2025-08-25 A |  | 100% | start no earlier than 2024-11-13 |
| 2095 |  | Service Activation Training Completed | 0d | 2025-08-25 A | 2025-08-25 A | 2094 | 100% | start no earlier than 2025-07-25 |
| 2096 | 1.6.3.6.1.6 | **Service Activation Readiness** | 7d | 2025-08-04 A | 2025-08-12 A |  | 100% |  |
| 2097 |  | Dress Rehearsal 1 | 2d | 2025-08-04 A | 2025-08-05 A | 2079, 2084, 2089 | 100% | start no earlier than 2025-08-04 |
| 2098 |  | Dress Rehearsal 1 Complete | 0d | 2025-08-05 A | 2025-08-05 A | 2097 | 100% | start no earlier than 2025-01-22 |
| 2099 |  | Dress Rehearsal 2 | 2d | 2025-08-11 A | 2025-08-12 A | 2098FS+3d | 100% | start no earlier than 2025-08-04 |
| 2100 |  | Dress Rehearsal 2 Complete | 0d | 2025-08-12 A | 2025-08-12 A | 2099 | 100% | start no earlier than 2025-01-22 |

| ID | WBS | Task | Duration | Start | Finish | Predecessors | Complete | Constraint |
| --- | --- | --- | --- | --- | --- | --- | --- | --- |
| 2101 | 1.6.3.6.1.7 | **Service Activation Go / No Go** | 1d | 2025-08-22 A | 2025-08-22 A |  | 100% |  |
| 2102 | 1.6.3.6.1.7.1 | **Final Service Activation Go/No Go Decision** | 1d | 2025-08-22 A | 2025-08-22 A |  | 100% |  |
| 2103 |  | DIP Team Ready | 1d | 2025-08-22 A | 2025-08-22 A | 2100FS+7d, 2098 | 100% |  |
| 2104 |  | DIP Technical Onboarding Processes Completed | 0d | 2025-08-22 A | 2025-08-22 A |  | 100% | start no earlier than 2025-08-22 |
| 2105 |  | PM Team Ready | 0d | 2025-08-22 A | 2025-08-22 A | 2098, 2100 | 100% | start no earlier than 2025-08-22 |
| 2106 |  | Operational Support Ready (Ops Control Centre, Account Managers) | 0d | 2025-08-22 A | 2025-08-22 A |  | 100% | start no earlier than 2025-08-22 |
| 2107 |  | Service Management Activity Completed (Resolver Groups) | 0d | 2025-08-22 A | 2025-08-22 A |  | 100% | start no earlier than 2025-08-22 |
| 2108 |  | Process 1.1.1 ISD and Related LWIs Completed | 0d | 2025-08-22 A | 2025-08-22 A | 2107 | 100% |  |
| 2109 | 1.6.3.6.1.8 | **SOLR Consultation** | 107d? | 2025-04-10 A | 2025-09-05 A | 2127 | 100% |  |
| 2110 |  | SOLR workshop 1 | 1d | 2025-04-10 A | 2025-04-10 A | 2127SF | 100% | start no earlier than 2025-04-10 |
| 2111 |  | SOLR workshop 2 | 1d | 2025-04-29 A | 2025-04-29 A | 2127SF | 100% | start no earlier than 2025-04-29 |
| 2112 | 1.6.3.6.1.8.3 | **SOLR consultation** | 81d? | 2025-04-10 A | 2025-07-31 |  | 100% |  |
| 2113 |  | SOLR consultation | 81d? | 2025-04-10 A | 2025-07-31 A |  | 100% | start no earlier than 2025-04-10 |
| 2114 |  | LDSO Workshop | 0d | 2025-06-30 A | 2025-06-30 A |  | 100% | start no earlier than 2025-06-30 |
| 2115 |  | GLIG | 0d | 2025-07-04 A | 2025-07-04 A |  | 100% | start no earlier than 2025-07-04 |
| 2116 |  | QWG | 0d | 2025-07-08 A | 2025-07-08 A |  | 100% | start no earlier than 2025-07-08 |
| 2117 |  | GLIG (Second presentation) | 0d | 2025-07-18 A | 2025-07-18 A |  | 100% | start no earlier than 2025-07-18 |
| 2118 |  | Process Refinement | 33d | 2025-06-17 A | 2025-07-31 A |  | 100% | start no earlier than 2025-06-17 |
| 2119 |  | Process Test | 26d | 2025-08-01 A | 2025-09-05 A | 2118 | 100% |  |
| 2120 |  | SOLR comms to MHHS for review | 1d | 2025-08-27 A | 2025-08-27 A |  | 100% | finish no earlier than 2025-08-26 |
| 2121 | 1.6.3.6.1.9 | **MDR Process** | 77d | 2025-04-16 A | 2025-07-31 A |  | 100% |  |
| 2122 |  | MDR workshop 1 | 1d | 2025-04-16 A | 2025-04-16 A |  | 100% | start no earlier than 2025-04-16 |
| 2123 |  | MDR workshop 2 | 1d | 2025-04-30 A | 2025-04-30 A |  | 100% | start no earlier than 2025-04-30 |
| 2124 |  | MDR workshop | 1d | 2025-05-27 A | 2025-05-27 A |  | 100% | start no earlier than 2025-05-27 |
| 2125 |  | MDR consultation | 12d | 2025-05-06 A | 2025-05-21 A |  | 100% | start no earlier than 2025-05-06 |
| 2126 |  | MDR consultation ongoing actions | 62d | 2025-05-07 A | 2025-07-31 A |  | 100% | start no earlier than 2025-05-07 |
| 2127 |  | Service Activation Go / No Go | 0d | 2025-08-22 A | 2025-08-22 A | 2104, 2105, 2106FF, 2107FF, 2043FF, 2108 | 100% |  |
| 2128 | 1.6.3.6.2 | **Phase 2 - Implementation** | 418d? | 2024-06-07 A | 2026-01-13 A |  | 100% |  |
| 2129 | 1.6.3.6.2.1 | **Non-SIT LDSO & SIT MVC Data Loading (M10 Ready)** | 6d | 2024-06-07 A | 2024-06-14 A |  | 100% |  |
| 2130 |  | Define Non-SIT LDSO Upfront Activities | 6d | 2024-06-07 A | 2024-06-14 A |  | 100% | finish no earlier than 2024-06-15 |
| 2131 | 1.6.3.6.2.2 | **M10-Ready Activation Preparation Tasks** | 15d? | 2025-08-25 A | 2025-09-12 A | 2130 | 100% |  |
| 2132 |  | Identify Resources | 1d | 2025-08-25 A | 2025-08-25 A |  | 100% | start no earlier than 2025-08-25 |
| 2133 |  | Confirmation from Qualification of Wave Participants Complete | 0d | 2025-08-25 A | 2025-08-25 A |  | 100% | start no earlier than 2025-08-25 |
| 2134 |  | Agree & Understand Support Model | 1d | 2025-08-26 A | 2025-08-26 A |  | 100% | start no earlier than 2025-08-26 |
| 2135 |  | Confirm Training complete | 0d | 2025-08-27 A | 2025-08-27 A |  | 100% | start no earlier than 2025-08-27 |
| 2136 |  | Confirm IDNOs global sign completed prior to M10 | 7d | 2025-08-28 A | 2025-09-05 A |  | 100% | finish no earlier than 2025-09-05 |
| 2137 |  | Engagement / Communications with Participants | 9d | 2025-08-29 A | 2025-09-10 A |  | 100% | finish no earlier than 2025-09-10 |
| 2138 | 1.6.3.6.2.2.7 | **Internal Communications** | 1d | 2025-09-01 A | 2025-09-01 A |  | 100% |  |
| 2139 |  | Agree Content for Livewire | 1d | 2025-09-01 A | 2025-09-01 A |  | 100% | start no earlier than 2025-09-01 |
| 2140 |  | Publish Content for Livewire | 0d | 2025-09-01 A | 2025-09-01 A |  | 100% | start no earlier than 2025-09-01 |
| 2141 |  | Validate User Access | 1d | 2025-09-02 A | 2025-09-02 A |  | 100% | start no earlier than 2025-09-02 |
| 2142 |  | Target Systems and Environments Ready | 1d | 2025-09-03 A | 2025-09-03 A |  | 100% | start no earlier than 2025-09-03 |
| 2143 |  | Publish the guidence with Parties | 1d | 2025-09-12 A | 2025-09-12 A |  | 100% | start no earlier than 2025-09-12 |
| 2144 |  | Provide LWIs | 1d? | 2025-09-12 A | 2025-09-12 A |  | 100% | finish no earlier than 2025-09-12 |
| 2145 |  | Business Readiness Governance Approval | 1d | 2025-09-08 A | 2025-09-08 A | 2144 | 100% | start no earlier than 2025-09-05 |
| 2146 |  | M10-Ready Participants Service Activation Preparation Completed | 0d | 2025-09-08 A | 2025-09-08 A | 2132, 2134, 2135, 2136, 2138, 2141, 2142, 2145 | 100% | start no earlier than 2025-09-05 |
| 2147 | 1.6.3.6.2.3 | **M10-Ready (Inlcuding Non-SIT LDSOs) Service Activation Implementation** | 6d | 2025-09-10 A | 2025-09-19 A |  | 100% |  |
| 2148 |  | MHHSP Enabled Confirmation | 0d | 2025-09-10 A | 2025-09-10 A | 2465, 2468 | 100% | start no earlier than 2025-09-08 |
| 2149 |  | Add EFD (ISD Calendar Date) to DIP | 1d | 2025-09-11 A | 2025-09-11 A | 2141, 2142, 2145, 2148 | 100% | start no earlier than 2025-09-11 |
| 2150 |  | Non-SIT LDSO PP DIP User Promoted to Production | 1d | 2025-09-12 A | 2025-09-12 A | 2149 | 100% | start no earlier than 2025-09-12 |
| 2151 |  | Create M16 in Customer Solution Started | 0d | 2025-09-11 A | 2025-09-11 A |  | 100% | start no earlier than 2025-09-11 |
| 2152 |  | Create M16 in Customer Solution | 1d | 2025-09-11 A | 2025-09-11 A | 2151SS, 2155SS | 100% | start no earlier than 2025-09-11 |
| 2153 |  | DIP Production Success Checks | 1d | 2025-09-12 A | 2025-09-12 A | 2149, 2152 | 100% |  |
| 2154 |  | 1st ISD Publish Started | 0d | 2025-09-11 A | 2025-09-11 A |  | 100% | start no earlier than 2025-09-11 |
| 2155 |  | 1st ISD Publish (7 day window for this activity is consistent with Code requirements) | 6d | 2025-09-11 A | 2025-09-18 A | 2149SS, 2154SS | 100% | start no earlier than 2025-09-11 |
| 2156 |  | Go Live ISD | 1d | 2025-09-18 A | 2025-09-18 A |  | 100% | start no earlier than 2025-09-18 |
| 2157 |  | M10-Ready Service Activation Implementation Completed | 0d | 2025-09-19 A | 2025-09-19 A | 2148, 2149, 2150, 2152, 2155, 2156 | 100% | start no earlier than 2025-09-19 |
| 2158 | 1.6.3.6.2.4 | **M10-Ready Service Activation Implementation MDD** | 6d | 2025-09-10 A | 2025-09-18 A |  | 100% |  |
| 2159 |  | MDD Final Circular Completed | 0d | 2025-09-10 A | 2025-09-10 A | 2145 | 100% | finish no earlier than 2025-09-10 |
| 2160 |  | MDD Manual Update | 3d | 2025-09-11 A | 2025-09-15 A | 2159FF | 100% | finish no earlier than 2025-09-15 |
| 2161 |  | MDD Publish | 6d | 2025-09-11 A | 2025-09-18 A | 2160SF | 100% | finish no earlier than 2025-09-18 |
| 2162 |  | MDD Go Live | 0d | 2025-09-18 A | 2025-09-18 A | 2161 | 100% | finish no earlier than 2025-09-18 |
| 2163 |  | Non-SIT LDSO & SIT MVC Service Activation Implementation MDD Completed | 0d | 2025-09-18 A | 2025-09-18 A | 2159, 2160, 2161, 2162 | 100% | finish no earlier than 2025-09-18 |
| 2164 | 1.6.3.6.2.5 | **Non-SIT LDSO & SIT Service Activation Hypercare (M10 Ready)** | 54d | 2025-09-18 A | 2025-12-02 A |  | 100% |  |
| 2165 |  | Monitoring | 54d | 2025-09-18 A | 2025-12-02 A |  | 100% | finish no earlier than 2025-12-02 |
| 2166 |  | Reporting | 54d | 2025-09-18 A | 2025-12-02 A |  | 100% | start no earlier than 2025-09-18 |
| 2167 |  | Issue Management | 54d | 2025-09-18 A | 2025-12-02 A |  | 100% | finish no earlier than 2025-12-02 |
| 2168 |  | Closed Down Activities | 1d | 2025-09-19 A | 2025-09-19 A | 2165SS, 2166SS, 2167SS | 100% | finish no earlier than 2025-09-19 |
| 2169 |  | Inform MHHSP | 1d | 2025-09-19 A | 2025-09-19 A | 2168SS | 100% | finish no earlier than 2025-09-19 |
| 2170 | 1.6.3.6.2.6 | **M11-Ready Activation Preparation Tasks** | 3d | 2025-10-09 A | 2025-10-13 A | 2130 | 100% |  |

| ID | WBS | Task | Duration | Start | Finish | Predecessors | Complete | Constraint |
| --- | --- | --- | --- | --- | --- | --- | --- | --- |
| 2171 |  | Engagement / Communications with Participants | 1d | 2025-10-09 A | 2025-10-09 A |  | 100% | start no earlier than 2025-10-09 |
| 2172 |  | Validate User Access | 1d | 2025-10-13 A | 2025-10-13 A |  | 100% | start no earlier than 2025-10-13 |
| 2173 |  | M11-Ready Participants Service Activation Preparation Completed | 0d | 2025-10-13 A | 2025-10-13 A | 2171, 2172 | 100% | start no earlier than 2025-09-05 |
| 2174 | 1.6.3.6.2.7 | **M11-Ready Service Activation Implementation** | 19d? | 2025-09-25 A | 2025-10-22 A |  | 100% |  |
| 2175 | 1.6.3.6.2.7.1 | **Pathway 4 PPs** | 6d? | 2025-09-25 A | 2025-10-03 A |  | 100% |  |
| 2176 |  | MHHSP Enabled Confirmation | 0d | 2025-09-25 A | 2025-09-25 A | 2476 | 100% | start no earlier than 2025-09-25 |
| 2177 |  | Add EFD (ISD Calendar Date) to DIP | 0d | 2025-09-25 A | 2025-09-25 A | 2176 | 100% |  |
| 2178 |  | Create M16 in Customer Solution | 0d | 2025-09-25 A | 2025-09-25 A | 2176 | 100% |  |
| 2179 |  | DIP Production Success Checks | 1d? | 2025-09-26 A | 2025-09-26 A | 2177, 2178 | 100% |  |
| 2180 |  | Publish ISD | 6d | 2025-09-26 A | 2025-10-03 A | 2176 | 100% | start no earlier than 2025-09-26 |
| 2181 |  | Go Live ISD | 0d | 2025-10-03 A | 2025-10-03 A | 2180 | 100% |  |
| 2182 |  | Pathway 4 Service Activation Implementation Completed | 0d | 2025-10-03 A | 2025-10-03 A | 2177, 2178, 2181 | 100% | start no earlier than 2025-09-19 |
| 2183 | 1.6.3.6.2.7.2 | **Pathway 5 PPs** | 5d? | 2025-10-15 A | 2025-10-22 A |  | 100% |  |
| 2184 |  | MHHSP Enabled Confirmation | 0d | 2025-10-15 A | 2025-10-15 A | 2479 | 100% | start no earlier than 2025-09-08 |
| 2185 |  | Add EFD (ISD Calendar Date) to DIP | 0d | 2025-10-15 A | 2025-10-15 A | 2184 | 100% | start no earlier than 2025-10-15 |
| 2186 |  | Create M16 in Customer Solution | 0d | 2025-10-16 A | 2025-10-16 A | 2184 | 100% | start no earlier than 2025-10-16 |
| 2187 |  | DIP Production Success Checks | 1d? | 2025-10-16 A | 2025-10-16 A | 2185, 2186 | 100% |  |
| 2188 |  | Publish ISD | 5d | 2025-10-16 A | 2025-10-22 A | 2184 | 100% | start no earlier than 2025-10-15 |
| 2189 |  | Go Live ISD | 0d | 2025-10-22 A | 2025-10-22 A | 2188 | 100% | start no earlier than 2025-10-17 |
| 2190 |  | Publish MDD | 5d | 2025-10-16 A | 2025-10-22 A | 2184 | 100% |  |
| 2191 |  | MDD Go Live | 0d | 2025-10-22 A | 2025-10-22 A | 2190 | 100% |  |
| 2192 |  | Pathway 5 Service Activation Implementation Completed | 0d | 2025-10-22 A | 2025-10-22 A | 2184, 2185, 2186, 2189 | 100% | start no earlier than 2025-09-19 |
| 2193 | 1.6.3.6.2.8 | **M11-Ready Service Activation Hypercare** | 16d | 2025-10-15 A | 2025-11-05 A |  | 100% |  |
| 2194 |  | Monitoring | 11d | 2025-10-15 A | 2025-10-29 A |  | 100% | start no earlier than 2025-10-15 |
| 2195 |  | Reporting | 11d | 2025-10-15 A | 2025-10-29 A |  | 100% | start no earlier than 2025-10-15 |
| 2196 |  | Issue Management | 11d | 2025-10-15 A | 2025-10-29 A |  | 100% | start no earlier than 2025-10-15 |
| 2197 |  | Closed Down Activities | 3d | 2025-10-30 A | 2025-11-03 A | 2196 | 100% | finish no earlier than 2025-09-19 |
| 2198 |  | Inform MHHSP | 2d | 2025-11-04 A | 2025-11-05 A | 2197 | 100% | finish no earlier than 2025-09-19 |
| 2199 |  | M11-Ready Service Activation Hypercare Completed | 0d | 2025-11-05 A | 2025-11-05 A | 2198 | 100% |  |
| 2200 | 1.6.3.6.2.9 | **Not M11-Ready Service Activation Preparation Tasks** | 4d | 2025-10-13 A | 2025-10-16 A | 2130 | 100% |  |
| 2201 |  | Engagement / Communications with Participants | 1d | 2025-10-16 A | 2025-10-16 A |  | 100% | start no earlier than 2025-10-16 |
| 2202 |  | Validate User Access | 1d | 2025-10-13 A | 2025-10-13 A |  | 100% | start no earlier than 2025-10-13 |
| 2203 | 1.6.3.6.2.10 | **Not M11-Ready Service Activation Implementation** | 53d | 2025-10-30 A | 2026-01-13 A |  | 100% |  |
| 2204 | 1.6.3.6.2.10.1 | **First Pathway 6 PAB** | 16d | 2025-10-30 A | 2025-11-21 A |  | 100% |  |
| 2205 |  | MHHSP Enabled Confirmation | 0d | 2025-10-30 A | 2025-10-30 A | 2487 | 100% | start no earlier than 2025-09-08 |
| 2206 |  | Add EFD (ISD Calendar Date) to DIP | 0d | 2025-10-30 A | 2025-10-30 A | 2205 | 100% | start no earlier than 2025-09-11 |
| 2207 |  | Create M16 in Customer Solution | 0d | 2025-10-31 A | 2025-10-31 A | 2205FS+1d | 100% | finish no earlier than 2025-10-31 |
| 2208 |  | DIP Production Success Checks | 0d | 2025-10-31 A | 2025-10-31 A | 2207 | 100% | finish no earlier than 2025-10-31 |
| 2209 |  | Publish ISD | 6d | 2025-11-14 A | 2025-11-21 A |  | 100% | start no earlier than 2025-11-14 |
| 2210 |  | Go Live ISD | 0d | 2025-11-21 A | 2025-11-21 A | 2209 | 100% | start no earlier than 2025-09-18 |
| 2211 |  | Publish MDD | 6d | 2025-11-14 A | 2025-11-21 A |  | 100% | start no earlier than 2025-11-14 |
| 2212 |  | MDD Go Live | 0d | 2025-11-21 A | 2025-11-21 A | 2211 | 100% |  |
| 2213 |  | Service Activation Implementation Completed | 0d | 2025-11-21 A | 2025-11-21 A | 2210, 2212 | 100% |  |
| 2214 | 1.6.3.6.2.10.2 | **Final Pathway 6 PAB** | 19d | 2025-12-18 A | 2026-01-13 A |  | 100% |  |
| 2215 |  | MHHSP Enabled Confirmation | 0d | 2025-12-18 A | 2025-12-18 A | 2489 | 100% | start no earlier than 2025-12-18 |
| 2216 |  | Add EFD (ISD Calendar Date) to DIP | 0d | 2025-12-18 A | 2025-12-18 A | 2215 | 100% | start no earlier than 2025-09-11 |
| 2217 |  | Create M16 in Customer Solution | 0d | 2025-12-18 A | 2025-12-18 A | 2215FS+1d | 100% | start no earlier than 2025-12-17 |
| 2218 |  | DIP Production Success Checks | 0d | 2025-12-18 A | 2025-12-18 A | 2216, 2217 | 100% |  |
| 2219 |  | Publish ISD | 7d | 2026-01-05 A | 2026-01-13 A | 2215FS+12d | 100% |  |
| 2220 |  | Go Live ISD | 0d | 2026-01-13 A | 2026-01-13 A | 2219 | 100% | start no earlier than 2025-09-18 |
| 2221 |  | Publish MDD | 7d | 2025-12-22 A | 2025-12-30 A | 2215FS+2d | 100% |  |
| 2222 |  | MDD Go Live | 0d | 2025-12-30 A | 2025-12-30 A | 2221 | 100% |  |
| 2223 |  | Service Activation Implementation Completed | 0d | 2026-01-13 A | 2026-01-13 A | 2220, 2222 | 100% |  |
| 2224 | 1.6.3.6.2.11 | **Not M11-Ready Service Activation Hypercare** | 11d | 2025-12-17 A | 2025-12-31 A |  | 100% |  |
| 2225 |  | Monitoring | 11d | 2025-12-17 A | 2025-12-31 A |  | 100% | start no earlier than 2025-12-17 |
| 2226 |  | Reporting | 11d | 2025-12-17 A | 2025-12-31 A |  | 100% | start no earlier than 2025-12-17 |
| 2227 |  | Issue Management | 11d | 2025-12-17 A | 2025-12-31 A |  | 100% | start no earlier than 2025-12-17 |
| 2228 |  | Closed Down Activities | 3d | 2025-12-29 A | 2025-12-31 A | 2225SS, 2226SS, 2227SS | 100% | start no earlier than 2025-12-29 |
| 2229 |  | Inform MHHSP | 2d | 2025-12-30 A | 2025-12-31 A | 2228SS | 100% | start no earlier than 2025-12-30 |
| 2230 |  | Not M11-Ready Service Activation Hypercare Completed | 0d | 2025-12-31 A | 2025-12-31 A | 2229 | 100% |  |
| 2231 | 1.6.4 | **Helix Solution Build** | 284d? | 2024-08-19 A | 2025-09-18 A |  | 100% |  |
| 2232 |  | M10 Build Candidate | 80d | 2025-04-28 A | 2025-08-15 A |  | 100% | start no earlier than 2025-04-28 |
| 2233 |  | Helix Code Uplifts | 24d | 2025-08-18 A | 2025-09-18 A | 2232 | 100% | start no earlier than 2025-07-09 |
| 2234 | 1.6.4.3 | **Helix E2E Settlement Assurance Testing (SAT)** | 260d? | 2024-08-19 A | 2025-08-15 A |  | 100% |  |
| 2235 | 1.6.4.3.1 | **Test design** | 125d | 2024-09-02 A | 2025-02-21 A |  | 100% |  |
| 2236 |  | SAT tests (Review and finalise) | 95d | 2024-09-02 A | 2025-01-10 A |  | 100% | start no earlier than 2024-09-02 |
| 2237 |  | Test Automation and Supporting Tools | 80d | 2024-11-04 A | 2025-02-21 A |  | 100% | start no earlier than 2024-11-04 |
| 2238 |  | SAT tests batch 3 | 50d | 2024-12-16 A | 2025-02-21 A |  | 100% | start no earlier than 2024-12-16 |
| 2239 | 1.6.4.3.2 | **Data and environment** | 120d? | 2024-08-19 A | 2025-01-31 A |  | 100% |  |
| 2240 |  | Data and environment requirements | 55d | 2024-08-19 A | 2024-11-01 A |  | 100% | start no earlier than 2024-08-19 |

| ID | WBS | Task | Duration | Start | Finish | Predecessors | Complete | Total float | Constraint |
| --- | --- | --- | --- | --- | --- | --- | --- | --- | --- |
| 2241 |  | Data sourcing | 95d | 2024-09-02 A | 2025-01-10 A |  | 100% |  | start no earlier than 2024-09-02 |
| 2242 |  | Environment data check | 15d? | 2025-01-13 A | 2025-01-31 A | 2241 | 100% |  |  |
| 2243 | 1.6.4.3.3 | **Execution** | 200d | 2024-11-11 A | 2025-08-15 A |  | 100% |  |  |
| 2244 |  | Trial test runs | 50d | 2024-11-11 A | 2025-01-17 A |  | 100% |  | start no earlier than 2024-11-11 |
| 2245 |  | Test planning prioritisation | 14d | 2025-01-20 A | 2025-02-06 A | 2244 | 100% |  |  |
| 2246 |  | Programme agreement to start SAT testing | 0d | 2025-02-06 A | 2025-02-06 A | 2245 | 100% |  |  |
| 2247 |  | SAT Testing Start | 0d | 2025-02-06 A | 2025-02-06 A | 2246 | 100% |  |  |
| 2248 | 1.6.4.3.3.5 | **SAT Cycle 1** | 114d | 2025-02-07 A | 2025-07-16 A | 2247 | 100% |  |  |
| 2249 | 1.6.4.3.3.5.1 | **Legacy** | 99d | 2025-02-07 A | 2025-06-25 A |  | 100% |  |  |
| 2250 |  | GMT | 89d | 2025-02-07 A | 2025-06-11 A |  | 100% |  |  |
| 2251 |  | P0210 file shared for NESO Validation | 0d | 2025-05-23 A | 2025-05-23 A |  | 100% |  | start no earlier than 2025-05-23 |
| 2252 |  | NESO Validation Period (GMT) | 5d | 2025-05-28 A | 2025-06-03 A | 2251 | 100% |  | start no earlier than 2025-05-28 |
| 2253 |  | Long | 13d | 2025-05-28 A | 2025-06-13 A |  | 100% |  | start no earlier than 2025-05-28 |
| 2254 |  | Helix SAT Confidence Check 1 | 0d | 2025-06-10 A | 2025-06-10 A |  | 100% |  | finish no earlier than 2025-06-10 |
| 2255 |  | P0210 file shared for NESO Validation | 0d | 2025-06-13 A | 2025-06-13 A | 2253 | 100% |  | start no earlier than 2025-06-13 |
| 2256 |  | Helix SAT Confidence Check 2 | 0d | 2025-06-13 A | 2025-06-13 A |  | 100% |  | finish no earlier than 2025-06-13 |
| 2257 |  | NESO Validation Period (Long) | 5d | 2025-06-16 A | 2025-06-20 A | 2255 | 100% |  | start no earlier than 2025-06-16 |
| 2258 |  | BST | 13d | 2025-06-02 A | 2025-06-18 A |  | 100% |  | start no earlier than 2025-06-02 |
| 2259 |  | P0210 file shared for NESO Validation | 0d | 2025-06-18 A | 2025-06-18 A | 2258 | 100% |  |  |
| 2260 |  | NESO Validation Period (BST) | 5d | 2025-06-19 A | 2025-06-25 A |  | 100% |  | start no earlier than 2025-06-19 |
| 2261 |  | Trading Dispute | 3d | 2025-06-18 A | 2025-06-20 A |  | 100% |  | start no earlier than 2025-06-18 |
| 2262 | 1.6.4.3.3.5.2 | **Transition** | 36d | 2025-05-28 A | 2025-07-16 A |  | 100% |  |  |
| 2263 |  | GMT | 19d | 2025-05-28 A | 2025-06-23 A |  | 100% |  | start no earlier than 2025-05-28 |
| 2264 |  | P0210 file shared for NESO Validation | 0d | 2025-06-13 A | 2025-06-13 A |  | 100% |  | finish no earlier than 2025-06-13 |
| 2265 |  | NESO Validation Period (GMT) | 5d | 2025-06-17 A | 2025-06-23 A | 2264 | 100% |  | finish no earlier than 2025-06-23 |
| 2266 |  | Long | 4d | 2025-06-24 A | 2025-06-27 A |  | 100% |  | start no earlier than 2025-06-24 |
| 2267 |  | P0210 file shared for NESO Validation | 0d | 2025-06-27 A | 2025-06-27 A | 2266 | 100% |  |  |
| 2268 |  | NESO Validation Period (Long) | 5d | 2025-06-30 A | 2025-07-04 A | 2267 | 100% |  | start no earlier than 2025-06-30 |
| 2269 |  | BST | 4d | 2025-06-26 A | 2025-07-01 A |  | 100% |  | start no earlier than 2025-06-26 |
| 2270 |  | P0210 file shared for NESO Validation | 0d | 2025-07-01 A | 2025-07-01 A | 2269 | 100% |  |  |
| 2271 |  | NESO Validation Period (BST) | 5d | 2025-07-03 A | 2025-07-09 A | 2270 | 100% |  | finish no earlier than 2025-07-09 |
| 2272 |  | Short | 7d | 2025-07-01 A | 2025-07-09 A |  | 100% |  | start no earlier than 2025-07-01 |
| 2273 |  | P0210 file shared for NESO Validation | 0d | 2025-07-03 A | 2025-07-03 A | 2272 | 100% |  |  |
| 2274 |  | NESO Validation Period (Short) | 5d | 2025-07-08 A | 2025-07-14 A | 2273 | 100% |  | start no earlier than 2025-07-08 |
| 2275 |  | DCP MPAN Mig | 3d | 2025-07-01 A | 2025-07-03 A |  | 100% |  | start no earlier than 2025-07-01 |
| 2276 |  | ISD | 3d | 2025-07-01 A | 2025-07-03 A |  | 100% |  | start no earlier than 2025-07-01 |
| 2277 |  | Data Agg | 6d | 2025-07-04 A | 2025-07-11 A |  | 100% |  | start no earlier than 2025-07-04 |
| 2278 |  | M16 | 3d | 2025-07-14 A | 2025-07-16 A |  | 100% |  | start no earlier than 2025-07-14 |
| 2279 |  | End of Cycle 1 | 0d | 2025-07-16 A | 2025-07-16 A |  | 100% |  | start no earlier than 2025-07-16 |
| 2280 | 1.6.4.3.3.6 | **SAT Cycle 2** | 12d | 2025-07-17 A | 2025-08-01 A |  | 100% |  |  |
| 2281 | 1.6.4.3.3.6.1 | **Legacy** | 12d | 2025-07-17 A | 2025-08-01 A |  | 100% |  |  |
| 2282 |  | Pre-M10 | 1d | 2025-07-17 A | 2025-07-17 A |  | 100% |  | start no earlier than 2025-07-17 |
| 2283 |  | GMT & BST & Long | 6d | 2025-07-18 A | 2025-07-25 A |  | 100% |  | start no earlier than 2025-07-18 |
| 2284 |  | NESO Validation Period (GMT & BST & Long) | 5d | 2025-07-28 A | 2025-08-01 A | 2283 | 100% |  |  |
| 2285 |  | Trading Dispute | 2d | 2025-07-28 A | 2025-07-29 A |  | 100% |  | start no earlier than 2025-07-28 |
| 2286 | 1.6.4.3.3.6.2 | **Transition** | 4d | 2025-07-24 A | 2025-07-29 A |  | 100% |  |  |
| 2287 |  | ISD | 4d | 2025-07-24 A | 2025-07-29 A |  | 100% |  | start no earlier than 2025-07-24 |
| 2288 |  | Data Agg | 3d | 2025-07-24 A | 2025-07-28 A |  | 100% |  | start no earlier than 2025-07-24 |
| 2289 |  | End of Cycle 2 | 0d | 2025-08-01 A | 2025-08-01 A |  | 100% |  | start no earlier than 2025-08-01 |
| 2290 |  | SAT Exit Report | 11d | 2025-08-01 A | 2025-08-15 A | 2289 | 100% |  |  |
| 2291 |  | SAT Complete | 0d | 2025-08-01 A | 2025-08-01 A |  | 100% |  | start no earlier than 2025-08-01 |
| 2292 |  | DR Testing | 90d | 2025-04-28 A | 2025-08-29 A |  | 100% |  | start no earlier than 2025-04-28 |
| 2293 |  | Pen Testing | 40d? | 2025-04-28 A | 2025-06-20 A |  | 100% |  | start no earlier than 2025-04-28 |
| 2294 |  | Production Environment Build | 35d | 2025-06-30 A | 2025-08-15 A |  | 100% |  | finish no earlier than 2025-07-31 |
| 2295 |  | Production Environment Base Platform Sign-off | 0d | 2025-08-15 A | 2025-08-15 A | 2294FF | 100% |  | finish no earlier than 2025-08-08 |
| 2296 | 1.6.5 | **Implementation (Helix & DIP)** | 116d | 2025-04-28 A | 2025-10-06 A |  | 100% |  |  |
| 2297 |  | Go / No-Go (DIP & SM) | 0d | 2025-07-31 A | 2025-07-31 A | 2030, 2047, 2048, 2049 | 100% |  | start no earlier than 2025-07-31 |
| 2298 |  | Implementation Readiness (inc Technical Readiness, Approach and Runbook, Walkthrough / Rehearsals | 71d | 2025-04-28 A | 2025-08-04 A |  | 100% |  | start no earlier than 2025-04-28 |
| 2299 |  | M10 Implementation Approach & Go-Live Runbook | 46d | 2025-04-28 A | 2025-06-30 A |  | 100% |  | start no earlier than 2025-04-28 |
| 2300 |  | DIP Production Build | 15d | 2025-06-09 A | 2025-06-27 A |  | 100% |  | start no earlier than 2025-06-09 |
| 2301 |  | Final Production Deployment | 30d | 2025-07-07 A | 2025-08-15 A |  | 100% |  | start no earlier than 2025-07-07 |
| 2302 |  | DIP Portal Available | 0d | 2025-08-04 A | 2025-08-04 A | 2301 | 100% |  | finish no earlier than 2025-08-04 |
| 2303 |  | Go / No-Go (Helix Central Systems) | 0d | 2025-08-12 A | 2025-08-12 A | 2291, 2295, 1568 | 100% |  | start no earlier than 2025-08-12 |
| 2304 |  | ISD Data Migration | 10d | 2025-08-18 A | 2025-08-29 A | 2303, 2290 | 100% |  |  |
| 2305 |  | DAH & ISD Dark Mode | 0d | 2025-09-01 A | 2025-09-01 A | 2304 | 100% |  | start no earlier than 2025-09-01 |
| 2306 |  | VAS Inspection pre-prod | 16d | 2025-08-27 A | 2025-09-17 A |  | 100% |  | start no earlier than 2025-08-27 |
| 2307 |  | M10 Cutover Weekend (20/09 and 21/09) | 2d | 2025-09-19 A | 2025-09-22 A | 2306 | 100% |  | start no earlier than 2025-09-19 |
| 2308 |  | Post Implementation Review | 1d | 2025-10-06 A | 2025-10-06 A | 2307FS+9d | 100% |  | start no earlier than 2025-10-06 |
| 2309 | 1.7 | **ELEXON / HELIX M10 - M16** | 331d | 2025-09-03 A | 2026-12-09 |  | 84% | 31844d |  |
| 2310 | 1.7.1 | **Solution Build Sprints** | 150d | 2025-09-03 A | 2026-03-31 |  | 75% | 32025d |  |

| ID | WBS | Task | Duration | Start | Finish | Predecessors | Complete | Total float | Constraint |
| --- | --- | --- | --- | --- | --- | --- | --- | --- | --- |
| 2311 |  | 25.18 | 10d | 2025-09-03 A | 2025-09-16 A |  | 100% |  | finish no earlier than 2025-09-16 |
| 2312 |  | 25.19 | 10d | 2025-09-17 A | 2025-09-30 A |  | 100% |  |  |
| 2313 |  | 25.20 | 10d | 2025-10-01 A | 2025-10-14 A | 2312 | 100% |  |  |
| 2314 |  | 25.21 | 10d | 2025-10-15 A | 2025-10-28 A | 2313 | 100% |  |  |
| 2315 |  | 25.22 | 10d | 2025-10-29 A | 2025-11-11 A | 2314 | 100% |  |  |
| 2316 |  | 25.23 | 10d | 2025-11-12 A | 2025-11-25 A | 2315 | 100% |  |  |
| 2317 |  | 25.24 | 18d | 2025-11-26 A | 2025-12-19 A | 2316 | 100% |  |  |
| 2318 |  | 26.1 | 10d | 2026-01-07 A | 2026-01-20 A | 2317FS+12d | 100% |  |  |
| 2319 |  | 26.2 | 10d | 2026-01-21 A | 2026-02-03 A | 2318 | 100% |  |  |
| 2320 |  | 26.3 | 10d | 2026-02-04 A | 2026-02-17 | 2319 | 60% | 32025d |  |
| 2321 |  | 26.4 | 10d | 2026-02-18 | 2026-03-03 | 2320 |  | 32025d |  |
| 2322 |  | 26.5 | 10d | 2026-03-04 | 2026-03-17 | 2321 |  | 32025d |  |
| 2323 |  | 26.6 | 10d | 2026-03-18 | 2026-03-31 | 2322 |  | 32025d |  |
| 2324 | 1.7.2 | **Release management deployment schedule** | 321d | 2025-09-17 A | 2026-12-09 |  | 87% | 31844d |  |
| 2325 |  | 25.14.5 | 1d | 2025-10-20 A | 2025-10-20 A |  | 100% |  |  |
| 2326 |  | 25.14.6 | 1d | 2025-11-04 A | 2025-11-04 A |  | 100% |  |  |
| 2327 |  | 25.14.7 | 1d | 2025-11-19 A | 2025-11-19 A |  | 100% |  |  |
| 2328 |  | 25.14.8 | 1d | 2025-12-03 A | 2025-12-03 A |  | 100% |  | finish no earlier than 2025-12-03 |
| 2329 |  | 25.14.9 | 1d | 2025-12-11 A | 2025-12-11 A |  | 100% |  | start no earlier than 2025-12-11 |
| 2330 |  | 26.1.0 | 1d | 2026-01-28 A | 2026-01-28 A |  | 100% |  | finish no earlier than 2026-01-28 |
| 2331 |  | 26.2.0 | 1d | 2026-02-05 A | 2026-02-05 A |  | 100% |  | start no earlier than 2026-02-05 |
| 2332 |  | 26.3.0 | 1d | 2026-02-19 | 2026-02-19 |  |  | 32053d | start no earlier than 2026-02-19 |
| 2333 |  | 26.4.0 | 1d | 2026-03-05 | 2026-03-05 |  |  | 32043d | start no earlier than 2026-03-05 |
| 2334 |  | 26.5.0 | 1d | 2026-03-19 | 2026-03-19 |  |  | 32033d | start no earlier than 2026-03-19 |
| 2335 | 1.7.2.11 | **Work Package Development** | 321d | 2025-09-17 A | 2026-12-09 |  | 87% | 31844d |  |
| 2336 | 1.7.2.11.1 | **DAH** | 140d | 2025-09-17 A | 2026-03-31 |  | 85% | 32025d |  |
| 2337 |  | MSID Counts and Missing DA files (Bronze to Silver) | 10d | 2025-09-17 A | 2025-09-30 A |  | 100% |  |  |
| 2338 |  | P0276 & P0277 Reports | 10d | 2025-10-01 A | 2025-10-14 A |  | 100% |  |  |
| 2339 |  | Throughput monitoring for DIP ingestion | 30d | 2025-09-17 A | 2025-10-28 A |  | 100% |  |  |
| 2340 |  | P0213 Report | 10d | 2025-10-29 A | 2025-11-11 A |  | 100% |  |  |
| 2341 |  | P0214 Report | 10d | 2025-10-29 A | 2025-11-11 A |  | 100% |  |  |
| 2342 |  | P0275 Report | 10d | 2025-10-29 A | 2025-11-11 A |  | 100% |  |  |
| 2343 |  | Errors & warnings in new DAH table | 20d | 2025-10-15 A | 2025-11-11 A |  | 100% |  |  |
| 2344 |  | Electralink | 60d | 2025-11-12 A | 2026-02-03 A |  | 100% |  |  |
| 2345 |  | CP1607 IF-51 Data Refresh (CR044) | 120d | 2025-10-15 A | 2026-03-31 A |  | 100% |  |  |
| 2346 |  | CP1606 Supplier Start Date Correction Tools (CR045) | 90d | 2025-11-26 A | 2026-03-31 A |  | 100% |  | start no earlier than 2025-11-26 |
| 2347 |  | MDS Annual Consumption | 10d | 2026-01-07 A | 2026-01-20 A | 2317FS+12d | 100% |  |  |
| 2348 |  | Missing Parms report | 30d | 2026-01-07 A | 2026-02-17 A | 2317FS+12d | 100% |  |  |
| 2349 |  | Trading Disputes | 20d | 2026-01-21 A | 2026-02-17 | 2318 | 70% | 32055d |  |
| 2350 |  | Business Validations | 10d | 2026-01-21 A | 2026-02-03 A | 2318 | 100% |  |  |
| 2351 |  | Merge IF51 into main | 10d | 2026-01-07 A | 2026-01-20 A | 2317FS+12d | 100% |  |  |
| 2352 |  | Upload 350K MPANs | 10d | 2026-02-04 A | 2026-02-17 A | 2319 | 100% |  |  |
| 2353 |  | Enable batching to DIP | 10d | 2026-02-04 A | 2026-02-17 | 2319 | 40% | 32055d |  |
| 2354 |  | Trading disputes test suite | 40d | 2026-02-04 A | 2026-03-31 | 2319 | 10% | 32025d |  |
| 2355 |  | Data lifecycle | 40d | 2026-02-04 A | 2026-03-31 | 2319 | 10% | 32025d |  |
| 2356 | 1.7.2.11.2 | **WP2 (LSS/MDS/VAS/OP)** | 110d | 2025-09-17 A | 2026-02-17 |  | 97% | 32055d |  |
| 2357 |  | Implementation of P0275 | 45d | 2025-10-15 A | 2025-12-16 A |  | 100% |  |  |
| 2358 |  | SCCS Technical Work | 10d | 2025-10-29 A | 2025-11-11 A |  | 100% |  |  |
| 2359 |  | SCCS Report | 10d | 2025-11-12 A | 2025-11-25 A |  | 100% |  |  |
| 2360 |  | LSS Publishing Load Shapes | 60d | 2025-10-29 A | 2026-01-20 A |  | 100% |  | start no earlier than 2025-10-29 |
| 2361 |  | Update configuration parameters into Operator Portal for LSS / VAS | 10d | 2025-09-17 A | 2025-09-30 A |  | 100% |  |  |
| 2362 |  | Operator Portal Configuration Parameters (part 1) | 20d | 2025-09-17 A | 2025-10-14 A |  | 100% |  |  |
| 2363 |  | MDS Annual Consumption | 10d | 2026-01-07 A | 2026-01-20 A | 2317FS+12d, 2347SF | 100% |  | start no earlier than 2026-01-07 |
| 2364 |  | Missing Parms report | 10d | 2026-01-22 A | 2026-02-04 A | 2317FS+12d, 2348SS+10d | 100% |  | finish no earlier than 2026-02-04 |
| 2365 |  | LSS Threshold | 10d | 2026-01-21 A | 2026-02-03 A | 2318 | 100% |  |  |
| 2366 |  | Errors and Warnings / Business Validation | 10d | 2026-01-21 A | 2026-02-03 A | 2318 | 100% |  |  |
| 2367 |  | Operator portal override functionality | 10d | 2026-02-04 A | 2026-02-17 | 2319 | 40% | 32055d |  |
| 2368 | 1.7.2.11.3 | **ISD** | 110d | 2025-10-01 A | 2026-03-03 |  | 86% | 32045d |  |
| 2369 | 1.7.2.11.3.1 | **ISD Asure** | 70d | 2025-11-12 A | 2026-02-17 |  | 86% | 32055d |  |
| 2370 |  | Validation error messages (RT and CSAD) | 70d | 2025-11-12 A | 2026-02-17 | 2315 | 91% | 32055d |  |
| 2371 |  | LLF publication and filter | 30d | 2026-01-07 A | 2026-02-17 | 2317FS+12d | 80% | 32055d |  |
| 2372 |  | DTID Data to EIS | 30d | 2026-01-07 A | 2026-02-17 | 2317FS+12d | 80% | 32055d |  |
| 2373 | 1.7.2.11.3.2 | **ISD Salesforce** | 110d | 2025-10-01 A | 2026-03-03 |  | 85% | 32045d |  |
| 2374 |  | ISD UI Alignment | 110d | 2025-10-01 A | 2026-03-03 | 2312 | 85% | 32045d |  |
| 2375 | 1.7.2.11.4 | **Settlement Checks** | 318d | 2025-09-22 A | 2026-12-09 |  | 58% | 31844d |  |
| 2376 | 1.7.2.11.4.1 | **M10** | 296d | 2025-09-22 A | 2026-11-09 |  | 60% | 31866d |  |
| 2377 |  | M10 Settlement Start Date | 1d | 2025-09-22 A | 2025-09-22 A | 1802 | 100% |  |  |
| 2378 |  | R1 | 1d | 2025-10-06 A | 2025-10-06 A | 2377FS+9d | 100% |  |  |
| 2379 |  | R2 | 1d | 2026-01-14 A | 2026-01-14 A | 2377FS+81d | 100% |  |  |
| 2380 |  | R3 | 1d | 2026-04-24 | 2026-04-24 | 2377FS+153d |  | 32007d |  |

| ID | WBS | Task | Duration | Start | Finish | Predecessors | Complete | Total float | Constraint |
| --- | --- | --- | --- | --- | --- | --- | --- | --- | --- |
| 2381 |  | RF | 1d | 2026-11-09 | 2026-11-09 | 2377FS+294d |  | 31866d |  |
| 2382 | 1.7.2.11.4.2 | **M11** | 296d | 2025-10-22 A | 2026-12-09 |  | 57% | 31844d |  |
| 2383 |  | M11 Settlement Start Date | 1d | 2025-10-22 A | 2025-10-22 A | 3453 | 100% |  |  |
| 2384 |  | II | 1d | 2025-10-28 A | 2025-10-28 A | 2383FS+3d | 100% |  |  |
| 2385 |  | SF | 1d | 2025-11-12 A | 2025-11-12 A | 2383FS+14d | 100% |  |  |
| 2386 |  | R1 | 1d | 2025-12-09 A | 2025-12-09 A | 2383FS+33d | 100% |  |  |
| 2387 |  | R2 | 1d | 2026-02-13 | 2026-02-13 | 2383FS+81d |  | 32057d |  |
| 2388 |  | R3 | 1d | 2026-05-28 | 2026-05-28 | 2383FS+155d |  | 31983d |  |
| 2389 |  | RF | 1d | 2026-12-09 | 2026-12-09 | 2383FS+294d |  | 31844d |  |
| 2390 |  | SAT M16 Test Case Execution | 22d | 2026-07-01 | 2026-07-30 |  |  | 31938d | start no earlier than 2026-07-01 |
| 2391 |  | LSS provides Load Shape data that is publicly accessible - Business Requirement MHHSP-37 | 0d | 2026-04-08 | 2026-04-08 | 3453FS+120d |  | 32019d |  |
| 2392 | 1.8 | **S & A QUALIFICATION** | 843d? | 2023-11-07 A | 2027-01-28 |  | 88% | 31808d |  |
| 2393 | 1.8.1 | **MHHS Qualification - Qualification Deliverables** | 509d | 2023-11-07 A | 2025-10-17 A |  | 100% |  |  |
| 2394 | 1.8.1.1 | **BSC & REC Assessment Criteria** | 463d | 2023-11-07 A | 2025-08-14 A |  | 100% |  |  |
| 2395 |  | Draft BSC Assessment Criteria (Functional) | 21d | 2023-11-07 A | 2023-12-05 A |  | 100% |  | finish no earlier than 2023-12-05 |
| 2396 |  | BSC PAB Review | 1d | 2023-12-14 A | 2023-12-14 A |  | 100% |  | start no earlier than 2023-12-14 |
| 2397 |  | Update BSC Assessment Criteria (Functional, Non-Functional, Migration) | 30d | 2024-02-07 A | 2024-03-19 A |  | 100% |  | finish no earlier than 2024-03-19 |
| 2398 |  | REC & BSC PAB Approval | 3d | 2024-03-26 A | 2024-03-28 A |  | 100% |  | start no earlier than 2024-03-28 |
| 2399 |  | Update BSC Assessment Criteria (Functional, Non-Functional, Migration, Operational) | 20d | 2024-07-24 A | 2024-08-20 A |  | 100% |  |  |
| 2400 |  | Assessment Criteria (Functional, Non-Functional, Migration, Operational) Approved by REC PAB and BSC PAB | 250d | 2024-08-29 A | 2025-08-14 A | 2399FS+7d | 100% |  | start no earlier than 2023-09-15 |
| 2401 | 1.8.1.2 | **Qualification Approach and Plan** | 194d | 2023-12-04 A | 2024-08-29 A |  | 100% |  |  |
| 2402 | 1.8.1.2.1 | **Qualification Approach and Plan v2** | 84d | 2023-12-04 A | 2024-03-28 A |  | 100% |  |  |
| 2403 |  | Draft Qualification Approach and Plan v2 | 30d | 2023-12-04 A | 2024-01-12 A |  | 100% |  | finish no earlier than 2024-01-12 |
| 2404 |  | Internal Review (Code Bodies and MHHSP) for Qualification Approach and Plan V2 | 10d | 2024-01-15 A | 2024-01-26 A | 2403 | 100% |  | finish no earlier than 2024-01-26 |
| 2405 |  | Industry consultation for Qualification Approach and Plan v2 | 11d | 2024-01-31 A | 2024-02-14 A | 2404 | 100% |  | start no earlier than 2024-01-31 |
| 2406 |  | Update Qualification Approach and Plan v2 post industry consultation | 10d | 2024-02-15 A | 2024-02-28 A | 2405 | 100% |  |  |
| 2407 |  | QWG Endorsement of Qualification Approach and Plan v2 | 1d | 2024-03-12 A | 2024-03-12 A |  | 100% |  | start no earlier than 2024-03-12 |
| 2408 |  | QAG Approval of Qualification Approach and Plan v2 | 1d | 2024-03-21 A | 2024-03-21 A |  | 100% |  | start no earlier than 2024-03-21 |
| 2409 |  | BSC and REC PAB Approval of Qualification Approach and Plan v2 | 3d | 2024-03-26 A | 2024-03-28 A |  | 100% |  | finish no earlier than 2024-03-28 |
| 2410 |  | Functional Testing elements of Qualification Approach & Plan v2 approvement by REC PAB and BSC PAB | 0d | 2024-03-28 A | 2024-03-28 A | 2409 | 100% |  |  |
| 2411 |  | Migration Testing elements of Qualification Approach & Plan v2 appoved by REC PAB and BSC PAB | 0d | 2024-03-28 A | 2024-03-28 A | 2409 | 100% |  |  |
| 2412 | 1.8.1.2.2 | **Qualification Approach and Plan v3** | 84d | 2024-05-06 A | 2024-08-29 A |  | 100% |  |  |
| 2413 |  | Draft Qualification Approach and Plan v3 | 35d | 2024-05-06 A | 2024-06-21 A | 1068 | 100% |  | finish no earlier than 2024-05-17 |
| 2414 |  | Internal Review (Code Bodies and MHHSP) of Qualification Approach and Plan v3 | 10d | 2024-06-24 A | 2024-07-05 A | 2413 | 100% |  |  |
| 2415 |  | Industry consultation for Qualification Approach and Plan v3 | 10d | 2024-07-08 A | 2024-07-19 A | 2414 | 100% |  |  |
| 2416 |  | Update Qualification Approach and Plan v3 Post-Consultation | 10d | 2024-07-22 A | 2024-08-02 A | 2415 | 100% |  |  |
| 2417 |  | QWG Endorsement of Qualification Approach and Plan v3 | 1d | 2024-08-13 A | 2024-08-13 A | 2416FS+6d | 100% |  |  |
| 2418 |  | QAG Approval of Qualification Approach and Plan v3 | 0d | 2024-08-22 A | 2024-08-22 A | 2417FS+7d | 100% |  |  |
| 2419 |  | BSC and REC PAB Approval of Qualification Approach and Plan v3 | 3d | 2024-08-27 A | 2024-08-29 A | 2418FS+2d | 100% |  |  |
| 2420 |  | Non-Functional Testing elements of Qualification Approach and Plan v3 approved by REC PAB and BSC PAB | 0d | 2024-08-29 A | 2024-08-29 A | 2419 | 100% |  |  |
| 2421 | 1.8.1.3 | **Qualification Assessment Document** | 476d | 2023-12-22 A | 2025-10-17 A |  | 100% |  |  |
| 2422 | 1.8.1.3.1 | **Qualification Assessment Document v1** | 70d | 2023-12-22 A | 2024-03-28 A |  | 100% |  |  |
| 2423 |  | Draft Qualification Assessment Document v1 | 30d | 2023-12-22 A | 2024-02-01 A |  | 100% |  | finish no earlier than 2024-02-01 |
| 2424 |  | Internal Review (Code Bodies and MHHSP) of Qualification Assessment Document v1 | 10d | 2024-02-01 A | 2024-02-14 A |  | 100% |  | finish no earlier than 2024-02-14 |
| 2425 |  | Industry consultation for Qualification Assessment Document v1 | 11d | 2024-02-16 A | 2024-03-01 A |  | 100% |  | start no earlier than 2024-02-16 |
| 2426 |  | Update Post-Consultation for Qualification Assessment Document v1 | 10d | 2024-03-04 A | 2024-03-15 A | 2425 | 100% |  |  |
| 2427 |  | BSC and REC PAB Approval of Qualification Assessment Document v1 | 3d | 2024-03-26 A | 2024-03-28 A |  | 100% |  | start no earlier than 2024-03-26 |
| 2428 |  | Qualification Assessment Document v1 approved by REC PAB and BSC PAB | 0d | 2024-03-28 A | 2024-03-28 A | 2427 | 100% |  |  |
| 2429 | 1.8.1.3.2 | **Qualification Assessment Document v3** | 110d | 2024-03-29 A | 2024-08-29 A |  | 100% |  |  |
| 2430 |  | Draft Qualification Assessment Document V1.1 | 26d | 2024-03-29 A | 2024-05-03 A | 2428 | 100% |  |  |
| 2431 |  | Industry Consultation for Qualification Assessment Document V1.1 | 12d | 2024-05-06 A | 2024-05-21 A | 2430 | 100% |  |  |
| 2432 |  | Draft Qualification Assessment Document v3 | 6d | 2024-06-14 A | 2024-06-21 A | 1176, 2431 | 100% |  |  |
| 2433 |  | Internal Review (Code Bodies and MHHSP) of Qualification Assessment Document v3 | 10d | 2024-06-24 A | 2024-07-05 A | 2432 | 100% |  |  |
| 2434 |  | Industry consultation for Qualification Assessment Document v3 | 10d | 2024-07-08 A | 2024-07-19 A | 2433 | 100% |  |  |
| 2435 |  | Update Post-Consultation for Qualification Assessment Document v3 | 10d | 2024-07-22 A | 2024-08-02 A | 2434 | 100% |  |  |
| 2436 |  | QWG Endorsement of Qualification Assessment Document v3 | 1d | 2024-08-13 A | 2024-08-13 A | 2435FS+6d | 100% |  |  |
| 2437 |  | QAG Endorsement of Qualification Assessment Document v3 | 1d | 2024-08-22 A | 2024-08-22 A | 2436FS+6d | 100% |  |  |
| 2438 |  | BSC and REC PAB Approval of Qualification Assessment Document v3 | 3d | 2024-08-27 A | 2024-08-29 A | 2437FS+2d | 100% |  |  |
| 2439 |  | Qualification Assessment Document v3 approved by REC PAB and BSC PAB | 0d | 2024-08-29 A | 2024-08-29 A | 2438 | 100% |  |  |
| 2440 | 1.8.1.3.3 | **Qualification Assessment Document Portal** | 445d | 2024-02-05 A | 2025-10-17 A |  | 100% |  |  |
| 2441 |  | Design Completion | 30d | 2024-02-05 A | 2024-03-15 A |  | 100% |  | finish no earlier than 2024-03-15 |
| 2442 |  | Qualification Assessment Document Portal Build | 30d | 2024-03-18 A | 2024-04-26 A | 2441 | 100% |  |  |
| 2443 |  | Qualification Assessment Document Internal Testing | 20d | 2024-04-29 A | 2024-05-24 A | 2442 | 100% |  |  |
| 2444 |  | Qualification Assessment Document Portal Training and Onboarding Material Creation | 20d | 2024-05-27 A | 2024-06-21 A | 2443 | 100% |  |  |
| 2445 |  | Qualification Assessment Document Portal Webinar (Date TBC) | 1d | 2024-06-18 A | 2024-06-18 A |  | 100% |  | start no earlier than 2024-06-18 |
| 2446 |  | SIT Participant QAD Application Creation in Portal | 10d | 2024-12-09 A | 2024-12-20 A | 2444FS+120d | 100% |  |  |
| 2447 |  | Non-SIT LDSO Participant QAD Application Creation in Portal | 10d | 2024-12-09 A | 2024-12-20 A | 2444FS+120d | 100% |  |  |
| 2448 |  | QT Wave 1 Participant QAD Application Creation in Portal | 10d | 2025-04-21 A | 2025-05-02 A | 2444FS+215d | 100% |  |  |
| 2449 |  | QT Wave 2 Participant QAD Application Creation in Portal | 10d | 2025-05-26 A | 2025-06-06 A | 2444FS+240d | 100% |  |  |
| 2450 |  | QT Wave 3 Participant QAD Application Creation in Portal | 10d | 2025-07-28 A | 2025-08-08 A | 2444FS+285d | 100% |  |  |

| ID | WBS | Task | Duration | Start | Finish | Predecessors | Complete | Total float | Constraint |
| --- | --- | --- | --- | --- | --- | --- | --- | --- | --- |
| 2451 |  | QT Wave 4 Participant QAD Application Creation in Portal | 10d | 2025-10-06 A | 2025-10-17 A | 2444FS+335d | 100% |  |  |
| 2452 |  | Update to Qualification Assessment Document Portal post QAD V3 | 10d | 2024-08-30 A | 2024-09-12 A | 2439 | 100% |  |  |
| 2453 |  | Update to Qualification Assessment Document Portal post QAD V3 Complete | 0d | 2024-09-12 A | 2024-09-12 A | 2452 | 100% |  |  |
| 2454 | 1.8.2 | **MHHS Qualification - SIT Participants** | 408d? | 2025-01-06 A | 2026-07-30 |  | 99% | 31939d |  |
| 2455 |  | Initial QAD Submission Window opens | 0d | 2025-01-06 A | 2025-01-06 A | 2446FS+10d | 100% |  | start no earlier than 2025-01-06 |
| 2456 |  | SIT Participants submit Initial QAD | 30d | 2025-01-06 A | 2025-02-14 A |  | 100% |  | start no earlier than 2025-01-06 |
| 2457 |  | Code Bodies review Initial QAD | 36d | 2025-02-14 A | 2025-04-04 A | 2456FS-1d | 100% |  |  |
| 2458 |  | Completion of Code Bodies review of Initial QAD | 0d | 2025-04-04 A | 2025-04-04 A | 2457 | 100% |  |  |
| 2459 | 1.8.2.5 | **MHHS Qualification - M10-Ready** | 113d | 2025-04-07 A | 2025-09-10 A |  | 100% |  |  |
| 2460 |  | Final QAD Submission Window opens | 0d | 2025-04-07 A | 2025-04-07 A | 2457, 2453, 2458FS+1d | 100% |  |  |
| 2461 |  | SIT M10-ready Participants submit Final QAD (exc Test Reports) | 25d | 2025-04-07 A | 2025-05-09 A | 2460FS-1d | 100% |  |  |
| 2462 |  | Completion of Code Bodies review of Final QAD (M10-Ready) | 20d | 2025-05-12 A | 2025-06-06 A | 2461 | 100% |  |  |
| 2463 | 1.8.2.5.4 | **SIT / LDSO Pathway 2** | 16d | 2025-08-07 A | 2025-08-28 A | 1586 | 100% |  |  |
| 2464 |  | QAD Sign Off Deadline + Test Reports | 0d | 2025-08-07 A | 2025-08-07 A | 2462 | 100% |  | start no earlier than 2025-08-07 |
| 2465 |  | REC Code Manager / BSC PAB Approval of Qualification (M10-Ready) | 0d | 2025-08-28 A | 2025-08-28 A | 2464FS+16d | 100% |  |  |
| 2466 | 1.8.2.5.5 | **SIT / LDSO Pathway 3** | 13d | 2025-08-22 A | 2025-09-10 A | 1589 | 100% |  |  |
| 2467 |  | QAD Sign Off Deadline + Test Reports | 0d | 2025-08-22 A | 2025-08-22 A | 2462 | 100% |  | finish no earlier than 2025-08-22 |
| 2468 |  | REC Code Manager / BSC PAB Approval of Qualification (M10-Ready) | 2d | 2025-09-09 A | 2025-09-10 A | 2467FS+11d | 100% |  | start no earlier than 2025-09-09 |
| 2469 |  | M10-Ready SIT Participants are qualified | 0d | 2025-09-10 A | 2025-09-10 A | 2468 | 100% |  | finish no earlier than 2025-09-10 |
| 2470 | 1.8.2.6 | **MHHS Qualification - M11-Ready** | 137d? | 2025-04-07 A | 2025-10-15 A |  | 100% |  |  |
| 2471 |  | Final QAD Submission Window opens | 0d | 2025-04-07 A | 2025-04-07 A | 2457, 2453, 2458FS+1d | 100% |  |  |
| 2472 |  | SIT M11-ready Participants submit Final QAD (exc Test Reports) | 44d | 2025-04-08 A | 2025-06-06 A | 2471 | 100% |  |  |
| 2473 |  | Completion of Code Bodies review of Final QAD (M11-Ready) | 20d? | 2025-06-09 A | 2025-07-04 A | 2472 | 100% |  |  |
| 2474 | 1.8.2.6.4 | **SIT Pathway 4** | 16d | 2025-09-04 A | 2025-09-25 A |  | 100% |  |  |
| 2475 |  | QAD Sign Off Deadline + Test Reports | 0d | 2025-09-04 A | 2025-09-04 A | 2473 | 100% |  | start no earlier than 2025-09-04 |
| 2476 |  | REC Code Manager / BSC PAB Approval of Qualification (M11-Ready) | 0d | 2025-09-25 A | 2025-09-25 A | 2475FS+16d | 100% |  |  |
| 2477 | 1.8.2.6.5 | **SIT Pathway 5** | 16d | 2025-09-24 A | 2025-10-15 A |  | 100% |  |  |
| 2478 |  | QAD Sign Off Deadline + Test Reports | 0d | 2025-09-24 A | 2025-09-24 A | 2473 | 100% |  | start no earlier than 2025-09-24 |
| 2479 |  | REC Code Manager / BSC PAB Approval of Qualification | 0d | 2025-10-15 A | 2025-10-15 A | 2478FS+16d | 100% |  |  |
| 2480 |  | 'M11-Ready SIT Participants are qualified' | 0d | 2025-10-15 A | 2025-10-15 A | 2479 | 100% |  |  |
| 2481 | 1.8.2.7 | **MHHS Qualification - Not M11-Ready** | 313d | 2025-05-19 A | 2026-07-30 |  | 99% | 31939d |  |
| 2482 |  | Final QAD Submission Window opens | 0d | 2025-05-19 A | 2025-05-19 A | 2458FS+31d | 100% |  | start no earlier than 2025-04-07 |
| 2483 |  | SIT Not M11-Ready Participants submit Final QAD | 90d | 2025-05-19 A | 2025-09-19 A | 2482SS-1d | 100% |  |  |
| 2484 |  | Completion of Code Bodies review of Final QAD (Not M11-Ready) | 25d | 2025-09-22 A | 2025-10-24 A | 2483 | 100% |  |  |
| 2485 | 1.8.2.7.4 | **SIT Pathway 6** | 50d | 2025-10-09 A | 2025-12-18 A |  | 100% |  |  |
| 2486 |  | QAD Sign Off Deadline + Test Reports | 0d | 2025-10-09 A | 2025-10-09 A |  | 100% |  | start no earlier than 2025-10-09 |
| 2487 |  | REC Code Manager / BSC PAB Approval of Qualification (first Pathway 6 PAB) | 0d | 2025-10-30 A | 2025-10-30 A | 2486FS+16d | 100% |  |  |
| 2488 |  | QAD Sign Off Deadline + Test Reports | 0d | 2025-11-26 A | 2025-11-26 A |  | 100% |  | start no earlier than 2025-11-26 |
| 2489 |  | REC Code Manager / BSC PAB Approval of Qualification (final Pathway 6 PAB) | 0d | 2025-12-18 A | 2025-12-18 A | 2488FS+16d | 100% |  | start no earlier than 2025-12-18 |
| 2490 |  | SIT Participants are Qualified | 0d | 2026-07-30 | 2026-07-30 |  |  | 31939d | start no earlier than 2026-07-30 |
| 2491 | 1.8.3 | **MHHS Qualification - Non-SIT LDSO (M10-Ready)** | 179d | 2025-01-06 A | 2025-09-11 A |  | 100% |  |  |
| 2492 |  | Initial QAD Submission window opens | 0d | 2025-01-06 A | 2025-01-06 A | 2447FS+11d | 100% |  |  |
| 2493 |  | Non-SIT LDSO Participants submit initial QAD | 30d | 2025-01-06 A | 2025-02-14 A |  | 100% |  | start no earlier than 2025-01-06 |
| 2494 |  | Non-SIT LDSO QT Participants have submitted their initial QAD | 0d | 2025-02-14 A | 2025-02-14 A | 2493 | 100% |  |  |
| 2495 |  | Code Bodies review of Non-SIT LDSO participants Initial QAD | 35d | 2025-02-17 A | 2025-04-04 A | 2494 | 100% |  |  |
| 2496 |  | Completion of Code Bodies review of Initial QAD | 0d | 2025-04-04 A | 2025-04-04 A | 2495 | 100% |  |  |
| 2497 |  | Final QAD Submission window opens | 0d | 2025-04-07 A | 2025-04-07 A | 2496FS+1d | 100% |  |  |
| 2498 |  | Non-SIT LDSO Participants submit Final QAD | 35d | 2025-04-07 A | 2025-05-23 A | 2497SS-1d, 1922 | 100% |  | finish no earlier than 2025-05-23 |
| 2499 |  | Non-SIT LDSO QT Participants have submitted their final QAD | 0d | 2025-05-23 A | 2025-05-23 A | 2498 | 100% |  |  |
| 2500 |  | Completion of Code Bodies review of the Final QAD | 20d | 2025-05-26 A | 2025-06-20 A | 2499 | 100% |  |  |
| 2501 |  | QAD Finalisation | 42d | 2025-06-23 A | 2025-08-19 A | 2500 | 100% |  |  |
| 2502 |  | QAD Sign Off Deadline (Non-SIT LDSOs) | 0d | 2025-08-22 A | 2025-08-22 A | 2500FS+5d, 1922, 2501 | 100% |  | finish no earlier than 2025-08-22 |
| 2503 |  | BSC PAB & REC Manager approval of Qualification for Non-SIT LDSOs | 0d | 2025-09-11 A | 2025-09-11 A | 2502FS+13d | 100% |  | finish no earlier than 2025-09-11 |
| 2504 | 1.8.4 | **MHHS Qualification - Qualification Waves** | 814d? | 2023-12-18 A | 2027-01-28 |  | 85% | 31808d |  |
| 2505 | 1.8.4.1 | **Qualification Wave Prep** | 569d? | 2023-12-18 A | 2026-02-19 |  | 99% | 31820d |  |
| 2506 | 1.8.4.1.1 | **Non-SIT Supplier and Agent Test Approach and Plan** | 119d | 2023-12-18 A | 2024-05-30 A |  | 100% |  |  |
| 2507 |  | Draft Non-SIT S&A Test Approach and Plan | 50d | 2023-12-18 A | 2024-02-23 A |  | 100% |  | finish no earlier than 2024-02-23 |
| 2508 |  | Internal Review of Non-SIT S&A Test Approach and Plan (Code Bodies and MHHSP) | 10d | 2024-02-26 A | 2024-03-08 A | 2507 | 100% |  |  |
| 2509 |  | Issue Non-SIT S&A Test Approach and Plan for Consultation | 15d | 2024-03-18 A | 2024-04-05 A | 2508 | 100% |  | start no earlier than 2024-03-18 |
| 2510 |  | Update Non-SIT S&A Test Approach and Plan Post-Consultation | 10d | 2024-04-08 A | 2024-04-19 A | 2509 | 100% |  |  |
| 2511 |  | QWG Endorsement of Non-SIT S&A Test Approach and Plan | 1d | 2024-05-14 A | 2024-05-14 A |  | 100% |  | finish no earlier than 2024-05-14 |
| 2512 |  | QAG Approval of Non-SIT S&A Test Approach and Plan | 0d | 2024-05-23 A | 2024-05-23 A | 2511FS+7d | 100% |  |  |
| 2513 |  | BSC & REC PAB Approval of Non-SIT S&A Test Approach and Plan | 0d | 2024-05-30 A | 2024-05-30 A | 2512FS+5d | 100% |  |  |
| 2514 | 1.8.4.1.2 | **QT Test Data Approach and Plan** | 64d | 2024-04-19 A | 2024-07-18 A |  | 100% |  |  |
| 2515 |  | QT Test Data Approach agreed as part of the Non-SIT Supplier and Agent Test Approach and Plan | 0d | 2024-04-19 A | 2024-04-19 A | 2510 | 100% |  |  |
| 2516 |  | Draft Test Data Approach and Plan for QT | 10d | 2024-05-06 A | 2024-05-17 A | 2515 | 100% |  |  |
| 2517 |  | Internal Review (Code Bodies and MHHSP) of QT Test Data Approach and Plan | 15d | 2024-05-20 A | 2024-06-07 A | 2516 | 100% |  |  |
| 2518 |  | Issue QT Test Data Approach and Plan for Industry Consultation | 10d | 2024-06-10 A | 2024-06-21 A | 2517 | 100% |  |  |
| 2519 |  | Update QT Test Approach and Plan Post Industry Consultation | 5d | 2024-06-24 A | 2024-06-28 A | 2518 | 100% |  |  |
| 2520 |  | QWG Endorsement of Test Data Approach and Plan | 1d | 2024-07-09 A | 2024-07-09 A | 2519FS+6d | 100% |  |  |

| ID | WBS | Task | Duration | Start | Finish | Predecessors | Complete | Total float | Constraint |
| --- | --- | --- | --- | --- | --- | --- | --- | --- | --- |
| 2521 |  | QAG Approval of QT Test Data Approach and Plan | 0d | 2024-07-18 A | 2024-07-18 A | 2520FS+7d | 100% |  |  |
| 2522 | 1.8.4.1.3 | **QT Functional Test Scenarios and Test Cases** | 59d | 2024-03-04 A | 2024-05-23 A |  | 100% |  |  |
| 2523 |  | Draft Test Scenarios and Test Case list - Batch 1 | 10d | 2024-03-04 A | 2024-03-15 A |  | 100% |  | finish no earlier than 2024-03-15 |
| 2524 |  | Issue Batch 1 for Consultation | 15d | 2024-03-18 A | 2024-04-05 A | 2523 | 100% |  | start no earlier than 2024-03-18 |
| 2525 |  | Gap analysis against QT Requirements | 8d | 2024-03-18 A | 2024-03-27 A | 2523 | 100% |  |  |
| 2526 |  | Update Test Scenarios and Test Case list - Batch 2 | 6d | 2024-03-28 A | 2024-04-04 A | 2525 | 100% |  |  |
| 2527 |  | Issue Batch 2 for consultation | 10d | 2024-04-05 A | 2024-04-18 A | 2526 | 100% |  |  |
| 2528 |  | Update Batch 2 post consultation | 10d | 2024-04-19 A | 2024-05-02 A | 2527 | 100% |  |  |
| 2529 |  | QWG Endorsement of Batch 1 and 2 | 1d | 2024-05-14 A | 2024-05-14 A |  | 100% |  | finish no earlier than 2024-05-14 |
| 2530 |  | QAG Approval of QT Functional Test Scenarios and Test Cases Batches 1 and 2 | 0d | 2024-05-23 A | 2024-05-23 A | 2529FS+7d | 100% |  |  |
| 2531 | 1.8.4.1.4 | **QT Migration Test Scenarios and Test Cases** | 54d | 2024-05-06 A | 2024-07-18 A |  | 100% |  |  |
| 2532 |  | Draft Test Scenarios and Test Case list - Batch 1 | 20d | 2024-05-06 A | 2024-05-31 A | 987FS+12d | 100% |  |  |
| 2533 |  | Issue Batch 1 for Consultation | 10d | 2024-06-03 A | 2024-06-14 A | 2532 | 100% |  |  |
| 2534 |  | Update Batch 1 Post Consultation | 10d | 2024-06-17 A | 2024-06-28 A | 2533 | 100% |  |  |
| 2535 |  | QWG Endorsement of Batch 1 | 0d | 2024-07-09 A | 2024-07-09 A | 2534FS+7d | 100% |  |  |
| 2536 |  | QAG Approval of QT Migration Test Scenarios and Test Cases Batches 1 | 0d | 2024-07-18 A | 2024-07-18 A | 2535FS+7d | 100% |  |  |
| 2537 | 1.8.4.1.5 | **QT Functional (inc NF and Operational) Test Scenarios and Test Cases** | 77d | 2024-11-05 A | 2025-02-20 A |  | 100% |  |  |
| 2538 |  | Draft Test Scenarios and Test Case list - Batch 3 | 20d | 2024-11-05 A | 2024-12-02 A | 874FS-1d | 100% |  |  |
| 2539 |  | Issue Batch 3 for Consultation | 10d | 2024-12-03 A | 2024-12-16 A | 2538 | 100% |  |  |
| 2540 |  | Update Batch 3 Post Consultation | 20d | 2024-12-17 A | 2025-01-13 A | 2539 | 100% |  |  |
| 2541 |  | QWG Endorsement of Batch 3 | 0d | 2025-02-11 A | 2025-02-11 A | 2540FS+21d | 100% |  |  |
| 2542 |  | QAG Approval of QT Functional Test Scenarios and Test Cases Batches 3 | 0d | 2025-02-20 A | 2025-02-20 A | 2541FS+6d | 100% |  | start no earlier than 2025-02-20 |
| 2543 | 1.8.4.1.6 | **Qualification Testing Framework (Test Stubs and Supporting UI)** | 539d? | 2024-01-29 A | 2026-02-19 |  | 99% | 31820d |  |
| 2544 |  | Proof of Concept for QTF Completion | 45d | 2024-01-29 A | 2024-03-29 A |  | 100% |  | finish no earlier than 2024-03-29 |
| 2545 |  | Discovery and Mobilisation | 25d | 2024-04-01 A | 2024-05-03 A | 2544 | 100% |  | finish no earlier than 2024-05-03 |
| 2546 | 1.8.4.1.6.3 | **Agile DBT of Qualification Testing Framework** | 83d | 2024-04-24 A | 2024-08-16 A |  | 100% |  |  |
| 2547 | 1.8.4.1.6.3.1 | **User Interface (UI)** | 48d | 2024-04-24 A | 2024-06-28 A |  | 100% |  |  |
| 2548 |  | UI Wireframe | 48d | 2024-04-24 A | 2024-06-28 A |  | 100% |  | finish no earlier than 2024-06-28 |
| 2549 |  | UI Standards | 35d | 2024-05-13 A | 2024-06-28 A | 2548FS+13d | 100% |  | finish no earlier than 2024-06-28 |
| 2550 |  | Elexon Branding Sylesheet | 2d | 2024-05-17 A | 2024-05-20 A | 2549FS+10d | 100% |  | finish no earlier than 2024-05-20 |
| 2551 |  | Elexon Branding QTF Logo | 2d | 2024-05-31 A | 2024-06-03 A | 2550FS+20d | 100% |  | finish no earlier than 2024-06-03 |
| 2552 | 1.8.4.1.6.3.2 | **Design, Build, Test** | 70d | 2024-05-13 A | 2024-08-16 A |  | 100% |  |  |
| 2553 |  | Core UI Screens | 60d | 2024-05-13 A | 2024-08-02 A | 2549SS | 100% |  | finish no earlier than 2024-08-02 |
| 2554 |  | Tooling (Trigger Files / Template Generators) | 70d | 2024-05-13 A | 2024-08-16 A | 2548SS+13d | 100% |  | finish no earlier than 2024-08-16 |
| 2555 |  | Database Schema | 50d | 2024-05-13 A | 2024-07-19 A | 2548SS+13d | 100% |  | finish no earlier than 2024-07-19 |
| 2556 |  | Core API's | 60d | 2024-05-13 A | 2024-08-02 A | 2548SS+13d | 100% |  | finish no earlier than 2024-08-02 |
| 2557 |  | QTF Test Cases DBT Refinement, Execution and Results Validation, Defect Management, Error Handling | 77d | 2024-11-05 A | 2025-02-20 A | 2542FF, 2536FF, 2538SS | 100% |  |  |
| 2558 | 1.8.4.1.6.5 | **Environments** | 339d | 2024-04-15 A | 2025-07-31 |  | 100% |  |  |
| 2559 | 1.8.4.1.6.5.1 | **Azure Devops** | 173d | 2024-04-15 A | 2024-12-11 A |  | 100% |  |  |
| 2560 | 1.8.4.1.6.5.1.1 | **QFT ADO Development Instance** | 15d | 2024-04-15 A | 2024-05-03 A |  | 100% |  |  |
| 2561 |  | Elexon Instance Setup for QTF Build | 5d | 2024-04-15 A | 2024-04-19 A | 2545SS+10d | 100% |  | finish no earlier than 2024-04-19 |
| 2562 |  | Configuration and User Access | 10d | 2024-04-22 A | 2024-05-03 A | 2561 | 100% |  | finish no earlier than 2024-05-03 |
| 2563 | 1.8.4.1.6.5.1.2 | **MHHSP ADO Instance** | 102d | 2024-07-23 A | 2024-12-11 A |  | 100% |  |  |
| 2564 |  | MHHSP Instance Setup for QTF Production | 29d | 2024-07-23 A | 2024-08-30 A | 2570SS+41d | 100% |  | finish no earlier than 2024-08-30 |
| 2565 |  | Configuration and User Access | 73d | 2024-09-02 A | 2024-12-11 A | 2564 | 100% |  | finish no earlier than 2024-09-27 |
| 2566 | 1.8.4.1.6.5.2 | **Temporary Development Environment** | 35d | 2024-04-15 A | 2024-05-31 A |  | 100% |  |  |
| 2567 |  | Design | 15d | 2024-04-15 A | 2024-05-03 A | 2545SS+10d | 100% |  | finish no earlier than 2024-05-03 |
| 2568 |  | Build and Deployment | 20d | 2024-05-06 A | 2024-05-31 A | 2562, 2567 | 100% |  | finish no earlier than 2024-05-31 |
| 2569 | 1.8.4.1.6.5.3 | **Dev, Test & Prod Environment Requirements + Design** | 135d | 2024-05-27 A | 2024-11-29 A |  | 100% |  |  |
| 2570 |  | Design (including Security Review) | 135d | 2024-05-27 A | 2024-11-29 A | 2545FS+15d | 100% |  | finish no earlier than 2024-08-30 |
| 2571 |  | Hub Development Dev/Test | 20d | 2024-06-10 A | 2024-07-05 A | 2570SS+10d | 100% |  |  |
| 2572 |  | Hub Deployment | 20d | 2024-06-10 A | 2024-07-05 A | 2570FS+10d, 2571 | 100% |  | finish no earlier than 2024-07-05 |
| 2573 |  | Development Envn. Deployment | 53.8d | 2024-07-08 A | 2024-09-19 A | 2572 | 100% |  | finish no earlier than 2024-08-30 |
| 2574 |  | Test Envn. Deployment | 10d | 2024-09-19 A | 2024-10-03 A | 2573 | 100% |  | finish no earlier than 2024-09-13 |
| 2575 |  | Production Envn. Deployment | 25d | 2024-10-03 A | 2024-11-07 A | 2574 | 100% |  | finish no earlier than 2024-10-18 |
| 2576 | 1.8.4.1.6.5.4 | **QTF Deployment into Production** | 19d | 2025-02-20 A | 2025-03-18 A |  | 100% |  |  |
| 2577 |  | App Deployment | 5d | 2025-02-20 A | 2025-02-26 A | 2557, 2575 | 100% |  | start no earlier than 2025-02-03 |
| 2578 |  | Smoke Test | 2d | 2025-02-27 A | 2025-02-28 A | 2577 | 100% |  | finish no earlier than 2025-02-04 |
| 2579 |  | PEN Test | 2d | 2025-03-03 A | 2025-03-04 A | 2578 | 100% |  | finish no earlier than 2025-02-06 |
| 2580 |  | Regression Test | 10d | 2025-03-05 A | 2025-03-18 A | 2579 | 100% |  | finish no earlier than 2025-02-20 |
| 2581 | 1.8.4.1.6.5.5 | **DIP Onboarding (UIT)** | 101d | 2024-07-26 A | 2024-12-13 A |  | 100% |  |  |
| 2582 |  | DIP Simulator | 15d | 2024-07-26 A | 2024-08-15 A |  | 100% |  | finish no earlier than 2024-08-15 |
| 2583 |  | DIP (UIT) Instance available for Onboarding | 1d | 2024-08-05 A | 2024-08-05 A |  | 100% |  | start no earlier than 2024-08-05 |
| 2584 |  | DIP (UIT) Portal | 1d | 2024-09-03 A | 2024-09-03 A | 2583 | 100% |  | start no earlier than 2024-09-03 |
| 2585 |  | DIP (UIT) Onboarding for Development (incl. certificates and security compliance) | 39d | 2024-08-06 A | 2024-09-27 A | 2583 | 100% |  | finish no earlier than 2024-09-27 |
| 2586 |  | DIP (UIT) Onboarding for Development Connection Confirmed | 1d | 2024-09-30 A | 2024-09-30 A | 2585 | 100% |  | start no earlier than 2024-09-30 |
| 2587 |  | DIP (UIT) Onboarding for Test (incl. certificates and security compliance) | 5d | 2024-10-01 A | 2024-10-07 A | 2586 | 100% |  | finish no earlier than 2024-10-07 |
| 2588 |  | DIP (UIT) Onboarding for Test Connection Confirmed | 1d | 2024-10-08 A | 2024-10-08 A | 2587 | 100% |  | start no earlier than 2024-10-08 |
| 2589 |  | DIP (UIT) Onboarding for Prod (incl. certificates and security compliance) | 5d | 2024-10-09 A | 2024-10-15 A | 2588 | 100% |  | finish no earlier than 2024-10-15 |
| 2590 |  | DIP (UIT) Onboarding for Prod Connection Confirmed | 1d | 2024-10-16 A | 2024-10-16 A | 2589 | 100% |  | start no earlier than 2024-10-16 |

| ID | WBS | Task | Duration | Start | Finish | Predecessors | Complete | Constraint |
| --- | --- | --- | --- | --- | --- | --- | --- | --- |
| 2591 |  | DIP UIT Test Stubs | 32d | 2024-10-31 A | 2024-12-13 A | 2586, 2588, 2590 | 100% | start no earlier than 2024-10-31 |
| 2592 | 1.8.4.1.6.5.6 | **DTN Onboarding** | 115d | 2024-05-20 A | 2024-10-25 A |  | 100% |  |
| 2593 |  | DTN Request Raised for Onboarding | 25d | 2024-05-20 A | 2024-06-21 A |  | 100% | start no earlier than 2024-05-20 |
| 2594 |  | Setup, configuration of New Host and Test Flags | 5d | 2024-06-24 A | 2024-06-28 A | 2593 | 100% | start no earlier than 2024-06-24 |
| 2595 |  | New VPN Connection (Test) | 30d | 2024-08-05 A | 2024-09-13 A | 2594 | 100% | start no earlier than 2024-08-05 |
| 2596 |  | New VPN Connection (Prod) | 30d | 2024-09-16 A | 2024-10-25 A | 2595 | 100% | finish no earlier than 2024-10-25 |
| 2597 |  | DTN Test Stubs | 10d | 2024-09-16 A | 2024-09-27 A | 2595 | 100% | start no earlier than 2024-09-16 |
| 2598 | 1.8.4.1.6.5.7 | **Generate Tooling** | 334d | 2024-04-22 A | 2025-07-31 |  | 100% |  |
| 2599 |  | MPAN Core Generator | 25d | 2024-04-22 A | 2024-05-24 A |  | 100% | finish no earlier than 2024-05-24 |
| 2600 |  | MPAN File Generator | 55d | 2024-05-27 A | 2024-08-09 A | 2599 | 100% | finish no earlier than 2024-08-09 |
| 2601 |  | MPAN Template Loader | 32d | 2024-08-12 A | 2024-09-24 A | 2600 | 100% | finish no earlier than 2024-09-24 |
| 2602 |  | ADO Extract (QTC) From SIT | 30d | 2024-05-06 A | 2024-06-14 A |  | 100% | finish no earlier than 2024-06-14 |
| 2603 |  | Populate QT ADO | 40d | 2024-06-17 A | 2024-08-09 A | 2602 | 100% | finish no earlier than 2024-08-09 |
| 2604 |  | Create QTC Spreadsheets | 20d | 2024-06-03 A | 2024-06-28 A | 2602 | 100% | finish no earlier than 2024-06-28 |
| 2605 |  | Upload QTC Spreadsheets to QTF | 20d | 2024-07-01 A | 2024-07-26 A | 2604 | 100% | finish no earlier than 2024-07-26 |
| 2606 |  | Create QTC Set / Master QTC Loader | 40d | 2024-07-22 A | 2024-09-13 A | 2605 | 100% | finish no earlier than 2024-09-13 |
| 2607 | 1.8.4.1.6.5.8 | **Test Data** | 15d | 2024-06-10 A | 2024-06-28 A |  | 100% |  |
| 2608 |  | Sample MPAN Data + Attributes from Suppliers | 15d | 2024-06-10 A | 2024-06-28 A |  | 100% | finish no earlier than 2024-06-28 |
| 2609 | 1.8.4.1.6.6 | **MPANs, DIP Messages, Settlement, Consumption, Reference** | 423d? | 2024-05-27 A | 2026-01-07 |  | 97% |  |
| 2610 |  | Create MPAN Data | 55d | 2024-05-27 A | 2024-08-09 A | 2599 | 100% | finish no earlier than 2024-08-09 |
| 2611 |  | Create message templates (DIP, CSS, DTN) | 40d | 2024-06-03 A | 2024-07-26 A |  | 100% | finish no earlier than 2024-07-26 |
| 2612 |  | Create Consumption Data Templates | 20d | 2024-09-16 A | 2024-10-11 A |  | 100% | finish no earlier than 2024-10-11 |
| 2613 |  | Load Consumption Data | 25d | 2024-11-11 A | 2024-12-13 A | 2612FS+20d | 100% |  |
| 2614 |  | Create Load Shape and Load Shape Total Templates | 20d | 2024-09-16 A | 2024-10-11 A |  | 100% | finish no earlier than 2024-10-11 |
| 2615 |  | Load Shape and Load Shape Total Data | 25d | 2024-11-11 A | 2024-12-13 A | 2614FS+20d | 100% |  |
| 2616 |  | Create Settlement Report Templates | 20d | 2024-09-16 A | 2024-10-11 A |  | 100% | finish no earlier than 2024-10-11 |
| 2617 |  | Load Settlement Report Data | 25d | 2024-11-11 A | 2024-12-13 A | 2616FS+20d | 100% |  |
| 2618 |  | Market Domain Data (MDD) For Legacy Systems | 25d | 2024-07-29 A | 2024-08-30 A |  | 100% | finish no earlier than 2024-08-30 |
| 2619 | 1.8.4.1.6.6.10 | **Industry Standing Data (ISD)** | 71d? | 2024-07-26 A | 2024-11-01 A |  | 100% |  |
| 2620 |  | Dependant on Receiving ISD Agreed Source Data from Helix | 1d | 2024-07-26 A | 2024-07-26 A |  | 100% | start no earlier than 2024-07-26 |
| 2621 |  | Helix Dev Environment migration | 6d | 2024-07-29 A | 2024-08-05 A | 2620 | 100% | finish no earlier than 2024-08-05 |
| 2622 |  | STGi (UK) migration | 5d | 2024-09-09 A | 2024-09-13 A | 2620 | 100% | finish no earlier than 2024-09-13 |
| 2623 |  | Maintenance window between cycle 2 and 3 | 1d | 2024-09-20 A | 2024-09-20 A | 2620 | 100% | finish no earlier than 2024-09-20 |
| 2624 |  | First View of Migrated ISD Data | 5d | 2024-09-23 A | 2024-09-27 A | 2623 | 100% | finish no earlier than 2024-09-27 |
| 2625 |  | Second View of Migrated ISD Data (HXT1 (SIT B) migration) | 5d | 2024-09-23 A | 2024-09-27 A | 2623 | 100% | finish no earlier than 2024-09-27 |
| 2626 |  | Final Cycle 3 Migrated ISD Data | 5d | 2024-10-07 A | 2024-10-11 A | 2624 | 100% | finish no earlier than 2024-10-11 |
| 2627 |  | Create ISD Template inc. DIP ID | 35d? | 2024-09-16 A | 2024-11-01 A | 2623 | 100% | finish no earlier than 2024-11-01 |
| 2628 |  | Publish Qualification ISD | 10d? | 2024-10-14 A | 2024-10-25 A | 2626, 2623 | 100% | finish no earlier than 2024-10-25 |
| 2629 | 1.8.4.1.6.6.11 | **BETA Testing 1 - Test Data** | 27d | 2024-11-01 A | 2024-12-09 |  | 100% |  |
| 2630 |  | Provide Example MPAN File | 3d | 2024-11-01 A | 2024-11-05 A | 2673SS | 100% | finish no earlier than 2024-11-05 |
| 2631 |  | Load Example MPAN File | 6d | 2024-11-06 A | 2024-11-13 A | 2630 | 100% | finish no earlier than 2024-11-13 |
| 2632 |  | Industry Standing Data (ISD) | 6d | 2024-11-06 A | 2024-11-13 A | 2673SS+3d | 100% | finish no earlier than 2024-11-13 |
| 2633 |  | Market Domain Data (MDD) | 6d | 2024-11-06 A | 2024-11-13 A | 2673SS+3d | 100% | finish no earlier than 2024-11-13 |
| 2634 |  | Load ISD / MDD Data | 1d | 2024-12-06 A | 2024-12-06 A | 2632FS+16d, 2633FS+11d | 100% | start no earlier than 2024-11-14 |
| 2635 |  | Create QTC sets and Test MPANs via QTF | 1d | 2024-12-06 A | 2024-12-06 A | 2631FS+16d | 100% | start no earlier than 2024-11-14 |
| 2636 |  | Create QTC sets in ADO via QTF | 1d | 2024-12-06 A | 2024-12-06 A | 2635SS | 100% | start no earlier than 2024-11-14 |
| 2637 |  | Provide Test MPANs (Suppliers only) allocated to specfic QTC's | 1d | 2024-12-06 A | 2024-12-06 A | 2634SS | 100% | start no earlier than 2024-11-14 |
| 2638 |  | Load Test MPANs | 1d | 2024-12-09 A | 2024-12-09 A | 2637 | 100% | start no earlier than 2024-11-15 |
| 2639 | 1.8.4.1.6.6.11.10 | **BETA Testing 2 - Test Data** | 11d | 2025-01-08 A | 2025-01-22 A |  | 100% |  |
| 2640 |  | Provide Example MPAN File | 3d | 2025-01-08 A | 2025-01-10 A | 2674SS | 100% | start no earlier than 2025-01-08 |
| 2641 |  | Load Example MPAN File | 6d | 2025-01-13 A | 2025-01-20 A | 2640 | 100% | start no earlier than 2025-01-13 |
| 2642 |  | Industry Standing Data (ISD) | 6d | 2025-01-08 A | 2025-01-15 A | 2628, 2674SS | 100% | start no earlier than 2025-01-08 |
| 2643 |  | Market Domain Data (MDD) | 6d | 2025-01-08 A | 2025-01-15 A | 2612, 2674SS | 100% | start no earlier than 2025-01-08 |
| 2644 |  | Load ISD / MDD Data | 1d | 2025-01-16 A | 2025-01-16 A | 2642, 2643, 2674SS | 100% | start no earlier than 2025-01-16 |
| 2645 |  | Create QTC sets and Test MPANs via QTF | 1d | 2025-01-21 A | 2025-01-21 A | 2641 | 100% | start no earlier than 2025-01-21 |
| 2646 |  | Create QTC sets in ADO via QTF | 1d | 2025-01-21 A | 2025-01-21 A | 2645SS | 100% | start no earlier than 2025-01-21 |
| 2647 |  | Provide Test MPANs (Suppliers only) allocated to specfic QTC's | 1d | 2025-01-21 A | 2025-01-21 A | 2645SS | 100% | start no earlier than 2025-01-21 |
| 2648 |  | Load Test MPANs | 1d | 2025-01-22 A | 2025-01-22 A | 2647 | 100% | start no earlier than 2025-01-22 |
| 2649 | 1.8.4.1.6.6.12 | **Wave 1 Test Data** | 46d | 2025-05-12 | 2025-07-15 | 2635SS | 100% |  |
| 2650 |  | Test Data Request + Templates Completed | 2d | 2025-07-14 A | 2025-07-15 A | 2634SS | 100% | start no earlier than 2025-07-14 |
| 2651 |  | Test Data Generated | 2d | 2025-07-16 A | 2025-07-17 A | 2637, 2650 | 100% | finish no earlier than 2025-06-03 |
| 2652 |  | Test Data Loaded into QP Systems | 15d | 2025-07-18 A | 2025-08-07 A | 2651 | 100% | finish no earlier than 2025-06-17 |
| 2653 |  | Test Data Loaded into QTF + ADO | 5d | 2025-08-11 A | 2025-08-15 A | 2651, 2652 | 100% | finish no earlier than 2025-08-15 |
| 2654 | 1.8.4.1.6.6.13 | **Wave 2 Test Data** | 42d | 2025-07-07 | 2025-09-03 |  | 100% |  |
| 2655 |  | Test Data Request + Templates Completed | 2d | 2025-09-17 A | 2025-09-18 A |  | 100% | start no earlier than 2025-09-17 |
| 2656 |  | Test Data Generated | 2d | 2025-09-19 A | 2025-09-22 A | 2655 | 100% | finish no earlier than 2025-07-29 |
| 2657 |  | Test Data Loaded into QP Systems | 15d | 2025-09-23 A | 2025-10-13 A | 2656 | 100% | finish no earlier than 2025-08-12 |
| 2658 |  | Test Data Loaded into QTF + ADO | 4d | 2025-10-14 A | 2025-10-17 A | 2656, 2657 | 100% | finish no earlier than 2025-08-12 |
| 2659 | 1.8.4.1.6.6.14 | **Wave 3 Test Data** | 45d | 2025-09-08 | 2025-11-10 |  | 100% |  |
| 2660 |  | Test Data Request + Templates Completed | 2d | 2025-11-10 A | 2025-11-11 A |  | 100% | start no earlier than 2025-11-10 |

| ID | WBS | Task | Duration | Start | Finish | Predecessors | Complete | Total float | Constraint |
| --- | --- | --- | --- | --- | --- | --- | --- | --- | --- |
| 2661 |  | Test Data Generated | 2d | 2025-11-12 A | 2025-11-13 A | 2660 | 100% |  | finish no earlier than 2025-09-29 |
| 2662 |  | Test Data Loaded into QP Systems | 15d | 2025-11-14 A | 2025-12-04 A | 2661 | 100% |  | finish no earlier than 2025-10-13 |
| 2663 |  | Test Data Loaded into QTF + ADO | 5d | 2025-12-05 A | 2025-12-11 A | 2661, 2662 | 100% |  | finish no earlier than 2025-10-13 |
| 2664 | 1.8.4.1.6.6.15 | **Wave 4 Test Data** | 24d | 2026-01-19 A | 2026-02-19 |  | 8% |  |  |
| 2665 |  | Test Data Request + Templates Completed | 2d | 2026-01-19 A | 2026-01-20 |  | 50% | 1d | start no earlier than 2026-01-19 |
| 2666 |  | Test Data Generated | 2d | 2026-01-21 A | 2026-01-22 | 2665 | 50% | 31820d | finish no earlier than 2025-11-27 |
| 2667 |  | Test Data Loaded into QP Systems | 15d | 2026-01-23 | 2026-02-12 | 2666 |  | 31820d | finish no earlier than 2025-12-11 |
| 2668 |  | Test Data Loaded into QTF + ADO | 5d | 2026-02-13 | 2026-02-19 | 2666, 2667 |  | 31820d | finish no earlier than 2025-12-11 |
| 2669 | 1.8.4.1.6.6.16 | **Governance** | 195d | 2024-07-01 A | 2025-03-28 A |  | 100% |  |  |
| 2670 |  | Onboarding Strategy and Develop Training Requirements & Materials Inc. Day in the Life | 120d | 2024-07-01 A | 2024-12-13 A | 2548 | 100% |  | finish no earlier than 2024-12-13 |
| 2671 |  | Design Approach & Set-Up ADO Tool for Test & Defect Management Tool | 20d | 2024-07-01 A | 2024-07-26 A | 2670SS | 100% |  |  |
| 2672 |  | Knowledge Transfer, Training, Demonstrations, Documentation, Governance | 78d | 2024-08-30 A | 2024-12-17 A | 2670SS+44d | 100% |  |  |
| 2673 |  | BETA Testing | 33d | 2024-11-01 A | 2024-12-17 A |  | 100% |  | finish no earlier than 2024-12-17 |
| 2674 |  | BETA Testing 2 | 58d | 2025-01-08 A | 2025-03-28 A | 2673 | 100% |  | start no earlier than 2025-01-08 |
| 2675 |  | Qualification Testing Framework Readiness Confirmed | 0d | 2025-03-28 A | 2025-03-28 A | 2674 | 100% |  | start no earlier than 2025-03-28 |
| 2676 |  | Qualification Testing Wave Readiness Confirmed | 0d | 2025-08-21 A | 2025-08-21 A | 2708FS-2d | 100% |  | finish no earlier than 2025-05-30 |
| 2677 | 1.8.4.1.7 | **Wave Allocation** | 129d | 2024-01-02 A | 2024-06-28 A |  | 100% |  |  |
| 2678 |  | Draft Pre-Qualification Submission (PQS) document | 20d | 2024-01-02 A | 2024-01-29 A |  | 100% |  | finish no earlier than 2024-01-26 |
| 2679 |  | Publish PQS document | 1d | 2024-01-31 A | 2024-01-31 A |  | 100% |  | start no earlier than 2024-01-31 |
| 2680 |  | PQS Submission window | 60d | 2024-02-05 A | 2024-04-26 A |  | 100% |  | start no earlier than 2024-02-05 |
| 2681 |  | Pre-Qualification Submission and PIT Test Plan Deadline for Submission​ | 0d | 2024-04-26 A | 2024-04-26 A | 2680 | 100% |  |  |
| 2682 |  | PQS Review by Code Bodies | 25d | 2024-04-29 A | 2024-05-31 A | 2680, 2681 | 100% |  |  |
| 2683 |  | Draft Wave Allocations | 15d | 2024-06-03 A | 2024-06-21 A | 2682 | 100% |  |  |
| 2684 |  | Confirmation of participant Qualification Wave allocation | 0d | 2024-06-28 A | 2024-06-28 A | 2683FS+5d | 100% |  |  |
| 2685 | 1.8.4.2 | **Qualification Wave 1** | 248d | 2025-05-05 A | 2026-04-15 |  | 96% | 32014d |  |
| 2686 | 1.8.4.2.1 | **Qualification Wave 1 QAD Prep** | 80d | 2025-05-05 A | 2025-08-22 A |  | 100% |  |  |
| 2687 |  | Initial QAD Submission window opens | 0d | 2025-05-05 A | 2025-05-05 A | 2684, 2448FS+1d | 100% |  | start no earlier than 2025-03-24 |
| 2688 |  | Qualification Wave 1 Participants Submit Initial QAD | 50d | 2025-05-05 A | 2025-07-11 A | 2687FS-1d | 100% |  |  |
| 2689 |  | Minimum threshold of Qualification Wave 1 Participants required for QT start have submitted their initial QAD | 0d | 2025-07-14 A | 2025-07-14 A | 2688FS+1d | 100% |  |  |
| 2690 |  | All Qualification Wave 1 Participants have submitted their initial QAD | 0d | 2025-07-14 A | 2025-07-14 A | 2689 | 100% |  | start no earlier than 2025-07-14 |
| 2691 |  | Code Bodies review of Wave 1 Participants Initial QAD | 30d | 2025-07-14 A | 2025-08-22 A | 2688FS-1d, 2689FS-1d | 100% |  |  |
| 2692 |  | Completion of Code Bodies review of Initial QAD | 0d | 2025-08-22 A | 2025-08-22 A | 2691 | 100% |  |  |
| 2693 | 1.8.4.2.2 | **Qualification Wave 1 Test Prep** | 60d | 2025-05-26 A | 2025-08-15 A |  | 100% |  |  |
| 2694 |  | Confirmation from Qualification Wave 1 Participants that DIP onboarding has commenced | 0d | 2025-05-26 A | 2025-05-26 A |  | 100% |  | start no earlier than 2025-05-26 |
| 2695 |  | Qualification Wave 1 Participants DIP Onboarding Window | 35d | 2025-05-26 A | 2025-07-11 A | 2694 | 100% |  |  |
| 2696 |  | Confirmation from Qualification Wave 1 Participants that DIP onboarding has completed | 0d | 2025-07-11 A | 2025-07-11 A | 2695 | 100% |  |  |
| 2697 |  | Minimum threshold of Qualification Wave 1 Participants' required for QT start to provide status of PIT completion and submit QT Test Plan | 0d | 2025-07-14 A | 2025-07-14 A |  | 100% |  | start no earlier than 2025-07-14 |
| 2698 |  | All Qualification Wave 1 Participants' to provide status of PIT completion and submit QT Test Plan | 0d | 2025-07-14 A | 2025-07-14 A | 2697 | 100% |  | start no earlier than 2025-07-14 |
| 2699 |  | Review of Participants' PIT Status and QT Test Plan | 45d | 2025-06-16 A | 2025-08-15 A |  | 100% |  | start no earlier than 2025-06-16 |
| 2700 |  | Minimum threshold of Qualification Test Plans for Wave 1 Participants required for QT start approved | 0d | 2025-08-15 A | 2025-08-15 A | 2699 | 100% |  |  |
| 2701 |  | All Qualification Test Plans for Wave 1 Participants approved | 0d | 2025-08-15 A | 2025-08-15 A | 2700 | 100% |  | start no earlier than 2025-08-15 |
| 2702 |  | Minimum threshold of Qualification Wave 1 Participants required for QT start have submitted PIT Test Completion Report and evidence for QT Entry | 0d | 2025-07-14 A | 2025-07-14 A |  | 100% |  | start no earlier than 2025-07-14 |
| 2703 |  | Qualification Wave 1 Participants have submitted PIT Test Completion Report and evidence for QT Entry | 0d | 2025-07-14 A | 2025-07-14 A | 2702 | 100% |  | start no earlier than 2025-07-14 |
| 2704 |  | Review of Participants PIT Test Completion Report | 25d | 2025-07-14 A | 2025-08-15 A | 2702 | 100% |  |  |
| 2705 |  | Onboarding to QTF & ADO | 25d | 2025-07-14 A | 2025-08-15 A | 2704SS | 100% |  |  |
| 2706 | 1.8.4.2.3 | **Qualification Wave 1 QT Execution** | 100d | 2025-08-18 A | 2026-01-02 A |  | 100% |  |  |
| 2707 |  | Review Entry Criteria Evidence for each Wave 1 Participant | 5d | 2025-08-18 A | 2025-08-22 A | 2692FF, 2696, 2700, 2704 | 100% |  |  |
| 2708 |  | Minimum threshold of Qualification Wave 1 Participant Test required for QT start Readiness Confirmed | 0d | 2025-08-22 A | 2025-08-22 A | 2691, 2692, 2707FF | 100% |  |  |
| 2709 |  | All Qualification Wave 1 Participant Test Readiness Confirmed | 0d | 2025-08-22 A | 2025-08-22 A | 2708 | 100% |  | start no earlier than 2025-08-22 |
| 2710 |  | Qualification Wave 1 QT Execution Start | 0d | 2025-08-25 A | 2025-08-25 A | 2708FS+1d, 2705, 2653 | 100% |  | start no earlier than 2025-07-14 |
| 2711 |  | Qualification Wave 1 QT Execution Window | 95d | 2025-08-25 A | 2026-01-02 A | 2710FS-1d | 100% |  |  |
| 2712 |  | Qualification Wave 1 QT Projected Execution End | 0d | 2026-01-02 A | 2026-01-02 A | 2711 | 100% |  |  |
| 2713 | 1.8.4.2.4 | **Qualification Wave 1 Exit** | 168d | 2025-08-25 A | 2026-04-15 |  | 89% | 32014d |  |
| 2714 |  | Assurance on PP Test Completion Report | 10d | 2026-01-05 A | 2026-01-16 A | 2712 | 100% |  |  |
| 2715 |  | Final QAD Submission window opens | 0d | 2025-08-25 A | 2025-08-25 A | 2710 | 100% |  |  |
| 2716 |  | Qualification Wave 1 Participants submit their Final QAD | 105d | 2025-08-25 A | 2026-01-16 A | 2715FS-1d, 2714FF | 100% |  |  |
| 2717 |  | 80% of M14 Critical Qualification Wave 1 Participants have submitted their final QAD | 0d | 2026-01-16 A | 2026-01-16 A | 2716, 2712 | 100% |  |  |
| 2718 |  | All Qualification Wave 1 Participants have submitted their final QAD | 0d | 2026-01-16 A | 2026-01-16 A | 2717 | 100% |  | start no earlier than 2026-01-16 |
| 2719 |  | Completion of Code Bodies review of Final QAD | 35d | 2026-01-19 A | 2026-03-06 | 2716, 2717 | 55% | 0.3d |  |
| 2720 |  | QAD Sign Off deadline | 1d | 2026-03-20 A | 2026-03-20 | 2719FS+9d | 30% | 32008d |  |
| 2721 |  | 80% of M14 Critical Wave 1 Participants Qualification approved by BSC PAB and REC Manager | 0d | 2026-04-15 | 2026-04-15 |  |  | 32014d | finish no earlier than 2026-04-15 |
| 2722 |  | All M14 Critical Wave 1 Participants Qualification approved by BSC PAB and REC Manager | 0d | 2026-04-15 | 2026-04-15 | 2720FS+18d, 2690, 2709, 2718 |  | 32008d |  |
| 2723 | 1.8.4.3 | **Qualification Wave 2** | 254d | 2025-06-09 A | 2026-05-28 |  | 78% | 31983d |  |
| 2724 | 1.8.4.3.1 | **Qualification Wave 2 QAD Prep** | 95d | 2025-06-09 A | 2025-10-17 |  | 97% | 32142d |  |
| 2725 |  | Initial QAD Submission window opens | 0d | 2025-06-09 A | 2025-06-09 A | 2449FS+1d | 100% |  |  |
| 2726 |  | Qualification Wave 2 Participants Submit Initial QAD | 70d | 2025-06-09 A | 2025-09-12 A | 2725FS-1d | 100% |  |  |
| 2727 |  | Minimum threshold of Qualification Wave 2 Participants required for QT start have submitted their initial QAD | 0d | 2025-09-12 A | 2025-09-12 A | 2726 | 100% |  |  |
| 2728 |  | All Qualification Wave 2 Participants have submitted their initial QAD | 0d | 2025-09-12 A | 2025-09-12 A | 2727 | 100% |  | start no earlier than 2025-09-12 |
| 2729 |  | Code Bodies review of Wave 2 Participants' Initial QAD | 25d | 2025-09-15 A | 2025-10-17 | 2727 | 90% | 32142d |  |
| 2730 |  | Completion of Code Bodies review of Initial QAD | 0d | 2025-10-17 | 2025-10-17 | 2729 |  | 32142d |  |

| ID | WBS | Task | Duration | Start | Finish | Predecessors | Complete | Total float | Constraint |
| --- | --- | --- | --- | --- | --- | --- | --- | --- | --- |
| 2731 | 1.8.4.3.2 | **Qualification Wave 2 Test Prep** | 60d | 2025-07-21 A | 2025-10-10 A |  | 100% |  |  |
| 2732 |  | Confirmation from Qualification Wave 2 Participants that DIP Onboarding has commenced | 0d | 2025-07-21 A | 2025-07-21 A |  | 100% |  | start no earlier than 2025-07-21 |
| 2733 |  | Qualification Wave 2 Participants DIP Onboarding Window | 35d | 2025-07-21 A | 2025-09-05 A | 2732 | 100% |  |  |
| 2734 |  | Confirmation from Qualificiation Wave 2 Participants that DIP onboarding has completed | 0d | 2025-09-05 A | 2025-09-05 A | 2733 | 100% |  |  |
| 2735 |  | Minimum threshold of Qualification Wave 2 Participants' required for QT start to provide status of PIT completion and submit QT Test Plan | 0d | 2025-08-18 A | 2025-08-18 A |  | 100% |  | start no earlier than 2025-08-18 |
| 2736 |  | All Qualification Wave 2 Participants' to provide status of PIT completion and submit QT Test Plan | 0d | 2025-08-18 A | 2025-08-18 A | 2735 | 100% |  |  |
| 2737 |  | Review of Participants' PIT Status and QT Test Plan | 15d | 2025-08-18 A | 2025-09-05 A | 2735 | 100% |  | start no earlier than 2025-07-07 |
| 2738 |  | Minimum threshold of Qualification Test Plans for Wave 2 Participants required for QT start approved | 0d | 2025-09-05 A | 2025-09-05 A | 2737 | 100% |  | start no earlier than 2025-07-25 |
| 2739 |  | All Qualification Test Plans for Wave 2 Participants approved | 0d | 2025-09-05 A | 2025-09-05 A | 2738 | 100% |  |  |
| 2740 |  | Minimum threshold of Qualification Wave 2 Participants required for QT start have submitted PIT Test Completion Report and evidence for QT entry | 0d | 2025-09-08 A | 2025-09-08 A |  | 100% |  | start no earlier than 2025-09-08 |
| 2741 |  | All Qualification Wave 2 Participants have submitted PIT Test Completion Report and evidence for QT entry | 0d | 2025-09-08 A | 2025-09-08 A | 2740 | 100% |  |  |
| 2742 |  | Review of Participants' PIT Test Completion Report | 25d | 2025-09-08 A | 2025-10-10 A | 2740 | 100% |  |  |
| 2743 |  | Onboarding to QTF & ADO | 25d | 2025-09-08 A | 2025-10-10 A | 2742SS | 100% |  |  |
| 2744 | 1.8.4.3.3 | **Qualification Wave 2 QT Execution** | 95d | 2025-10-13 A | 2026-02-20 |  | 99% | 31987d |  |
| 2745 |  | Review Entry Criteria Evidence for each Wave 2 Participant | 5d | 2025-10-13 A | 2025-10-17 A | 2730FF, 2734, 2738, 2742 | 100% |  |  |
| 2746 |  | Minimum threshold of Qualification Wave 2 Participant required for QT start Test Readiness Confirmed | 0d | 2025-10-17 A | 2025-10-17 A | 2745, 2730 | 100% |  |  |
| 2747 |  | All Qualification Wave 2 Participant Test Readiness Confirmed | 0d | 2025-10-17 A | 2025-10-17 A | 2746 | 100% |  |  |
| 2748 |  | Qualification Wave 2 Execution Start | 0d | 2025-10-20 A | 2025-10-20 A | 2746FS+1d, 2743, 2658 | 100% |  |  |
| 2749 |  | Qualification Wave 2 QT Execution Window | 90d | 2025-10-20 A | 2026-02-20 | 2748SS-1d | 99% | 31987d |  |
| 2750 |  | Qualfication Wave 2 QT Execution End | 0d | 2026-02-20 | 2026-02-20 | 2749 |  | 31987d |  |
| 2751 | 1.8.4.3.4 | **Qualification Wave 2 Exit** | 159d | 2025-10-20 A | 2026-05-28 |  | 33% | 31983d |  |
| 2752 |  | Assurance on PP Test Completion Report | 10d | 2026-02-23 A | 2026-03-06 A | 2750 | 100% |  |  |
| 2753 |  | Final QAD Submission window opens | 0d | 2025-10-20 A | 2025-10-20 A | 2748 | 100% |  |  |
| 2754 |  | Qualification Wave 2 Participants submit their Final QAD | 100d | 2025-10-20 A | 2026-03-06 | 2753FS-1d, 2752FF | 35% | 31977d |  |
| 2755 |  | 80% of M14 Critical Qualification Wave 2 Participants have submitted their final QAD | 0d | 2026-03-06 | 2026-03-06 | 2754, 2750 |  | 31977d |  |
| 2756 |  | All Qualification Wave 2 Participants have submitted their final QAD | 0d | 2026-03-06 | 2026-03-06 | 2755 |  | 32036d |  |
| 2757 |  | Completion of Code Bodies review of Final QAD | 26d | 2026-03-09 | 2026-04-13 | 2755 |  | 31977d |  |
| 2758 |  | QAD Sign Off deadline | 1d | 2026-04-20 | 2026-04-20 | 2757FS+4d |  | 31977d |  |
| 2759 |  | 80% of M14 Critical Wave 2 Participants Qualification approved by BSC PAB and REC Manager | 0d | 2026-05-28 | 2026-05-28 |  |  | 31984d | start no earlier than 2026-05-28 |
| 2760 |  | All M14 Critical Wave 2 Participants Qualification approved by BSC PAB and REC Manager | 0d | 2026-05-28 | 2026-05-28 | 2758FS+28d, 2728, 2736, 2741, 2747, 2756 |  | 31977d |  |
| 2761 | 1.8.4.4 | **Qualification Wave 3** | 254d? | 2025-08-11 A | 2026-07-30 |  | 52% | 31938d |  |
| 2762 | 1.8.4.4.1 | **Qualification Wave 3 QAD Prep** | 95d | 2025-08-11 A | 2025-12-19 |  | 98% | 32097d |  |
| 2763 |  | Initial QAD Submission window opens | 0d | 2025-08-11 A | 2025-08-11 A | 2450FS+1d | 100% |  |  |
| 2764 |  | Qualification Wave 3 Participants Submit Initial QAD | 65d | 2025-08-11 A | 2025-11-07 A | 2763FS-1d | 100% |  |  |
| 2765 |  | Minimum threshold of Qualification Wave 3 Participants required for QT start have submitted their initial QAD | 0d | 2025-11-07 A | 2025-11-07 A | 2764 | 100% |  |  |
| 2766 |  | All Qualification Wave 3 Participants have submitted their initial QAD | 0d | 2025-11-07 A | 2025-11-07 A | 2765 | 100% |  | start no earlier than 2025-11-07 |
| 2767 |  | Code Bodies review of Wave 3 Participants' Initial QAD | 30d | 2025-11-10 A | 2025-12-19 | 2765 | 93% | 32097d |  |
| 2768 |  | Completion of Code Bodies review of Initial QAD | 0d | 2025-12-19 | 2025-12-19 | 2767 |  | 32097d |  |
| 2769 | 1.8.4.4.2 | **Qualification Wave 3 Test Prep** | 65d | 2025-09-15 A | 2025-12-12 |  | 82% | 32102d |  |
| 2770 |  | Confirmation from Qualification Wave 3 Participants that DIP Onboarding has commenced | 0d | 2025-09-15 A | 2025-09-15 A |  | 100% |  | start no earlier than 2025-09-15 |
| 2771 |  | Qualification Wave 3 Participants DIP Onboarding window | 35d | 2025-09-15 A | 2025-10-31 A | 2770 | 100% |  | start no earlier than 2025-08-04 |
| 2772 |  | Confirmation from Qualification Wave 3 Participants that DIP onboarding has completed | 0d | 2025-10-31 A | 2025-10-31 A | 2771 | 100% |  | start no earlier than 2025-09-22 |
| 2773 |  | Minimum threshold of Qualification Wave 3 Participants' required for QT start to provide status of PIT completion and submit QT Test Plan | 0d | 2025-10-20 A | 2025-10-20 A |  | 100% |  | start no earlier than 2025-10-20 |
| 2774 |  | All Qualification Wave 3 Participants' to provide status of PIT completion and submit QT Test Plan | 0d | 2025-10-20 A | 2025-10-20 A | 2773 | 100% |  | start no earlier than 2025-10-20 |
| 2775 |  | Review of Participants' PIT Status and QT Test Plan | 15d | 2025-10-20 A | 2025-11-07 A | 2773 | 100% |  | start no earlier than 2025-09-08 |
| 2776 |  | Minimum threshold of Qualification Test Plans for Wave 3 Participants required for QT start approved | 0d | 2025-11-07 A | 2025-11-07 A | 2775 | 100% |  | start no earlier than 2025-09-26 |
| 2777 |  | All Qualification Test Plans for Wave 3 Participants approved | 0d | 2025-11-07 A | 2025-11-07 A | 2776 | 100% |  | start no earlier than 2025-11-07 |
| 2778 |  | Minimum threshold of Qualification Wave 3 Participants required for QT start have submitted PIT Test Completion Report and evidence for QT Entry | 0d | 2025-11-10 A | 2025-11-10 A |  | 100% |  | start no earlier than 2025-11-10 |
| 2779 |  | All Qualification Wave 3 Participants have submitted PIT Test Completion Report and evidence for QT Entry | 0d | 2025-11-10 A | 2025-11-10 A | 2778 | 100% |  | start no earlier than 2025-11-10 |
| 2780 |  | Review of Participants' PIT Test Completion Report | 25d | 2025-11-10 A | 2025-12-12 | 2778 | 28% | 32102d | start no earlier than 2025-09-29 |
| 2781 |  | Onboarding to QTF & ADO | 25d | 2025-11-10 A | 2025-12-12 A | 2780SS | 100% |  | finish no earlier than 2025-10-31 |
| 2782 | 1.8.4.4.3 | **Qualification Wave 3 QT Execution** | 110d? | 2025-12-15 A | 2026-05-15 |  | 41% |  |  |
| 2783 |  | Review Entry Criteria Evidence for each Wave 3 Participant | 5d | 2025-12-15 A | 2025-12-19 A | 2772, 2768FF, 2781 | 100% |  | start no earlier than 2025-11-03 |
| 2784 |  | Minimum threshold of Qualification Wave 3 Participant required for QT start Test Readiness confirmed | 0d | 2025-12-19 A | 2025-12-19 A | 2772, 2783 | 100% |  |  |
| 2785 |  | All Qualification Wave 3 Participant Test Readiness confirmed | 0d | 2025-12-19 A | 2025-12-19 A | 2784 | 100% |  |  |
| 2786 |  | Qualification Wave 3 Execution Start | 0d | 2026-01-12 A | 2026-01-12 A | 2784FS+16d, 2781FS+1d, 2663 | 100% |  | start no earlier than 2025-11-03 |
| 2787 |  | Qualification Wave 3 QT Execution Window | 85d | 2026-01-12 A | 2026-05-08 | 2783, 2786FS-1d | 38% | 31932d |  |
| 2788 |  | Qualification Wave 3 Projected Execution End | 0d | 2026-05-08 | 2026-05-08 | 2787 |  | 31932d |  |
| 2789 | 1.8.4.4.4 | **Qualification Wave 3 Exit** | 144d | 2026-01-12 A | 2026-07-30 |  | 2% | 31938d |  |
| 2790 |  | Assurance on PP Test Completion Report | 10d | 2026-05-11 | 2026-05-22 | 2788 |  | 31932d |  |
| 2791 |  | Final QAD Submission window opens | 0d | 2026-01-12 A | 2026-01-12 A | 2786 | 100% |  |  |
| 2792 |  | Qualification Wave 3 Participants submit their Final QAD | 95d | 2026-01-12 A | 2026-05-22 | 2791FS-1d, 2790FF | 2% | 31932d |  |
| 2793 |  | 80% of M14 Critical Qualification Wave 3 Participants have submitted their Final QAD | 0d | 2026-05-22 | 2026-05-22 | 2792, 2788 |  | 31932d |  |
| 2794 |  | All Qualification Wave 3 Participants have submitted their Final QAD | 0d | 2026-05-22 | 2026-05-22 | 2793 |  | 31981d | finish no earlier than 2026-05-22 |
| 2795 |  | Completion of Code Bodies review of Final QAD | 20d | 2026-05-25 | 2026-06-19 | 2793 |  | 31932d |  |
| 2796 |  | QAD Sign Off deadline | 1d | 2026-06-26 | 2026-06-26 | 2795FS+4d |  | 31932d |  |
| 2797 |  | 80% of M14 Critical Wave 3 Participants Qualification approved by BSC PAB and REC Manager | 0d | 2026-07-30 | 2026-07-30 |  |  | 31939d | start no earlier than 2026-07-30 |
| 2798 |  | All M14 Critical Wave 3 Participants Qualification approved by BSC PAB and REC Manager | 0d | 2026-07-30 | 2026-07-30 | 2796FS+24d, 2766, 2774, 2779, 2785, 2794 |  | 31932d |  |
| 2799 | 1.8.4.5 | **Qualification Wave 4** | 526d | 2025-01-23 A | 2027-01-28 |  | 29% | 31808d |  |
| 2800 | 1.8.4.5.1 | **Qualification Wave 4 QAD Prep** | 95d | 2025-10-20 A | 2026-02-27 |  | 83% | 31808d |  |

| ID | WBS | Task | Duration | Start | Finish | Predecessors | Complete | Total float | Constraint |
| --- | --- | --- | --- | --- | --- | --- | --- | --- | --- |
| 2801 |  | Initial QAD Submission window opens | 0d | 2025-10-20 A | 2025-10-20 A | 2451FS+1d | 100% |  |  |
| 2802 |  | Qualification Wave 4 Participants Submit Initial QAD | 65d | 2025-10-20 A | 2026-01-16 | 2801FS-1d | 98% | 15d |  |
| 2803 |  | Qualification Wave 4 Participants have submitted their Initial QAD | 0d | 2026-01-16 | 2026-01-16 | 2802 |  | 15d |  |
| 2804 |  | Code Bodies review of Wave 4 Participants' Initial QAD | 30d | 2026-01-19 A | 2026-02-27 | 2803 | 50% | 31808d |  |
| 2805 |  | Completion of Code Bodies review of Initial QAD | 0d | 2026-02-27 | 2026-02-27 | 2804 |  | 31808d |  |
| 2806 | 1.8.4.5.2 | **Qualification Wave 4 Test Prep** | 75d | 2025-11-03 A | 2026-02-13 |  | 41% | 31824d |  |
| 2807 |  | Confirmation from Qualification 4 Participants that DIP Onboarding has commenced | 0d | 2025-11-03 A | 2025-11-03 A |  | 100% |  | start no earlier than 2025-11-03 |
| 2808 |  | Qualification Wave 4 Participants DIP Onboarding Window | 35d | 2025-11-03 A | 2025-12-19 | 2807 | 81% | 31858d |  |
| 2809 |  | Confirmation from Qualification Wave 4 Participants that DIP onboarding has completed | 0d | 2025-12-19 | 2025-12-19 | 2808 |  | 31858d |  |
| 2810 |  | Qualification Wave 4 Participants' to provide status of PIT completion and submit QT Test Plan | 0d | 2025-12-08 | 2025-12-08 |  |  | 17.25d | start no earlier than 2025-12-08 |
| 2811 |  | Review of Participants' PIT Status and QT Test Plan | 25d | 2025-12-08 A | 2026-01-09 | 2810 | 69% | 31824d |  |
| 2812 |  | Qualification Test Plans for Qualification Wave 4 Participants approved | 0d | 2026-01-09 | 2026-01-09 | 2811 |  | 31824d |  |
| 2813 |  | Qualification Wave 4 Participants have submitted PIT Test Completion Report and evidence for QT entry | 0d | 2026-01-09 | 2026-01-09 | 2812 |  | 31824d |  |
| 2814 |  | Review of Participants' PIT Test Completion Report | 25d | 2026-01-12 | 2026-02-13 | 2813 |  | 31824d |  |
| 2815 |  | Onboarding to QTF & ADO | 25d | 2026-01-12 | 2026-02-13 | 2814SS |  | 31824d | start no earlier than 2025-11-24 |
| 2816 | 1.8.4.5.3 | **Qualification Wave 4 QT Execution** | 95d | 2026-03-02 | 2026-07-10 |  |  | 31808d |  |
| 2817 |  | Review Entry Criteria Evidence for each Wave 4 Participant | 5d | 2026-03-02 | 2026-03-06 | 2805FF+5d, 2809 |  | 31808d |  |
| 2818 |  | Qualification Wave 4 Participant Test Readiness Confirmed | 0d | 2026-03-06 | 2026-03-06 | 2809, 2817 |  | 31808d |  |
| 2819 |  | Qualification Wave 4 QT Execution Start | 0d | 2026-03-09 | 2026-03-09 | 2818FS+1d, 2815, 2668 |  | 31808d | start no earlier than 2026-01-07 |
| 2820 |  | Qualification Wave 4 QT Execution Window | 90d | 2026-03-09 | 2026-07-10 | 2819FS-1d, 2817 |  | 31808d |  |
| 2821 |  | Qualification Wave 4 Projected Execution End | 0d | 2026-07-10 | 2026-07-10 | 2820 |  | 31808d |  |
| 2822 | 1.8.4.5.4 | **Qualification Wave 4 Exit** | 144d | 2026-03-09 | 2026-09-24 |  |  | 31808d |  |
| 2823 |  | Assurance on PP Test Completion Report | 10d | 2026-07-13 | 2026-07-24 | 2821 |  | 31808d |  |
| 2824 |  | Final QAD Submission window opens | 0d | 2026-03-09 | 2026-03-09 | 2819 |  | 31808d |  |
| 2825 |  | Qualification Wave 4 Participants submit their Final QAD | 100d | 2026-03-09 | 2026-07-24 | 2824FS-1d, 2823FF |  | 31808d |  |
| 2826 |  | Qualification Wave 4 Participants have submitted their Final QAD | 0d | 2026-07-24 | 2026-07-24 | 2825, 2821 |  | 31808d |  |
| 2827 |  | Completion of Code Bodies review of Final QAD | 20d | 2026-07-27 | 2026-08-21 | 2826 |  | 31808d |  |
| 2828 |  | QAD Sign Off deadline | 1d | 2026-08-28 | 2026-08-28 | 2827FS+4d |  | 31808d |  |
| 2829 |  | Qualification Wave 4 Participants Qualification approved by BSC PAB and REC Manager | 0d | 2026-09-24 | 2026-09-24 | 2828FS+19d |  | 31808d |  |
| 2830 | 1.8.4.5.5 | **Qualification Tier 1 Milestone** | 66d | 2026-10-28 | 2027-01-28 |  |  | 31808d |  |
| 2831 |  | All suppliers must be able to access MPANs under the new TOM (M14) | 0d | 2026-10-28 | 2026-10-28 | 2829FS+24d |  | 31808d | start no earlier than 2026-03-12 |
| 2832 |  | All suppliers must be able to access MPANs under the new TOM (M14*) - Late Exit | 0d | 2027-01-28 | 2027-01-28 | 2831FS+66d |  | 31808d |  |
| 2833 | 1.8.4.5.6 | **PAB dates** | 490d | 2025-01-23 A | 2026-12-09 |  | 99% | 31844d |  |
| 2834 |  | PAB288 | 0d | 2025-01-23 A | 2025-01-23 A |  | 100% |  | start no earlier than 2025-01-23 |
| 2835 |  | PAB289 | 2d | 2025-02-26 A | 2025-02-27 A |  | 100% |  | start no earlier than 2025-02-26 |
| 2836 |  | PAB290 | 0d | 2025-03-12 A | 2025-03-12 A |  | 100% |  | start no earlier than 2025-03-12 |
| 2837 |  | PAB291 | 0d | 2025-03-27 A | 2025-03-27 A |  | 100% |  | start no earlier than 2025-03-27 |
| 2838 |  | PAB292 | 0d | 2025-04-09 A | 2025-04-09 A |  | 100% |  | start no earlier than 2025-04-09 |
| 2839 |  | PAB293 | 0d | 2025-04-24 A | 2025-04-24 A |  | 100% |  | start no earlier than 2025-04-24 |
| 2840 |  | PAB294 | 0d | 2025-05-14 A | 2025-05-14 A |  | 100% |  | start no earlier than 2025-05-14 |
| 2841 |  | PAB295 | 0d | 2025-05-29 A | 2025-05-29 A |  | 100% |  | start no earlier than 2025-05-29 |
| 2842 |  | PAB296 | 0d | 2025-06-11 A | 2025-06-11 A |  | 100% |  | start no earlier than 2025-06-11 |
| 2843 |  | PAB297 | 0d | 2025-06-26 A | 2025-06-26 A |  | 100% |  | start no earlier than 2025-06-26 |
| 2844 |  | PAB298 | 0d | 2025-07-16 A | 2025-07-16 A |  | 100% |  | start no earlier than 2025-07-16 |
| 2845 |  | PAB299 | 0d | 2025-07-31 A | 2025-07-31 A |  | 100% |  | start no earlier than 2025-07-31 |
| 2846 |  | PAB300 | 0d | 2025-08-13 A | 2025-08-13 A |  | 100% |  | start no earlier than 2025-08-13 |
| 2847 |  | PAB301 | 2d | 2025-08-27 A | 2025-08-28 A |  | 100% |  | start no earlier than 2025-08-27 |
| 2848 |  | PAB302 | 0d | 2025-09-10 A | 2025-09-10 A |  | 100% |  | start no earlier than 2025-09-10 |
| 2849 |  | PAB303 | 0d | 2025-09-25 A | 2025-09-25 A |  | 100% |  | start no earlier than 2025-09-25 |
| 2850 |  | PAB304 | 0d | 2025-10-15 A | 2025-10-15 A |  | 100% |  | start no earlier than 2025-10-15 |
| 2851 |  | PAB305 | 0d | 2025-10-30 A | 2025-10-30 A |  | 100% |  | start no earlier than 2025-10-30 |
| 2852 |  | PAB306 | 0d | 2025-11-12 A | 2025-11-12 A |  | 100% |  | start no earlier than 2025-11-12 |
| 2853 |  | PAB307 | 0d | 2025-11-27 A | 2025-11-27 A |  | 100% |  | start no earlier than 2025-11-27 |
| 2854 |  | PAB308 | 0d | 2025-12-18 A | 2025-12-18 A |  | 100% |  | start no earlier than 2025-12-18 |
| 2855 |  | PAB2026/01 | 0d | 2026-01-29 A | 2026-01-29 A |  | 100% |  | finish no earlier than 2026-01-29 |
| 2856 |  | PAB2026/02 | 0d | 2026-02-11 A | 2026-02-11 A |  | 100% |  | finish no earlier than 2026-02-11 |
| 2857 |  | PAB2026/03 | 0d | 2026-02-26 | 2026-02-26 |  |  | 32048d | finish no earlier than 2026-02-26 |
| 2858 |  | PAB2026/04 | 0d | 2026-03-11 | 2026-03-11 |  |  | 32039d | finish no earlier than 2026-03-11 |
| 2859 |  | PAB2026/05 | 0d | 2026-03-26 | 2026-03-26 |  |  | 32028d | finish no earlier than 2026-03-26 |
| 2860 |  | PAB2026/06 | 0d | 2026-04-15 | 2026-04-15 |  |  | 32014d | finish no earlier than 2026-04-15 |
| 2861 |  | PAB2026/07 | 0d | 2026-04-30 | 2026-04-30 |  |  | 32003d | finish no earlier than 2026-04-30 |
| 2862 |  | PAB2026/08 | 0d | 2026-05-13 | 2026-05-13 |  |  | 31994d | finish no earlier than 2026-05-13 |
| 2863 |  | PAB2026/09 | 0d | 2026-05-28 | 2026-05-28 |  |  | 31983d | finish no earlier than 2026-05-28 |
| 2864 |  | PAB2026/10 | 0d | 2026-06-10 | 2026-06-10 |  |  | 31974d | finish no earlier than 2026-06-10 |
| 2865 |  | PAB2026/11 | 0d | 2026-06-25 | 2026-06-25 |  |  | 31963d | finish no earlier than 2026-06-25 |
| 2866 |  | PAB2026/12 | 0d | 2026-07-15 | 2026-07-15 |  |  | 31949d | finish no earlier than 2026-07-15 |
| 2867 |  | PAB2026/13 | 0d | 2026-07-30 | 2026-07-30 |  |  | 31938d | finish no earlier than 2026-07-30 |
| 2868 |  | PAB2026/14 | 0d | 2026-08-12 | 2026-08-12 |  |  | 31929d | finish no earlier than 2026-08-12 |
| 2869 |  | PAB2026/15 | 0d | 2026-08-27 | 2026-08-27 |  |  | 31918d | finish no earlier than 2026-08-27 |
| 2870 |  | PAB2026/16 | 0d | 2026-09-09 | 2026-09-09 |  |  | 31909d | finish no earlier than 2026-09-09 |

| ID | WBS | Task | Duration | Start | Finish | Predecessors | Complete | Total float | Constraint |
| --- | --- | --- | --- | --- | --- | --- | --- | --- | --- |
| 2871 |  | PAB2026/17 | 0d | 2026-09-24 | 2026-09-24 |  |  | 31898d | finish no earlier than 2026-09-24 |
| 2872 |  | PAB2026/18 | 0d | 2026-10-14 | 2026-10-14 |  |  | 31884d | finish no earlier than 2026-10-14 |
| 2873 |  | PAB2026/19 | 0d | 2026-10-29 | 2026-10-29 |  |  | 31873d | finish no earlier than 2026-10-29 |
| 2874 |  | PAB2026/20 | 0d | 2026-11-11 | 2026-11-11 |  |  | 31864d | finish no earlier than 2026-11-11 |
| 2875 |  | PAB2026/21 | 0d | 2026-11-26 | 2026-11-26 |  |  | 31853d | finish no earlier than 2026-11-26 |
| 2876 |  | PAB2026/22 | 0d | 2026-12-09 | 2026-12-09 |  |  | 31844d | finish no earlier than 2026-12-09 |
| 2877 | 1.9 | **REGULATORY** | 823d | 2022-10-31 A | 2025-12-24 A |  | 100% |  |  |
| 2878 | 1.9.1 | **Baseline MHHS Code Changes** | 475d | 2022-10-31 A | 2024-08-23 A |  | 100% |  |  |
| 2879 | 1.9.1.1 | **Preparation and planning** | 35d | 2022-10-31 A | 2022-12-16 A |  | 100% |  |  |
| 2880 |  | Impact assessment of Programme design on codes to determine required changes | 20d | 2022-10-31 A | 2022-11-25 A | 47 | 100% |  |  |
| 2881 |  | Become 'code draft ready' | 35d | 2022-10-31 A | 2022-12-16 A |  | 100% |  |  |
| 2882 |  | Soft start drafting where possible | 35d | 2022-10-31 A | 2022-12-16 A |  | 100% |  |  |
| 2883 | 1.9.1.2 | **Code drafting** | 443d | 2022-12-12 A | 2024-08-21 A |  | 100% |  |  |
| 2884 | 1.9.1.2.1 | **Data Services (BSC driven)** | 118d | 2022-12-12 A | 2023-05-24 A |  | 100% |  |  |
| 2885 |  | Pre Code Drafting activities | 5d | 2022-12-12 A | 2022-12-16 A |  | 100% |  | start no earlier than 2022-12-12 |
| 2886 |  | Code and subsidiary document drafting takes place offline | 19d | 2023-01-03 A | 2023-01-27 A | 2885FS+11d | 100% |  |  |
| 2887 |  | Internal review and cross-checking of drafting across code drafters | 11d | 2023-01-30 A | 2023-02-13 A | 2886 | 100% |  |  |
| 2888 |  | External industry review via consultation | 20d | 2023-02-14 A | 2023-03-13 A | 2887 | 100% |  |  |
| 2889 |  | Triage and action comments | 19d | 2023-03-10 A | 2023-04-05 A | 2888FS-2d | 100% |  |  |
| 2890 |  | CDWG review | 30d | 2023-04-06 A | 2023-05-17 A | 2889 | 100% |  |  |
| 2891 |  | CCAG review | 5d | 2023-05-18 A | 2023-05-24 A | 2890 | 100% |  |  |
| 2892 |  | Code drafting for Data Services topic area approved | 0d | 2023-05-24 A | 2023-05-24 A | 2891 | 100% |  |  |
| 2893 | 1.9.1.2.2 | **Metering (REC driven)** | 118d | 2022-12-12 A | 2023-05-24 A |  | 100% |  |  |
| 2894 |  | Pre Code Drafting activities | 5d | 2022-12-12 A | 2022-12-16 A | 2885SS | 100% |  |  |
| 2895 |  | Code and subsidiary document drafting takes place offline | 19d | 2023-01-03 A | 2023-01-27 A | 2894FS+11d | 100% |  |  |
| 2896 |  | Internal review and cross-checking of drafting across code drafters | 11d | 2023-01-30 A | 2023-02-13 A | 2895 | 100% |  |  |
| 2897 |  | External industry review via consultation | 20d | 2023-02-14 A | 2023-03-13 A | 2896 | 100% |  |  |
| 2898 |  | Triage and action comments | 19d | 2023-03-10 A | 2023-04-05 A | 2897FS-2d | 100% |  |  |
| 2899 |  | CDWG review | 30d | 2023-04-06 A | 2023-05-17 A | 2898 | 100% |  |  |
| 2900 |  | CCAG review | 5d | 2023-05-18 A | 2023-05-24 A | 2899 | 100% |  |  |
| 2901 |  | Code drafting for Metering topic area approved | 0d | 2023-05-24 A | 2023-05-24 A | 2900 | 100% |  |  |
| 2902 | 1.9.1.2.3 | **BSC Central Services (BSC driven)** | 156d | 2023-02-22 A | 2023-09-27 A |  | 100% |  |  |
| 2903 |  | Pre Code Drafting activities | 5d | 2023-02-22 A | 2023-02-28 A | 2904SS-5d | 100% |  |  |
| 2904 |  | Code Drafting (offline) | 80d | 2023-03-01 A | 2023-06-20 A | 2888SS | 100% |  | must start on 2023-03-01 |
| 2905 |  | Internal review and cross-checking of drafting across code drafters | 70d | 2023-03-15 A | 2023-06-20 A | 2904SS+10d | 100% |  |  |
| 2906 |  | External industry review via consultation | 15d | 2023-06-21 A | 2023-07-11 A | 2905 | 100% |  |  |
| 2907 |  | Triage and action comments | 19d | 2023-07-10 A | 2023-08-03 A | 2906FS-2d | 100% |  |  |
| 2908 |  | CDWG review | 28d | 2023-08-04 A | 2023-09-12 A | 2907 | 100% |  |  |
| 2909 |  | CCAG review | 11d | 2023-09-13 A | 2023-09-27 A | 2908 | 100% |  |  |
| 2910 |  | Code drafting for BSC Central Services topic area approved | 0d | 2023-09-27 A | 2023-09-27 A | 2909 | 100% |  |  |
| 2911 | 1.9.1.2.4 | **Registration (BSC & REC driven)** | 131d | 2023-02-22 A | 2023-08-23 A |  | 100% |  |  |
| 2912 |  | Pre Code Drafting activities | 5d | 2023-02-22 A | 2023-02-28 A | 2913SS-5d | 100% |  |  |
| 2913 |  | Code Drafting (offline) | 65d | 2023-03-01 A | 2023-05-30 A | 2887, 2896 | 100% |  | must start on 2023-03-01 |
| 2914 |  | Internal review and cross-checking of drafting across code drafters | 55d | 2023-03-15 A | 2023-05-30 A | 2913SS+10d | 100% |  |  |
| 2915 |  | External industry review via consultation | 15d | 2023-05-31 A | 2023-06-20 A | 2914 | 100% |  |  |
| 2916 |  | Triage and action comments | 19d | 2023-06-19 A | 2023-07-13 A | 2915FS-2d | 100% |  |  |
| 2917 |  | CDWG review | 18d | 2023-07-14 A | 2023-08-08 A | 2916 | 100% |  |  |
| 2918 |  | CCAG review | 11d | 2023-08-09 A | 2023-08-23 A | 2917 | 100% |  |  |
| 2919 |  | Code drafting for Registration topic area approved | 0d | 2023-08-23 A | 2023-08-23 A | 2918 | 100% |  |  |
| 2920 | 1.9.1.2.5 | **Governance and Qualification (BSC & REC driven)** | 130d | 2023-05-25 A | 2023-11-22 A |  | 100% |  |  |
| 2921 |  | Pre Code Drafting activities | 5d | 2023-05-25 A | 2023-05-31 A | 2922SS-5d | 100% |  |  |
| 2922 |  | Code Drafting (offline) | 55d | 2023-06-01 A | 2023-08-16 A | 2915SS+1d | 100% |  |  |
| 2923 |  | Internal review and cross-checking of drafting across code drafters | 45d | 2023-06-15 A | 2023-08-16 A | 2922SS+10d | 100% |  |  |
| 2924 |  | External industry review via consultation | 15d | 2023-08-18 A | 2023-09-07 A | 2923FS+1d | 100% |  |  |
| 2925 |  | Triage and action comments | 19d | 2023-09-06 A | 2023-10-02 A | 2924FS-2d | 100% |  |  |
| 2926 |  | CDWG review | 31d | 2023-10-03 A | 2023-11-14 A | 2925 | 100% |  |  |
| 2927 |  | CCAG review | 6d | 2023-11-15 A | 2023-11-22 A | 2926 | 100% |  |  |
| 2928 |  | Code drafting for Governance and Qualification topic areas approved | 0d | 2023-11-22 A | 2023-11-22 A | 2927 | 100% |  |  |
| 2929 | 1.9.1.2.6 | **Interfaces / Data Specification (REC driven)** | 174d | 2023-05-25 A | 2024-01-23 A |  | 100% |  |  |
| 2930 |  | Pre Code Drafting activities | 5d | 2023-05-25 A | 2023-05-31 A | 2931SS-5d | 100% |  |  |
| 2931 |  | Code Drafting (offline) | 94d | 2023-06-01 A | 2023-10-10 A | 2915SS+1d | 100% |  |  |
| 2932 |  | Internal review and cross-checking of drafting across code drafters | 84d | 2023-06-15 A | 2023-10-10 A | 2931SS+10d | 100% |  |  |
| 2933 |  | External industry review via consultation | 15d | 2023-10-11 A | 2023-10-31 A | 2932 | 100% |  |  |
| 2934 |  | Triage and action comments | 20d | 2023-10-30 A | 2023-11-24 A | 2933FS-2d | 100% |  |  |
| 2935 |  | CDWG review | 37d | 2023-11-27 A | 2024-01-16 A | 2934 | 100% |  |  |
| 2936 |  | CCAG review | 5d | 2024-01-17 A | 2024-01-23 A | 2935 | 100% |  |  |
| 2937 |  | Code drafting for Interfaces / Data Specification topic areas approved | 0d | 2024-01-23 A | 2024-01-23 A | 2936 | 100% |  |  |
| 2938 | 1.9.1.2.7 | **Migration (BSC & REC driven)** | 130d | 2023-05-25 A | 2023-11-22 A |  | 100% |  |  |
| 2939 |  | Pre Code Drafting activities | 5d | 2023-05-25 A | 2023-05-31 A | 2940SS-5d | 100% |  |  |
| 2940 |  | Code Drafting (offline) | 55d | 2023-06-01 A | 2023-08-16 A | 2915SS+1d | 100% |  |  |

| ID | WBS | Task | Duration | Start | Finish | Predecessors | Complete | Constraint |
| --- | --- | --- | --- | --- | --- | --- | --- | --- |
| 2941 |  | Internal review and cross-checking of drafting across code drafters | 45d | 2023-06-15 A | 2023-08-16 A | 2940SS+10d | 100% |  |
| 2942 |  | External industry review via consultation | 15d | 2023-08-18 A | 2023-09-07 A | 2941FS+1d | 100% |  |
| 2943 |  | Triage and action comments | 19d | 2023-09-06 A | 2023-10-02 A | 2942FS-2d | 100% |  |
| 2944 |  | CDWG review | 31d | 2023-10-03 A | 2023-11-14 A | 2943 | 100% |  |
| 2945 |  | CCAG review | 6d | 2023-11-15 A | 2023-11-22 A | 2944 | 100% |  |
| 2946 |  | Code drafting for Migration topic area approved | 0d | 2023-11-22 A | 2023-11-22 A | 2945 | 100% |  |
| 2947 | 1.9.1.2.8 | **Consequential Code Change** | 109d | 2023-10-11 A | 2024-03-11 A |  | 100% |  |
| 2948 |  | External industry review via consultation - drop 1 (DCUSA) | 15d | 2023-10-11 A | 2023-10-31 A | 2954SS | 100% |  |
| 2949 |  | External industry review via consultation - drop 2 (Elexon) | 16d | 2024-02-19 A | 2024-03-11 A | 2964SS | 100% | start no earlier than 2024-02-19 |
| 2950 | 1.9.1.2.9 | **Transition Text (all codes)** | 118d | 2023-08-11 A | 2024-01-23 A |  | 100% |  |
| 2951 |  | Pre Code Drafting activities | 8d | 2023-08-11 A | 2023-08-22 A | 2952SS-5d | 100% |  |
| 2952 |  | Code Drafting (offline) | 38d | 2023-08-18 A | 2023-10-10 A | 2942SS | 100% |  |
| 2953 |  | Internal review and cross-checking of drafting across code drafters | 28d | 2023-09-01 A | 2023-10-10 A | 2952SS+10d | 100% |  |
| 2954 |  | External industry review via consultation | 15d | 2023-10-11 A | 2023-10-31 A | 2953 | 100% |  |
| 2955 |  | Triage and action comments | 20d | 2023-10-30 A | 2023-11-24 A | 2954FS-2d | 100% |  |
| 2956 |  | CDWG review | 37d | 2023-11-27 A | 2024-01-16 A | 2955 | 100% |  |
| 2957 |  | CCAG review | 5d | 2024-01-17 A | 2024-01-23 A | 2956 | 100% |  |
| 2958 |  | Code drafting for Transition Text topic area approved | 0d | 2024-01-23 A | 2024-01-23 A | 2957 | 100% |  |
| 2959 | 1.9.1.2.10 | **Final Code Drafting (mop-up) (all codes)** | 199d | 2023-08-18 A | 2024-05-22 A |  | 100% |  |
| 2960 |  | Forward look and confirm remaining plan | 15d | 2023-08-18 A | 2023-09-07 A | 2952SS | 100% |  |
| 2961 |  | Identify remaining or additional areas of code (e.g. consequential change requirements) to be completed | 15d | 2023-08-18 A | 2023-09-07 A | 2960SS | 100% |  |
| 2962 |  | Code Drafting (offline) Interim Consultation (1) | 60d | 2023-09-08 A | 2023-11-30 A | 2961 | 100% |  |
| 2963 |  | Internal review and cross-checking of drafting across code drafters Interim Consultation (1) | 50d | 2023-09-22 A | 2023-11-30 A | 2962SS+10d | 100% |  |
| 2964 |  | External industry review via consultation Interim Consultation (1) | 23d | 2023-12-01 A | 2024-01-02 A | 2963 | 100% |  |
| 2965 |  | Code Drafting (offline) Final Consultation (2) | 55d | 2023-12-01 A | 2024-02-15 A | 2963 | 100% |  |
| 2966 |  | Internal review and cross-checking of drafting across code drafters Final Consultation (2) | 45d | 2023-12-15 A | 2024-02-15 A | 2965SS+10d | 100% |  |
| 2967 |  | External industry review via consultation Final Consultation (2) | 16d | 2024-02-19 A | 2024-03-11 A | 2966FS+1d | 100% |  |
| 2968 |  | Triage and action comments | 18d | 2024-03-11 A | 2024-04-03 A | 2967FS-1d | 100% |  |
| 2969 |  | CDWG review | 29d | 2024-04-04 A | 2024-05-14 A | 2968 | 100% |  |
| 2970 |  | CCAG review | 6d | 2024-05-15 A | 2024-05-22 A | 2969 | 100% |  |
| 2971 |  | Final code drafting (mop-up) approved | 0d | 2024-05-22 A | 2024-05-22 A | 2970 | 100% |  |
| 2972 | 1.9.1.2.11 | **Final code review, consistency check and approval** | 100d | 2024-04-04 A | 2024-08-21 A |  | 100% |  |
| 2973 |  | Gap analysis of final code against design artefacts (reverse process to code drafting) | 38d | 2024-04-04 A | 2024-05-27 A | 2969SS | 100% |  |
| 2974 |  | Outputs of gap analysis actioned offline | 11d | 2024-05-28 A | 2024-06-11 A | 2973 | 100% |  |
| 2975 |  | Final documentation collated for final consultation | 8d | 2024-06-12 A | 2024-06-21 A | 2974 | 100% |  |
| 2976 |  | External industry review via consultation | 15d | 2024-06-24 A | 2024-07-12 A | 2975 | 100% |  |
| 2977 |  | Triage and action comments | 10d | 2024-07-15 A | 2024-07-26 A | 2976 | 100% |  |
| 2978 |  | Final CDWG review | 8d | 2024-08-02 A | 2024-08-13 A | 2977FS+4d | 100% |  |
| 2979 |  | Final CCAG review | 6d | 2024-08-14 A | 2024-08-21 A | 2978 | 100% |  |
| 2980 |  | CCAG recommend final code to PSG for baselining | 0d | 2024-08-21 A | 2024-08-21 A | 2979 | 100% |  |
| 2981 |  | Code changes baselined (M6) | 0d | 2024-08-23 A | 2024-08-23 A | 2979FS+2d, 2971, 2958, 2946, 2937, 2928, 2919, 2910, 2901, 2892 | 100% |  |
| 2982 | 1.9.2 | **Ofgem preparation and enactment of SCR powers** | 225d | 2024-02-05 A | 2024-12-13 A |  | 100% |  |
| 2983 | 1.9.2.1 | **Preparation and enactment of SCR Powers** | 223d | 2024-02-05 A | 2024-12-11 A |  | 100% |  |
| 2984 |  | Ofgem to keep Ofgem legal informed of process followed and nature of Code drafting to ensure that prepared for SCR go/no go decision | 101d | 2024-02-05 A | 2024-06-24 A | 2985SF | 100% |  |
| 2985 |  | OFGEM Legal to review Code Artefacts deliver policy intent and process followed and confirm that SCR powers are appropriate to use rather than SMAP - SCR go/no go | 14d | 2024-06-24 A | 2024-07-11 A | 2976SS | 100% |  |
| 2986 |  | Code Bodies to draft MOD proposal forms | 20d | 2024-07-12 A | 2024-08-08 A | 2985 | 100% |  |
| 2987 |  | Ofgem discuss and agree code mod timetable with code bodies (and MHHSP in relation to the dates for expected decisions) | 20d | 2024-07-12 A | 2024-08-08 A | 2985 | 100% |  |
| 2988 |  | Ofgem to publish each Direction to each code body specifying the timetable for each modification | 1d | 2024-08-28 A | 2024-08-28 A | 2987FS+13d | 100% |  |
| 2989 |  | Formally submit (by separate email) Modification Proposal Forms and legal texts to each code body | 1d | 2024-08-28 A | 2024-08-28 A | 2987FS+13d | 100% |  |
| 2990 |  | Each Code Body publishes and issues Modification Proposal Forms | 3d | 2024-08-29 A | 2024-09-02 A | 2989, 2988 | 100% |  |
| 2991 |  | Each Code Body sends Modification Proposal Forms to Panel to approve Mod to go to consultation | 10d | 2024-09-03 A | 2024-09-16 A | 2990 | 100% |  |
| 2992 |  | Modification Proposal approved by Panel for Consultation | 1d | 2024-09-17 A | 2024-09-17 A | 2991 | 100% |  |
| 2993 |  | Draft Modification Report issued for consultation | 1d | 2024-09-18 A | 2024-09-18 A | 2992 | 100% |  |
| 2994 |  | Consultation Close-out for representations | 15d | 2024-09-19 A | 2024-10-09 A | 2993 | 100% |  |
| 2995 |  | Each Code Body reviews consultation response and drafts Modification Report | 10d | 2024-10-10 A | 2024-10-23 A | 2994 | 100% |  |
| 2996 |  | Final Modification Report sent to Panel for decision with recommendation to approve | 1d | 2024-10-24 A | 2024-10-24 A | 2995 | 100% |  |
| 2997 |  | Modification Panel decision | 1d | 2024-11-07 A | 2024-11-07 A | 2996FS+9d | 100% |  |
| 2998 |  | Code Bodies Submit Final Modification/Change Reports | 1d | 2024-11-08 A | 2024-11-08 A | 2997 | 100% |  |
| 2999 |  | Ofgem Reviews Final Modification/Change Reports | 10d | 2024-11-11 A | 2024-11-22 A | 2998 | 100% |  |
| 3000 |  | Ofgem Drafts Decision/Direction Letters | 17d | 2024-11-18 A | 2024-12-10 A | 2999SS+5d | 100% |  |
| 3001 |  | Ofgem Internally Signs Off the Decision/Direction Letters and Sends Them to the Code Bodies | 1d | 2024-12-11 A | 2024-12-11 A | 3000 | 100% |  |
| 3002 |  | Ofgem decisions on M6 baselined code modification proposals (M7) | 0d | 2024-12-11 A | 2024-12-11 A | 2981, 3001 | 100% |  |
| 3003 |  | Ofgem Publishes the Decisions/Directions | 2d | 2024-12-12 A | 2024-12-13 A | 3002 | 100% |  |
| 3004 | 1.9.3 | **Deliver MHHS Code Changes** | 292d | 2024-11-12 A | 2025-12-24 A |  | 100% |  |
| 3005 | 1.9.3.1 | **Releases** | 78d | 2024-11-12 A | 2025-02-27 A |  | 100% |  |
| 3006 |  | Impacted codes make resourcing provisions and prepare to implement new Code via internal code body change processes | 78d | 2024-11-12 A | 2025-02-27 A |  | 100% | start no earlier than 2024-11-12 |
| 3007 | 1.9.3.2 | **M8 Code Change Preperation** | 155d | 2025-01-31 A | 2025-09-05 A |  | 100% |  |
| 3008 |  | Resources confirmed | 0d | 2025-01-31 A | 2025-01-31 A |  | 100% | finish no earlier than 2025-01-31 |
| 3009 |  | CDWG Endorsement | 0d | 2025-06-10 A | 2025-06-10 A |  | 100% | finish no earlier than 2025-06-10 |
| 3010 |  | CCAG Endorsement | 0d | 2025-06-25 A | 2025-06-25 A |  | 100% | finish no earlier than 2025-06-25 |

| ID | WBS | Task | Duration | Start | Finish | Predecessors | Complete | Total float | Constraint |
| --- | --- | --- | --- | --- | --- | --- | --- | --- | --- |
| 3011 |  | Send to Ofgem for SCR Direction | 0d | 2025-06-25 A | 2025-06-25 A |  | 100% |  | finish no earlier than 2025-06-25 |
| 3012 |  | Freeze M8 Change Control Log 1.0 and create V2.0 | 0d | 2025-07-02 A | 2025-07-02 A |  | 100% |  | finish no earlier than 2025-07-02 |
| 3013 |  | Agree Fast Track Code Change Process | 0d | 2025-07-02 A | 2025-07-02 A |  | 100% |  | finish no earlier than 2025-07-02 |
| 3014 |  | Ofgem direct SCR Code change | 0d | 2025-07-03 A | 2025-07-03 A |  | 100% |  | finish no earlier than 2025-07-03 |
| 3015 |  | Present to Panel | 0d | 2025-07-10 A | 2025-07-10 A |  | 100% |  | finish no earlier than 2025-07-10 |
| 3016 |  | Code Change Industry Consultation | 0d | 2025-07-29 A | 2025-07-29 A |  | 100% |  | finish no earlier than 2025-07-29 |
| 3017 |  | Panel Recommendation | 0d | 2025-08-14 A | 2025-08-14 A |  | 100% |  | finish no earlier than 2025-08-14 |
| 3018 |  | Ofgem Decision | 0d | 2025-09-05 A | 2025-09-05 A |  | 100% |  | finish no earlier than 2025-09-05 |
| 3019 | 1.9.3.3 | **Main Code Release** | 73d | 2025-09-15 A | 2025-12-24 A |  | 100% |  |  |
| 3020 |  | Release preparation (e.g. preparing release documentation) | 6d | 2025-09-15 A | 2025-09-22 A | 3021SF | 100% |  |  |
| 3021 |  | Implement new code on day of code release | 0d | 2025-09-22 A | 2025-09-22 A | 3022SF | 100% |  |  |
| 3022 |  | Code changes delivered (M8) | 0d | 2025-09-22 A | 2025-09-22 A | 3002, 2981, 1802SS-3d, 3018 | 100% |  | finish no earlier than 2025-09-22 |
| 3023 |  | Code changes delivered (M8*) late exit | 0d | 2025-12-24 A | 2025-12-24 A | 3022FS+67d | 100% |  |  |
| 3024 | 1.9.4 | **External Programme Dependency Management** | 38d | 2023-12-01 A | 2024-01-24 A |  | 100% |  |  |
| 3025 | 1.9.4.1 | **DCP397** | 38d | 2023-12-01 A | 2024-01-24 A |  | 100% |  |  |
| 3026 |  | Ensure DCP397 drafting included in mop-up code drafting activity (link to mop-up) | 20d | 2023-12-01 A | 2023-12-28 A | 2965SS, 2962SS | 100% |  |  |
| 3027 |  | Implementation of DCP397 | 0d | 2024-01-24 A | 2024-01-24 A |  | 100% |  | start no earlier than 2024-01-24 |
| 3028 | 1.10 | **MIGRATION** | 1246d? | 2022-10-31 A | 2027-08-09 |  | 90% | 31671d |  |
| 3029 | 1.10.1 | **Regulatory Governance** | 500d | 2024-04-01 A | 2026-02-27 |  | 96% | 32047d |  |
| 3030 |  | Incentive Mods Created | 110d | 2024-04-01 A | 2024-08-30 A |  | 100% |  | start no earlier than 2024-04-01 |
| 3031 |  | BSC Panel Ruling | 0d | 2025-06-12 A | 2025-06-12 A | 3030 | 100% |  | finish no earlier than 2025-06-12 |
| 3032 |  | Ofgem Incentives Approval | 186d | 2025-06-13 A | 2026-02-27 | 3031 | 94% | 32047d | finish no earlier than 2026-02-27 |
| 3033 |  | Incentives Implementation | 0d | 2026-02-27 | 2026-02-27 | 3032 |  | 32047d | finish no earlier than 2026-02-27 |
| 3034 | 1.10.2 | **Migration Framework Agreed and Implemented** | 324d? | 2024-02-01 A | 2025-04-29 A |  | 100% |  |  |
| 3035 | 1.10.2.1 | **Consultation 1 - Schedule** | 70d | 2024-02-01 A | 2024-05-08 A |  | 100% |  |  |
| 3036 |  | Prepare Artefacts for Consultation | 33d | 2024-02-01 A | 2024-03-18 A |  | 100% |  |  |
| 3037 |  | Industry Consultation | 16d | 2024-03-18 A | 2024-04-08 A |  | 100% |  |  |
| 3038 |  | Triage and Action Comments | 10d | 2024-04-08 A | 2024-04-19 A |  | 100% |  |  |
| 3039 |  | Industry Assurance Review | 6d | 2024-04-19 A | 2024-04-26 A |  | 100% |  |  |
| 3040 |  | MWG Recommendation | 1d | 2024-04-26 A | 2024-04-26 A |  | 100% |  |  |
| 3041 |  | MCAG Interim Approval Artefacts | 1d | 2024-05-08 A | 2024-05-08 A |  | 100% |  |  |
| 3042 | 1.10.2.2 | **Consultation 2 - Control** | 79d | 2024-04-08 A | 2024-07-25 A |  | 100% |  |  |
| 3043 |  | Prepare Artefacts for Consultation | 49d | 2024-04-08 A | 2024-06-13 A |  | 100% |  |  |
| 3044 |  | Industry Consultation | 11d | 2024-06-14 A | 2024-06-28 A | 3043 | 100% |  |  |
| 3045 |  | Triage and Action Comments | 9d | 2024-07-01 A | 2024-07-11 A | 3044 | 100% |  |  |
| 3046 |  | Industry Assurance Review | 5d | 2024-07-12 A | 2024-07-18 A | 3045 | 100% |  |  |
| 3047 |  | MWG Recommendation | 0d | 2024-07-18 A | 2024-07-18 A | 3046 | 100% |  |  |
| 3048 |  | Consultation 2 - Control - MCAG Approval of Interim Artefacts | 0d | 2024-07-25 A | 2024-07-25 A | 3047FS+5d | 100% |  |  |
| 3049 | 1.10.2.3 | **Consultation 3 - Parameters** | 71d | 2024-11-18 A | 2025-02-25 A |  | 100% |  |  |
| 3050 |  | Prepare Artefacts for Consultation | 24d | 2024-11-18 A | 2024-12-19 A |  | 100% |  |  |
| 3051 |  | Industry Consultation | 21d | 2024-12-20 A | 2025-01-17 A | 3050 | 100% |  |  |
| 3052 |  | Triage Response | 10d | 2025-01-20 A | 2025-01-31 A | 3051 | 100% |  |  |
| 3053 |  | MWG paper day | 0d | 2025-02-06 A | 2025-02-06 A | 3052 | 100% |  | start no earlier than 2025-02-06 |
| 3054 |  | MWG Recommendation | 0d | 2025-02-13 A | 2025-02-13 A | 3053FS+6d | 100% |  |  |
| 3055 |  | MCAG Paper Day | 0d | 2025-02-18 A | 2025-02-18 A | 3054FS+3d | 100% |  |  |
| 3056 |  | MCAG Approval of Consultation 3 | 0d | 2025-02-25 A | 2025-02-25 A | 3054, 3055 | 100% |  | start no earlier than 2025-02-25 |
| 3057 | 1.10.2.4 | **Consultation 4** | 72d? | 2025-01-20 A | 2025-04-29 A |  | 100% |  |  |
| 3058 |  | Agree Consultation 4 Plan | 15d | 2025-01-20 A | 2025-02-07 A |  | 100% |  |  |
| 3059 |  | Book MWG | 0d | 2025-02-07 A | 2025-02-07 A | 3058 | 100% |  |  |
| 3060 |  | Prepare Consultation 4 content | 9d | 2025-02-10 A | 2025-02-20 A | 3059 | 100% |  |  |
| 3061 |  | MWG paper day | 0d | 2025-02-20 A | 2025-02-20 A | 3060 | 100% |  |  |
| 3062 |  | MWG recommend Consultation 4 content go for industry consultation | 0d | 2025-03-04 A | 2025-03-04 A | 3061FS+8d | 100% |  |  |
| 3063 |  | Industry Consultation | 10d? | 2025-03-03 A | 2025-03-14 A | 3060 | 100% |  | finish no earlier than 2025-03-14 |
| 3064 |  | Comment responses by PPs | 10d? | 2025-03-17 A | 2025-03-28 A | 3063 | 100% |  | finish no earlier than 2025-03-28 |
| 3065 |  | Respond to comments and issue artefacts | 10d? | 2025-03-31 A | 2025-04-11 A | 3064 | 100% |  | finish no earlier than 2025-04-11 |
| 3066 |  | Assurance meeting | 0d | 2025-04-22 A | 2025-04-22 A | 3065FS+5d | 100% |  | finish no earlier than 2025-04-22 |
| 3067 |  | MCAG paper day | 0d | 2025-04-22 A | 2025-04-22 A | 3066 | 100% |  | finish no earlier than 2025-04-22 |
| 3068 |  | MCAG Approval of Consultation 4 | 0d | 2025-04-29 A | 2025-04-29 A | 3067FS+5d | 100% |  | finish no earlier than 2025-04-29 |
| 3069 |  | Framework Baselined at MCAG | 0d | 2025-04-29 A | 2025-04-29 A | 3068 | 100% |  | finish no earlier than 2025-04-29 |
| 3070 | 1.10.3 | **Migration Schedule Agreed and Maintained** | 125d? | 2024-07-01 A | 2024-12-20 A |  | 100% |  |  |
| 3071 |  | Schedule Production | 125d? | 2024-07-01 A | 2024-12-20 A |  | 100% |  | start no earlier than 2024-11-18 |
| 3072 |  | Schedule Production Complete | 0d | 2024-12-20 A | 2024-12-20 A | 3071 | 100% |  |  |
| 3073 | 1.10.4 | **V1.0 of Migration Schedule Baseline** | 81d | 2025-04-01 A | 2025-07-22 A |  | 100% |  |  |
| 3074 |  | Confirm Supplier Migration start dates, MPID groups (SIT & NonSIT) | 0d | 2025-04-01 A | 2025-04-01 A |  | 100% |  | start no earlier than 2025-04-01 |
| 3075 |  | V1.0 of Migration Schedule Baseline Approved at MCAG | 0d | 2025-07-22 A | 2025-07-22 A | 3074FS+81d | 100% |  |  |
| 3076 | 1.10.5 | **Supplier Submission Support** | 38d? | 2025-04-25 A | 2025-06-18 A |  | 100% |  |  |
| 3077 |  | Support guides issued | 1d? | 2025-04-25 A | 2025-04-25 A |  | 100% |  | start no earlier than 2025-04-25 |
| 3078 |  | Envelope webinar | 0d | 2025-05-02 A | 2025-05-02 A | 3077FS+5d | 100% |  |  |
| 3079 |  | De-minimus webinar | 0d | 2025-05-02 A | 2025-05-02 A | 3078 | 100% |  |  |
| 3080 |  | Drop-in session 1 | 0d | 2025-05-14 A | 2025-05-14 A | 3079FS+8d | 100% |  |  |

| ID | WBS | Task | Duration | Start | Finish | Predecessors | Complete | Total float | Constraint |
| --- | --- | --- | --- | --- | --- | --- | --- | --- | --- |
| 3081 |  | Drop-in session 2 | 0d | 2025-05-28 A | 2025-05-28 A | 3080FS+10d | 100% |  |  |
| 3082 |  | Drop-in session 3 | 0d | 2025-06-11 A | 2025-06-11 A | 3081FS+5d | 100% |  | start no earlier than 2025-06-11 |
| 3083 |  | Drop-in session 4 | 0d | 2025-06-18 A | 2025-06-18 A | 3082FS+5d | 100% |  | start no earlier than 2025-06-18 |
| 3084 | 1.10.6 | **MCC Stood up** | 265d? | 2024-11-18 A | 2025-11-21 A |  | 100% |  |  |
| 3085 |  | Migration Planning Management Tool Delivery | 265d | 2024-11-18 A | 2025-11-21 A |  | 100% |  |  |
| 3086 | 1.10.6.2 | **MCC Operational** | 98d | 2025-04-23 A | 2025-09-05 A |  | 100% |  |  |
| 3087 | 1.10.6.2.1 | **MCC Dress Rehersal 1 - Initialise Schedule (Weekly) Drop 1, 2** | 65d | 2025-04-23 A | 2025-07-22 A |  | 100% |  |  |
| 3088 |  | Issue Dress Rehearsal support information to all Suppliers (SIT & Non-SIT) | 0d | 2025-04-23 A | 2025-04-23 A |  | 100% |  | start no earlier than 2025-04-23 |
| 3089 |  | Kestrel Webinar 1 | 0d | 2025-04-23 A | 2025-04-23 A | 3088 | 100% |  |  |
| 3090 |  | Onboard and connectivity testing - Dress Rehearsal with Suppliers (All SIT and Wave 1 mandatory) | 0d | 2025-04-25 A | 2025-04-25 A | 3089FS+3d | 100% |  |  |
| 3091 |  | Test Scripts shared with Participants | 0d | 2025-06-02 A | 2025-06-02 A |  | 100% |  | start no earlier than 2025-06-02 |
| 3092 |  | Dress rehearsal 1 start | 0d | 2025-06-09 A | 2025-06-09 A |  | 100% |  | start no earlier than 2025-06-09 |
| 3093 |  | Supplier Schedule Submission #2 complete | 1d | 2025-06-20 A | 2025-06-20 A |  | 100% |  | start no earlier than 2025-06-20 |
| 3094 |  | Consolidate baseline schedule | 15d | 2025-06-23 A | 2025-07-11 A | 3093 | 100% |  |  |
| 3095 |  | Consolidated baseline schedule published to industry | 0d | 2025-07-11 A | 2025-07-11 A | 3094 | 100% |  |  |
| 3096 |  | Baselined Schedule available for download | 1d | 2025-07-14 A | 2025-07-14 A | 3095 | 100% |  |  |
| 3097 |  | Test execution report (weekly) | 0d | 2025-07-15 A | 2025-07-15 A |  | 100% |  |  |
| 3098 |  | Dress rehearsal completion report | 0d | 2025-07-15 A | 2025-07-15 A | 3097, 3094 | 100% |  |  |
| 3099 |  | MCC Dress Rehersal 1 - complete | 0d | 2025-07-15 A | 2025-07-15 A | 3098 | 100% |  |  |
| 3100 |  | MCAG approval of Baseline Migration schedule | 0d | 2025-07-22 A | 2025-07-22 A | 3099 | 100% |  | finish no earlier than 2025-07-22 |
| 3101 | 1.10.6.2.2 | **MCC Dress Rehersal 2 - complete** | 40d | 2025-07-14 A | 2025-09-05 A |  | 100% |  |  |
| 3102 |  | Issue Dress Rehearsal support information to Participants | 0d | 2025-07-14 A | 2025-07-14 A |  | 100% |  | start no earlier than 2025-07-14 |
| 3103 |  | Kestrel Webinar 1 | 0d | 2025-07-14 A | 2025-07-14 A | 3102 | 100% |  |  |
| 3104 |  | Kestrel Webinar 2 | 0d | 2025-08-06 A | 2025-08-06 A |  | 100% |  | finish no earlier than 2025-08-06 |
| 3105 |  | Onboard and connectivity testing - Dress Rehearsal with Suppliers (remaining suppliers and non-supplier PPs) | 0d | 2025-08-11 A | 2025-08-11 A | 3103FS+6d | 100% |  | start no earlier than 2025-08-11 |
| 3106 | 1.10.6.2.2.5 | **MCC Dress Rehersal 2** | 20d | 2025-08-11 A | 2025-09-05 A | 3105 | 100% |  |  |
| 3107 |  | MCC Dress Rehersal 2 start | 1d | 2025-08-11 A | 2025-08-11 A |  | 100% |  | finish no earlier than 2025-08-11 |
| 3108 |  | Test execution report (weekly) | 20d | 2025-08-11 A | 2025-09-05 A |  | 100% |  | finish no earlier than 2025-08-11 |
| 3109 |  | Dress rehearsal completion report available | 0d | 2025-09-05 A | 2025-09-05 A | 3108 | 100% |  | finish no earlier than 2025-08-29 |
| 3110 |  | PPs return test scripts | 0d | 2025-09-05 A | 2025-09-05 A |  | 100% |  | finish no earlier than 2025-09-05 |
| 3111 |  | MCC Dress Rehearsal 2 - complete | 0d | 2025-09-05 A | 2025-09-05 A | 3109 | 100% |  | finish no earlier than 2025-09-05 |
| 3112 |  | MCC Operational Complete | 0d | 2025-09-05 A | 2025-09-05 A | 3101, 3111 | 100% |  | finish no earlier than 2025-08-29 |
| 3113 | 1.10.7 | **M11 Readiness Checkpoint** | 36d | 2025-08-29 A | 2025-10-20 A |  | 100% |  |  |
| 3114 |  | Supplier Readiness Assessments for Sprint 0 Day 1 | 20d | 2025-08-29 A | 2025-09-25 A |  | 100% |  | start no earlier than 2025-08-29 |
| 3115 |  | MCAG Approve Sprint 0 Day 1 Baseline Schedule | 0d | 2025-10-20 A | 2025-10-20 A |  | 100% |  | start no earlier than 2025-10-20 |
| 3116 | 1.10.7.3 | **Legacy Settlement run stability assessment** | 16d | 2025-09-26 A | 2025-10-17 A |  | 100% |  |  |
| 3117 |  | Legacy Settlement run stability assessment | 16d | 2025-09-26 A | 2025-10-17 A | 1802, 2306 | 100% |  | start no earlier than 2025-09-26 |
| 3118 |  | Checkpoint 1 | 0d | 2025-10-03 A | 2025-10-03 A |  | 100% |  | finish no earlier than 2025-10-03 |
| 3119 |  | Checkpoint 2 | 0d | 2025-10-10 A | 2025-10-10 A |  | 100% |  | finish no earlier than 2025-10-10 |
| 3120 |  | Checkpoint 3 | 0d | 2025-10-17 A | 2025-10-17 A |  | 100% |  | finish no earlier than 2025-10-17 |
| 3121 | 1.10.8 | **Migration Artefact Development and Publication** | 1043d | 2022-10-31 A | 2026-10-28 |  | 92% | 31874d |  |
| 3122 | 1.10.8.1 | **Migration Approach** | 28d | 2022-10-31 A | 2022-12-07 A |  | 100% |  |  |
| 3123 |  | Option analysis (via MWG and PPIR) and recommendation | 23d | 2022-10-31 A | 2022-11-30 A |  | 100% |  |  |
| 3124 |  | Migration Approach approved | 0d | 2022-12-07 A | 2022-12-07 A | 3123FS+5d | 100% |  |  |
| 3125 | 1.10.8.2 | **Migration Design** | 100d | 2022-11-14 A | 2023-03-31 A |  | 100% |  |  |
| 3126 |  | Review and update existing design artefacts and socialise with participants ahead of MDSG | 10d | 2022-11-14 A | 2022-11-25 A |  | 100% |  |  |
| 3127 |  | Develop design artefacts and supporting technical documents in line with MDSG | 53d | 2022-11-30 A | 2023-02-10 A | 3126FS+2d | 100% |  |  |
| 3128 |  | Migration design artefacts issued for consultation | 0d | 2023-02-13 A | 2023-02-13 A | 3127FS+1d | 100% |  |  |
| 3129 |  | Industry consultation | 5d | 2023-02-14 A | 2023-02-20 A | 3128SS | 100% |  |  |
| 3130 |  | Review consultation feedback, address comments and update artefacts | 5d | 2023-02-21 A | 2023-02-27 A | 3129 | 100% |  |  |
| 3131 |  | Internal artefact review and comms preparation | 3d | 2023-02-28 A | 2023-03-02 A | 3130 | 100% |  |  |
| 3132 |  | Updated Migration Design artefacts issued to PPs for assurance review | 0d | 2023-03-03 A | 2023-03-03 A | 3131FS+1d | 100% |  |  |
| 3133 |  | Final Migration Design artefacts walkthrough with PPs | 0d | 2023-03-22 A | 2023-03-22 A | 3132FS+13d | 100% |  |  |
| 3134 |  | Migration Design approved | 0d | 2023-03-31 A | 2023-03-31 A | 3133FS+7d | 100% |  |  |
| 3135 | 1.10.8.3 | **Transition Design** | 186d | 2023-03-01 A | 2023-11-15 A |  | 100% |  |  |
| 3136 | 1.10.8.3.1 | **Tranche 1** | 56d | 2023-03-01 A | 2023-05-17 A |  | 100% |  |  |
| 3137 |  | Develop design artefacts and supporting technical details with participants | 50d | 2023-03-01 A | 2023-05-09 A |  | 100% |  |  |
| 3138 |  | Issue Material for DAG approval | 1d | 2023-05-10 A | 2023-05-10 A | 3137 | 100% |  |  |
| 3139 |  | Tranche 1 Transition Design approved | 0d | 2023-05-17 A | 2023-05-17 A | 3138FS+5d | 100% |  |  |
| 3140 | 1.10.8.3.2 | **Tranche 2** | 130d | 2023-05-18 A | 2023-11-15 A |  | 100% |  |  |
| 3141 |  | Develop Initial design artefacts and supporting technical details | 76d | 2023-05-18 A | 2023-08-31 A | 3139 | 100% |  |  |
| 3142 |  | Communicate Initial Design Artefacts with Industry (MTDSG) | 1d | 2023-09-01 A | 2023-09-01 A | 3141 | 100% |  |  |
| 3143 |  | Host MTDSG | 1d | 2023-09-11 A | 2023-09-11 A | 3142FS+5d | 100% |  |  |
| 3144 |  | Process MTDSG Feedback and Amend Design Artefacts | 4d | 2023-09-12 A | 2023-09-15 A | 3143 | 100% |  |  |
| 3145 |  | Communicate Amended Design Artefacts with Industry | 1d | 2023-09-15 A | 2023-09-15 A | 3144FF | 100% |  |  |
| 3146 |  | Host MTDSG | 1d | 2023-09-26 A | 2023-09-26 A | 3145FS+6d | 100% |  |  |
| 3147 |  | Make Final Amendments to Design Artefact | 5d | 2023-09-27 A | 2023-10-03 A | 3146 | 100% |  |  |
| 3148 |  | Request DAG Consultation | 1d | 2023-10-04 A | 2023-10-04 A | 3147 | 100% |  |  |
| 3149 |  | Consultation Period | 11d | 2023-10-04 A | 2023-10-18 A | 3148SS | 100% |  |  |
| 3150 |  | Action Consultation Comments | 5d | 2023-10-19 A | 2023-10-25 A | 3149 | 100% |  |  |

| ID | WBS | Task | Duration | Start | Finish | Predecessors | Complete | Total float | Constraint |
| --- | --- | --- | --- | --- | --- | --- | --- | --- | --- |
| 3151 |  | Post Consultation Industry Assurance | 5d | 2023-10-26 A | 2023-11-01 A | 3150 | 100% |  |  |
| 3152 |  | Request DAG Approval | 1d | 2023-11-01 A | 2023-11-01 A | 3151FF | 100% |  |  |
| 3153 |  | DAG Transition Design Approved | 1d | 2023-11-08 A | 2023-11-08 A | 3152FS+4d | 100% |  |  |
| 3154 |  | Update Transition Design Admin | 5d | 2023-11-09 A | 2023-11-15 A | 3153 | 100% |  |  |
| 3155 |  | Tranche 2 Transition Design Baselined | 0d | 2023-11-15 A | 2023-11-15 A | 3154 | 100% |  |  |
| 3156 | 1.10.8.4 | **Data Assessment Report** | 61d | 2022-12-06 A | 2023-02-28 A |  | 100% |  |  |
| 3157 |  | Develop document with MWG | 49d | 2022-12-06 A | 2023-02-10 A |  | 100% |  |  |
| 3158 |  | Artefact review (via TMAG) and updates | 25d | 2023-01-18 A | 2023-02-21 A | 3157FS-18d | 100% |  |  |
| 3159 |  | Data Assessment Report approved | 0d | 2023-02-28 A | 2023-02-28 A | 3158FS+5d | 100% |  |  |
| 3160 | 1.10.8.5 | **Migration, Cutover & Data Strategy (incl. Migration Entry Criteria)** | 102d | 2022-12-08 A | 2023-04-28 A |  | 100% |  |  |
| 3161 |  | Develop document with MWG | 67d | 2022-12-08 A | 2023-03-10 A | 3124 | 100% |  |  |
| 3162 |  | Artefact review (via TMAG) and updates | 28d | 2023-03-15 A | 2023-04-21 A | 3161FS+2d | 100% |  |  |
| 3163 |  | Migration, Cutover & Data Strategy approved | 0d | 2023-04-28 A | 2023-04-28 A | 3162FF+5d | 100% |  |  |
| 3164 | 1.10.8.6 | **Data Cleanse Plan** | 670d | 2023-03-02 A | 2025-09-24 A |  | 100% |  |  |
| 3165 |  | Develop document with MWG | 50d | 2023-03-02 A | 2023-05-10 A |  | 100% |  |  |
| 3166 |  | Artefact review (via TMAG) and updates | 20d | 2023-05-11 A | 2023-06-07 A | 3165 | 100% |  |  |
| 3167 |  | Data Cleanse Plan approved | 0d | 2023-07-19 A | 2023-07-19 A | 3166FS+30d | 100% |  |  |
| 3168 |  | Monitor Programme Participant adherence to Data Cleanse Plan | 467d | 2023-06-15 A | 2025-03-28 A | 3167 | 100% |  |  |
| 3169 | 1.10.8.6.5 | **MTDs** | 241d | 2024-08-16 A | 2025-07-21 A |  | 100% |  |  |
| 3170 | 1.10.8.6.5.1 | **ESME ID** | 195d | 2024-08-16 A | 2025-05-16 A |  | 100% |  |  |
| 3171 |  | DCC to extract ESME ID and share with LDSO | 0d | 2024-08-16 A | 2024-08-16 A | 3167FS+282d | 100% |  |  |
| 3172 |  | LDSO ‘full refresh’ between their Registration Service and the EES (ESME ID) | 16d | 2024-10-21 A | 2024-11-11 A | 3171FS+45d | 100% |  |  |
| 3173 |  | Suppliers complete investigation of exceptions and resolution of exceptions | 1d | 2024-12-20 A | 2024-12-20 A | 3172FS+28d | 100% |  |  |
| 3174 |  | Suppliers complete Work Off plans | 105d | 2024-12-23 A | 2025-05-16 A | 3173 | 100% |  | start no earlier than 2024-12-23 |
| 3175 |  | ESME ID Complete | 0d | 2025-05-16 A | 2025-05-16 A | 3174 | 100% |  |  |
| 3176 | 1.10.8.6.5.2 | **Meter Location and Number of Displayed Register Digits** | 222d | 2024-09-13 A | 2025-07-21 A |  | 100% |  |  |
| 3177 |  | MEM to extract data and share with LDSO | 6d | 2024-09-13 A | 2024-09-20 A | 3167FS+301d | 100% |  |  |
| 3178 |  | LDSO ‘full refresh’ between their Registration Service and the EES (Meter Location and Number of Displayed Register Digits) | 16d | 2024-10-21 A | 2024-11-15 A | 3177FS+25d | 100% |  |  |
| 3179 |  | Suppliers complete investigation of exceptions and resolution of exceptions | 1d | 2025-01-24 A | 2025-01-24 A | 3178FS+49d | 100% |  |  |
| 3180 |  | Suppliers complete Work Off plans | 123d | 2025-01-29 A | 2025-07-18 A | 3179 | 100% |  | finish no earlier than 2025-07-18 |
| 3181 |  | Meter Location and Number of Displayed Register Digits Complete | 1d | 2025-07-21 A | 2025-07-21 A | 3179, 3180 | 100% |  |  |
| 3182 | 1.10.8.6.6 | **Registration Data** | 274d | 2024-09-06 A | 2025-09-24 A |  | 100% |  |  |
| 3183 | 1.10.8.6.6.1 | **Connection Type** | 47d | 2024-09-06 A | 2024-11-11 A |  | 100% |  |  |
| 3184 |  | Automated Population of Connection Type for Measurement Classes ‘B’, ‘D’, ‘F’ & ‘G’ | 0d | 2024-10-04 A | 2024-10-04 A | 3167FS+317d | 100% |  | start no earlier than 2024-09-13 |
| 3185 |  | BAU Population of Connection Type for Site Specific LLFCs within Measurement Classes ‘C’ & ‘E’ | 0d | 2024-10-04 A | 2024-10-04 A | 3167FS+317d | 100% |  |  |
| 3186 |  | Automated Population of Connection Type for Smart Meters within Measurement Class ‘A’ | 0d | 2024-10-04 A | 2024-10-04 A | 3167FS+317d | 100% |  |  |
| 3187 |  | Population of Connection Type for Traditional and Advanced Meters within Measurement Class ‘A’ | 1d | 2024-09-06 A | 2024-09-06 A | 3167FS+296d | 100% |  |  |
| 3188 |  | Automated Population of Null Connection Type | 0d | 2024-10-04 A | 2024-10-04 A | 3167FS+317d | 100% |  |  |
| 3189 |  | Full MPAN refresh to ESS | 16d | 2024-10-21 A | 2024-11-11 A | 3167FS+327d | 100% |  |  |
| 3190 |  | Connection Type Complete | 0d | 2024-11-11 A | 2024-11-11 A | 3184, 3185, 3186, 3187, 3188, 3189 | 100% |  |  |
| 3191 | 1.10.8.6.6.2 | **Domestic Premises Indicator** | 14d | 2025-09-05 A | 2025-09-24 A |  | 100% |  |  |
| 3192 |  | The DCC to extract Domestic Premises Indicator from the CSS and provide a file to each LDSO and EES. | 2d | 2025-09-05 A | 2025-09-08 A |  | 100% |  | start no earlier than 2025-09-05 |
| 3193 |  | Each LDSO notifies the MHHS Programme SI of any exceptions which have occurred because of the data load and the reason for that exception | 1d | 2025-09-24 A | 2025-09-24 A | 3192 | 100% |  | start no earlier than 2025-09-24 |
| 3194 |  | Domestic Premises Indicator Complete | 0d | 2025-09-24 A | 2025-09-24 A | 3193 | 100% |  | finish no earlier than 2025-09-24 |
| 3195 | 1.10.8.7 | **Connection Type and Meter Type Misalignments** | 433d | 2025-03-03 A | 2026-10-28 |  | 84% | 31874d |  |
| 3196 | 1.10.8.7.1 | **Traditional Meters installed on Current Transformers** | 433d | 2025-03-03 A | 2026-10-28 |  | 63% | 31874d |  |
| 3197 |  | Suppliers investigate all MPANs with Traditional Meters installed on a Current Transformer Connection Type | 65d | 2025-03-03 A | 2025-05-30 A |  | 100% |  | finish no earlier than 2025-05-30 |
| 3198 |  | Suppliers to raise the relevant SDEP cases with LDSOs in pot 3 | 0d | 2025-05-30 A | 2025-05-30 A |  | 100% |  | finish no earlier than 2025-05-30 |
| 3199 |  | Suppliers to have ensured that Meter Operators have sent the necessary D0312s for MPANs in pot 2 | 21d | 2025-06-02 A | 2025-06-30 A | 3197 | 100% |  | start no earlier than 2025-06-02 |
| 3200 |  | LDSOs will be required to have corrected all of these Connection Types in pot 3 | 40d | 2025-06-02 A | 2025-07-25 A | 3198 | 100% |  | start no earlier than 2025-06-02 |
| 3201 |  | Suppliers to have completed meter exchanges for those MPANs in pot 1 | 368d | 2025-06-02 A | 2026-10-28 | 3197 | 50% | 31874d | start no earlier than 2025-06-02 |
| 3202 |  | Traditional Meters installed on Current Transformers complete | 0d | 2026-10-28 | 2026-10-28 | 3201 |  | 31874d | finish no earlier than 2026-10-28 |
| 3203 | 1.10.8.7.2 | **CHECK Meters** | 66d | 2025-03-03 A | 2025-06-02 A |  | 100% |  |  |
| 3204 |  | Suppliers and their appointed Meter Operator investigate MPANs within their portfolio that have incorrectly populated meters with the Meter Type CHECK within MPRS. Meter Operators are required to send a D0312 to remove the CHECK meter from MPRS. | 65d | 2025-03-03 A | 2025-05-30 A |  | 100% |  | finish no earlier than 2025-05-30 |
| 3205 |  | Once CHECK meters are either removed from MPRS or the Meter Type is changed to a valid Meter Type, the LDSO should check that the Connection Type assigned to the MPAN is still valid. | 65d | 2025-03-03 A | 2025-05-30 A |  | 100% |  | finish no earlier than 2025-05-30 |
| 3206 |  | Suppliers confirm to the Programme that they have completed this activity | 0d | 2025-06-02 A | 2025-06-02 A | 3204 | 100% |  | finish no earlier than 2025-06-02 |
| 3207 |  | CHECK Meters complete | 0d | 2025-06-02 A | 2025-06-02 A | 3205 | 100% |  | finish no earlier than 2025-06-02 |
| 3208 | 1.10.8.7.3 | **Smart Meter Types installed on CT Connection Types** | 90d | 2025-03-21 A | 2025-07-25 A |  | 100% |  |  |
| 3209 |  | Programme shares data via email with LDSOs and Suppliers on the total number of misalignments to inform work they will have to complete | 0d | 2025-03-21 A | 2025-03-21 A |  | 100% |  | finish no earlier than 2025-03-21 |
| 3210 |  | LDSOs investigate Connection Type misalignments and correct where appropriate | 50d | 2025-03-24 A | 2025-05-30 A | 3209 | 100% |  | finish no earlier than 2025-05-30 |
| 3211 |  | LDSOs raise SDEP queries with Suppliers where they believe there is an issue | 0d | 2025-05-30 A | 2025-05-30 A | 3210 | 100% |  | finish no earlier than 2025-05-30 |
| 3212 |  | Suppliers resolve all issues | 40d | 2025-06-02 A | 2025-07-25 A | 3211 | 100% |  | finish no earlier than 2025-07-25 |
| 3213 |  | Smart Meter Types installed on CT Connection Types complete | 0d | 2025-07-25 A | 2025-07-25 A | 3212 | 100% |  | finish no earlier than 2025-07-25 |
| 3214 | 1.10.8.7.4 | **Linked Import / Export MPANs** | 105d | 2025-03-03 A | 2025-07-25 A |  | 100% |  |  |
| 3215 |  | LDSOs review and correct linked Import / Export MPANs with Different Connection Types | 105d | 2025-03-03 A | 2025-07-25 A |  | 100% |  | finish no earlier than 2025-07-25 |
| 3216 |  | LDSOs, Import and Export Suppliers review and correct linked Import / Export MPANs with meters in the Advanced and Traditional or Smart Meter Groups | 105d | 2025-03-03 A | 2025-07-25 A |  | 100% |  | finish no earlier than 2025-07-25 |
| 3217 |  | Linked Import / Export MPANs complete | 0d | 2025-07-25 A | 2025-07-25 A | 3215, 3216 | 100% |  | finish no earlier than 2025-07-25 |
| 3218 | 1.10.8.7.5 | **Related MPANs** | 105d | 2025-03-03 A | 2025-07-25 A |  | 100% |  |  |
| 3219 |  | LDSOs review and correct related MPANs with different Connection Types | 80d | 2025-03-03 A | 2025-06-20 A |  | 100% |  |  |
| 3220 |  | Suppliers unrelate any MPANs required | 25d | 2025-06-23 A | 2025-07-25 A | 3219 | 100% |  | finish no earlier than 2025-07-25 |

| ID | WBS | Task | Duration | Start | Finish | Predecessors | Complete | Total float | Constraint |
| --- | --- | --- | --- | --- | --- | --- | --- | --- | --- |
| 3221 |  | Suppliers should investigate Related MPANs within different meter groups and verify that they are correct or request that their Meter Operators update the Meter Types where they are incorrect | 105d | 2025-03-03 A | 2025-07-25 A |  | 100% |  | start no earlier than 2025-03-03 |
| 3222 |  | Related MPANs complete | 0d | 2025-07-25 A | 2025-07-25 A | 3220, 3221 | 100% |  | finish no earlier than 2025-07-25 |
| 3223 | 1.10.8.8 | **Export / Import MPANs** | 392d | 2024-03-22 A | 2025-09-22 A |  | 100% |  |  |
| 3224 | 1.10.8.8.1 | **Linking of Export / Import MPANS** | 151d | 2024-03-22 A | 2024-10-18 A |  | 100% |  |  |
| 3225 |  | LDSO utilises BAU processing (DB05s) to populate each import/export association | 1d | 2024-03-22 A | 2024-03-22 A | 3167FS+176d | 100% |  |  |
| 3226 |  | Each LDSO notifies the Registered Supplier of any exceptions | 1d | 2024-04-19 A | 2024-04-19 A | 3225FS+19d | 100% |  |  |
| 3227 |  | Each Supplier completes investigation and resolution of exceptions | 1d | 2024-08-23 A | 2024-08-23 A | 3226FS+89d | 100% |  |  |
| 3228 |  | Each LDSO has linked al relevant import/export MPANS | 0d | 2024-10-18 A | 2024-10-18 A | 3227FS+40d | 100% |  |  |
| 3229 |  | Linking of Export / Import MPANS Complete | 0d | 2024-10-18 A | 2024-10-18 A | 3228 | 100% |  |  |
| 3230 |  | Pre-migration data cleanse complete | 0d | 2025-09-22 A | 2025-09-22 A |  | 100% |  | finish no earlier than 2025-09-22 |
| 3231 | 1.10.9 | **Migration Period Planning** | 805d | 2023-07-03 A | 2026-07-31 |  | 98% | 31813d |  |
| 3232 | 1.10.9.1 | **Migration Implementation Plan (incl. Migration Exit Criteria)** | 805d | 2023-07-03 A | 2026-07-31 |  | 98% | 31813d |  |
| 3233 | 1.10.9.1.1 | **Migration Threshold Volumes** | 101d | 2023-07-03 A | 2023-11-20 A |  | 100% |  |  |
| 3234 |  | Threshold volumes reviewed by MWG | 54d | 2023-07-03 A | 2023-09-14 A |  | 100% |  |  |
| 3235 |  | Artefact review (via TMAG) and updates | 47d | 2023-09-15 A | 2023-11-20 A | 3234 | 100% |  |  |
| 3236 |  | Threshold volumes approved at TMAG | 0d | 2023-11-20 A | 2023-11-20 A | 3235 | 100% |  |  |
| 3237 | 1.10.9.1.2 | **Define acceptance criteria for M15** | 78d | 2023-09-04 A | 2023-12-20 A |  | 100% |  |  |
| 3238 |  | Review acceptance criteria and reporting requirements with MWG | 49d | 2023-09-04 A | 2023-11-09 A |  | 100% |  | start no earlier than 2023-09-04 |
| 3239 |  | Artefact review (via TMAG) and updates | 29d | 2023-11-10 A | 2023-12-20 A | 3238 | 100% |  | start no earlier than 2023-10-30 |
| 3240 |  | Acceptance criteria for M15 agreed at TMAG | 0d | 2023-12-20 A | 2023-12-20 A | 3239 | 100% |  | finish no earlier than 2023-11-30 |
| 3241 | 1.10.9.1.3 | **M10/M11 cut-over plan** | 119d | 2023-12-21 A | 2024-06-04 A |  | 100% |  |  |
| 3242 |  | Draft Document | 84d | 2023-12-21 A | 2024-04-16 A | 3240 | 100% |  |  |
| 3243 |  | Share Document with SRO | 1d | 2024-04-17 A | 2024-04-17 A | 3242 | 100% |  |  |
| 3244 |  | Industry Consultation | 11d | 2024-04-23 A | 2024-05-07 A | 3243FS+3d | 100% |  |  |
| 3245 |  | Assurance Meeting | 1d | 2024-05-21 A | 2024-05-21 A | 3244FS+9d | 100% |  |  |
| 3246 |  | MCAG Approval of M10/M11 Cut-over Plan | 0d | 2024-06-04 A | 2024-06-04 A | 3245FS+10d | 100% |  |  |
| 3247 | 1.10.9.1.4 | **M16 Methodology** | 523d | 2024-07-31 A | 2026-07-31 |  | 96% | 31813d |  |
| 3248 |  | Draft Document | 262d | 2024-07-31 A | 2025-07-31 A |  | 100% |  |  |
| 3249 |  | Share Document with SRO | 0d | 2025-07-31 A | 2025-07-31 A | 3248 | 100% |  |  |
| 3250 |  | Industry Consultation | 11d | 2025-08-06 | 2025-08-20 | 3249FS+3d |  | 32040d |  |
| 3251 |  | Assurance Meeting | 1d | 2025-09-03 | 2025-09-03 | 3250FS+9d |  | 32040d |  |
| 3252 |  | M16 methodology approved | 0d | 2026-07-31 | 2026-07-31 | 3251FS+10d |  | 31813d | finish no earlier than 2026-07-31 |
| 3253 | 1.10.10 | **Preparation for Cutover to Live** | 774d? | 2024-06-03 A | 2027-05-20 |  | 59% | 31728d |  |
| 3254 | 1.10.10.1 | **Central Systems Prepare for Cutover to Live** | 363d? | 2024-06-03 A | 2025-10-22 A |  | 100% |  |  |
| 3255 |  | DCC (Functionality available June 2024) | 0d | 2024-06-28 A | 2024-06-28 A |  | 100% |  | start no earlier than 2024-06-28 |
| 3256 | 1.10.10.1.2 | **Development of Comms Approach and Declaration Guidance** | 79d | 2025-04-28 A | 2025-08-14 A |  | 100% |  |  |
| 3257 |  | Draft Cutover Comms Approach | 59d | 2025-04-28 A | 2025-07-17 A |  | 100% |  | start no earlier than 2025-04-28 |
| 3258 |  | Draft Cutover Comms Approach shared | 0d | 2025-07-17 A | 2025-07-17 A | 3257 | 100% |  |  |
| 3259 |  | Finalised Cutover Comms Approach shared | 0d | 2025-08-14 A | 2025-08-14 A | 3258FS+20d | 100% |  |  |
| 3260 | 1.10.10.1.3 | **Development of Cutover Plan requirements with Participants** | 139d | 2025-04-11 A | 2025-10-22 A |  | 100% |  |  |
| 3261 |  | Development of Central Parties Cutover Plans | 26d | 2025-04-11 A | 2025-05-16 A |  | 100% |  | start no earlier than 2025-04-11 |
| 3262 |  | Development of Programme Participant Cutover Plans | 66d | 2025-04-11 A | 2025-07-11 A | 3261SS | 100% |  | finish no earlier than 2025-07-11 |
| 3263 |  | Central Party Cutover Plan Assurance | 45d | 2025-04-14 A | 2025-06-13 A | 3261FF | 100% |  | start no earlier than 2025-04-14 |
| 3264 |  | Consolidated MHHS Cutover Plan Developed | 30d | 2025-05-19 A | 2025-06-27 A | 3261 | 100% |  | start no earlier than 2025-05-19 |
| 3265 |  | LDSO Cutover Plan Assurance | 15d | 2025-07-14 A | 2025-08-01 A | 3262 | 100% |  | start no earlier than 2025-06-30 |
| 3266 |  | SIT Supplier and SIT Agent Cutover Plan Assurance | 30d | 2025-07-14 A | 2025-08-22 A | 3262 | 100% |  | start no earlier than 2025-06-30 |
| 3267 |  | Monitor Participant Cutover Plan reporting | 56d | 2025-08-06 A | 2025-10-22 A |  | 100% |  | start no earlier than 2025-08-06 |
| 3268 | 1.10.10.1.4 | **M10/M11 Cutover Activities** | 120d? | 2025-04-14 | 2025-09-26 |  | 100% |  |  |
| 3269 |  | Load Shaping Service (LSS) | 10d | 2025-07-14 A | 2025-07-25 A |  | 100% |  | start no earlier than 2025-07-14 |
| 3270 |  | Volume Allocation Service (VAS) | 10d | 2025-07-14 A | 2025-07-25 A |  | 100% |  | start no earlier than 2025-07-14 |
| 3271 |  | Market-wide Data Service (MDS) | 10d | 2025-07-14 A | 2025-07-25 A |  | 100% |  | start no earlier than 2025-07-14 |
| 3272 |  | Deployment of Industry Standing Data (ISD) Work Package (WP3) source code | 10d | 2025-07-14 A | 2025-07-25 A |  | 100% |  | start no earlier than 2025-07-14 |
| 3273 |  | ISD Service Activation | 0d | 2025-08-05 A | 2025-08-05 A | 3272 | 100% |  | start no earlier than 2025-08-05 |
| 3274 |  | ISD Data Migration (PR-3) | 14d | 2025-08-05 A | 2025-08-22 A | 3273 | 100% |  | start no earlier than 2025-08-05 |
| 3275 |  | ISD Data Migration (PR-4) | 11d | 2025-08-15 A | 2025-08-29 A |  | 100% |  | start no earlier than 2025-08-15 |
| 3276 |  | ISD Catalogue Published | 0d | 2025-09-11 A | 2025-09-11 A | 3275 | 100% |  | start no earlier than 2025-09-11 |
| 3277 |  | DIP Production Environment stood up | 0d | 2025-07-18 A | 2025-07-18 A |  | 100% |  | start no earlier than 2025-07-18 |
| 3278 |  | Production DIP Portal (DIP Deployment) | 2d | 2025-08-01 A | 2025-08-04 A |  | 100% |  | start no earlier than 2025-08-01 |
| 3279 |  | Production Certificates (DIP Deployment) | 2d | 2025-08-01 A | 2025-08-04 A |  | 100% |  | start no earlier than 2025-08-01 |
| 3280 |  | Service Management Go-Live | 0d | 2025-07-31 A | 2025-07-31 A |  | 100% |  | start no earlier than 2025-07-31 |
| 3281 |  | DIP Onboarding | 15d | 2025-08-04 A | 2025-08-22 A |  | 100% |  | start no earlier than 2025-08-04 |
| 3282 |  | Deployment of MPRS 9 | 19d | 2025-08-06 A | 2025-09-01 A |  | 100% |  | start no earlier than 2025-08-06 |
| 3283 |  | ISD Population | 0d | 2025-09-11 A | 2025-09-11 A |  | 100% |  | start no earlier than 2025-09-11 |
| 3284 |  | Population of Market Segment (95%) | 28d | 2025-08-06 A | 2025-09-12 A | 3282SS | 100% |  | start no earlier than 2025-08-06 |
| 3285 |  | Population of Market Segment (100%) | 7d | 2025-09-12 A | 2025-09-22 A | 3284FS-1d | 100% |  | start no earlier than 2025-09-12 |
| 3286 |  | Population of Domestic Premises Indicator (Weekend start) | 2d | 2025-09-05 A | 2025-09-08 A |  | 100% |  | start no earlier than 2025-09-05 |
| 3287 |  | Completion of the pre-M10 MHHS Data Cleanse | 0d | 2025-09-22 A | 2025-09-22 A |  | 100% |  | finish no earlier than 2025-09-22 |
| 3288 |  | Early Life Support Implemented | 0d | 2025-09-19 A | 2025-09-19 A |  | 100% |  | start no earlier than 2025-09-19 |
| 3289 |  | MCC Tested and Ready to Operate | 31d | 2025-08-08 A | 2025-09-19 A |  | 100% |  | start no earlier than 2025-08-08 |
| 3290 |  | Market-wide Participant MHHS Supporting Functionality Ready - Confirmation from Code Bodies | 0d | 2025-09-15 A | 2025-09-15 A |  | 100% |  | start no earlier than 2025-09-15 |

| ID | WBS | Task | Duration | Start | Finish | Predecessors | Complete | Total float | Constraint |
| --- | --- | --- | --- | --- | --- | --- | --- | --- | --- |
| 3291 |  | Market-wide Participant MHHS Supporting Functionality Ready | 0d | 2025-09-22 A | 2025-09-22 A |  | 100% |  | start no earlier than 2025-09-22 |
| 3292 |  | Pre-M10 Service Activation - LDSOs | 6d | 2025-09-11 A | 2025-09-18 A |  | 100% |  | start no earlier than 2025-09-11 |
| 3293 |  | Pre-M10 Service Activation - Suppliers and Agents | 25d | 2025-09-11 A | 2025-10-15 A |  | 100% |  | start no earlier than 2025-09-11 |
| 3294 |  | Load Shaping Service (LSS) | 2d | 2025-09-19 A | 2025-09-22 A | 3269 | 100% |  | start no earlier than 2025-09-19 |
| 3295 |  | Volume Allocation Service (VAS) | 2d | 2025-09-19 A | 2025-09-22 A | 3270 | 100% |  | start no earlier than 2025-09-19 |
| 3296 |  | Market-wide Data Service (MDS) | 2d | 2025-09-19 A | 2025-09-22 A | 3271 | 100% |  | start no earlier than 2025-09-19 |
| 3297 |  | DTS | 2d | 2025-09-19 A | 2025-09-22 A |  | 100% |  | start no earlier than 2025-09-19 |
| 3298 |  | EES | 2d | 2025-09-19 A | 2025-09-22 A |  | 100% |  | start no earlier than 2025-09-19 |
| 3299 |  | DCC | 20d | 2024-06-03 A | 2024-06-28 A |  | 100% |  | start no earlier than 2024-06-01 |
| 3300 |  | MPRS – Registration Services, UMSO Role, LDSO Role | 2d | 2025-09-19 A | 2025-09-22 A |  | 100% |  | start no earlier than 2025-09-19 |
| 3301 |  | Qualification Pathway 4 Service Activation | 6d | 2025-09-26 A | 2025-10-03 A |  | 100% |  | start no earlier than 2025-09-26 |
| 3302 |  | Qualification Pathway 5 Service Activation | 5d | 2025-10-16 A | 2025-10-22 A |  | 100% |  | start no earlier than 2025-10-16 |
| 3303 |  | Central Systems live and Codes designated at 00:00 | 0d | 2025-09-22 A | 2025-09-22 A | 3255FS+1d | 100% |  | finish no earlier than 2025-09-22 |
| 3304 |  | IF-047 sent at 9am on Monday 22nd September by Elexon via the DIP to all LDSOs and EES | 0d | 2025-09-22 A | 2025-09-22 A |  | 100% |  | start no earlier than 2025-09-22 |
| 3305 |  | All LDSOs and EES to load ISD files via the URL published within the IF-047 via the Elexon data store (note, this should contain the same ISD file as uploaded to the Elexon portal following 11th September, therefore it may not need to be applied by each p | 0d | 2025-09-22 A | 2025-09-22 A |  | 100% |  | start no earlier than 2025-09-22 |
| 3306 |  | Following successful loading of ISD data LDSOs can process New Connections via their DB01 interface to MPRS | 0d | 2025-09-22 A | 2025-09-22 A | 3305 | 100% |  | start no earlier than 2025-09-22 |
| 3307 |  | Each LDSO will track successful sending of the IF-050 message to the DIP | 0d | 2025-09-22 A | 2025-09-22 A | 3306 | 100% |  | start no earlier than 2025-09-22 |
| 3308 |  | EES will track successful receipt and processing of the IF-050 | 0d | 2025-09-22 A | 2025-09-22 A | 3307 | 100% |  | start no earlier than 2025-09-22 |
| 3309 |  | IF-047 sent at 9am on Wednesday 22nd October by Elexon via the DIP | 0d | 2025-10-22 A | 2025-10-22 A |  | 100% |  | start no earlier than 2025-10-22 |
| 3310 | 1.10.10.2 | **Cutover Governance M10** | 23d | 2025-08-22 A | 2025-09-24 A |  | 100% |  |  |
| 3311 |  | Confirmation from all LDSOs that DIP onboarding has taken place | 0d | 2025-08-22 A | 2025-08-22 A |  | 100% |  | start no earlier than 2025-08-22 |
| 3312 |  | Confirmation that all LDSOs have deployed MPRS 9 to production | 0d | 2025-09-01 A | 2025-09-01 A |  | 100% |  | start no earlier than 2025-09-01 |
| 3313 |  | Confirmation that population of Domestic Premises Indicator is complete | 0d | 2025-09-08 A | 2025-09-08 A |  | 100% |  | start no earlier than 2025-09-08 |
| 3314 |  | Confirmation that Market Segment has been populated for 95% of LDSO portfolios | 0d | 2025-09-12 A | 2025-09-12 A |  | 100% |  | start no earlier than 2025-09-12 |
| 3315 |  | Confirmation of all pre-M10 parties | 0d | 2025-09-15 A | 2025-09-15 A |  | 100% |  | start no earlier than 2025-09-15 |
| 3316 |  | Confirmation that all LDSOs have populated the ISD | 0d | 2025-09-15 A | 2025-09-15 A |  | 100% |  | start no earlier than 2025-09-15 |
| 3317 |  | Declaration from all Central Services and LDSOs that they are in a position to move forwards | 0d | 2025-09-15 A | 2025-09-15 A |  | 100% |  | start no earlier than 2025-09-15 |
| 3318 |  | Market-wide Participant MHHS Migration Supporting Functionality is ready to be deployed | 0d | 2025-09-15 A | 2025-09-15 A |  | 100% |  | start no earlier than 2025-09-15 |
| 3319 |  | Recommendation from TORWG that the Programme should enter M10 | 0d | 2025-09-17 A | 2025-09-17 A |  | 100% |  | start no earlier than 2025-09-17 |
| 3320 |  | Production Service Activation Activities have taken place for all pre-M10 qualified parties | 0d | 2025-09-18 A | 2025-09-18 A |  | 100% |  | start no earlier than 2025-09-18 |
| 3321 |  | Early Life Support model is in place | 0d | 2025-09-19 A | 2025-09-19 A |  | 100% |  | start no earlier than 2025-09-19 |
| 3322 |  | MCC Operational | 0d | 2025-09-19 A | 2025-09-19 A |  | 100% |  | start no earlier than 2025-09-19 |
| 3323 |  | MCAG (Confirm that the Programme can Enter M10) | 0d | 2025-09-19 A | 2025-09-19 A |  | 100% |  | start no earlier than 2025-09-19 |
| 3324 |  | Self-Declaration from all Central Services and LDSOs that Cutover activities have been successfully carried out | 0d | 2025-09-22 A | 2025-09-22 A |  | 100% |  | start no earlier than 2025-09-22 |
| 3325 |  | Confirmation that DIP and ECS have been deployed, Service management is active, ISD has been populated | 0d | 2025-09-22 A | 2025-09-22 A |  | 100% |  | start no earlier than 2025-09-22 |
| 3326 |  | Confirmation that Market Segment has been populated for 100% of LDSO portfolios | 0d | 2025-09-22 A | 2025-09-22 A |  | 100% |  | start no earlier than 2025-09-22 |
| 3327 |  | IF-047 message has been sent | 0d | 2025-09-22 A | 2025-09-22 A |  | 100% |  | start no earlier than 2025-09-22 |
| 3328 |  | LDSOs have received the IF-047 message | 0d | 2025-09-22 A | 2025-09-22 A |  | 100% |  | start no earlier than 2025-09-22 |
| 3329 |  | EES has received the IF-047 message and loaded the ISD file | 0d | 2025-09-22 A | 2025-09-22 A |  | 100% |  | start no earlier than 2025-09-22 |
| 3330 |  | Confirmation that the IF-050 has been sent and the number sent | 0d | 2025-09-22 A | 2025-09-22 A |  | 100% |  | start no earlier than 2025-09-22 |
| 3331 |  | Confirmation of the number of IF-050s | 0d | 2025-09-22 A | 2025-09-22 A |  | 100% |  | start no earlier than 2025-09-22 |
| 3332 |  | Recommendation from TORWG that the M10 acceptance criteria have been met | 0d | 2025-09-23 A | 2025-09-23 A |  | 100% |  | start no earlier than 2025-09-23 |
| 3333 |  | PSG (OFGEM and PSG to Approve That Conditions of M10 and M13 Have Been Met) | 0d | 2025-09-24 A | 2025-09-24 A |  | 100% |  | start no earlier than 2025-09-24 |
| 3334 | 1.10.10.3 | **Cutover Governance M11** | 6d | 2025-10-14 A | 2025-10-22 A |  | 100% |  |  |
| 3335 |  | Self-Declaration that MHHS Functionality will be deployed to Production by Qualified parties | 0d | 2025-10-14 A | 2025-10-14 A |  | 100% |  | start no earlier than 2025-10-14 |
| 3336 |  | Qualification of all pre-M11 parties | 0d | 2025-10-16 A | 2025-10-16 A |  | 100% |  | start no earlier than 2025-10-16 |
| 3337 |  | Self-Declaration that ISD file has been manually accessed and applied by all qualified Suppliers and Agents | 0d | 2025-10-16 A | 2025-10-16 A |  | 100% |  | start no earlier than 2025-10-16 |
| 3338 |  | Confirmation of Qualified Parties from TORWG and their readiness | 0d | 2025-10-17 A | 2025-10-17 A |  | 100% |  | start no earlier than 2025-10-17 |
| 3339 |  | Recommendation from MCAG that the Programme can approve M11 / M12 | 0d | 2025-10-20 A | 2025-10-20 A |  | 100% |  | start no earlier than 2025-10-20 |
| 3340 |  | PSG (OFGEM and PSG Decision to Confirm M11 and M12) | 0d | 2025-10-22 A | 2025-10-22 A |  | 100% |  | start no earlier than 2025-10-22 |
| 3341 | 1.10.10.4 | **Migration Exclusion PPIR** | 20d | 2026-02-16 | 2026-03-13 |  |  | 32037d |  |
| 3342 |  | Publication of migration exclusion PPIR | 0d | 2026-02-16 | 2026-02-16 |  |  | 32037d | start no earlier than 2026-02-16 |
| 3343 |  | Participant response window for PPIR | 20d | 2026-02-16 | 2026-03-13 | 3342 |  | 32037d |  |
| 3344 |  | PPIR consultation window closed | 0d | 2026-03-13 | 2026-03-13 | 3343 |  | 32037d |  |
| 3345 | 1.10.10.5 | **Migration Sprints** | 432d | 2025-09-24 A | 2027-05-20 |  | 18% | 31728d |  |
| 3346 | 1.10.10.5.1 | **Migration Sprint 0** | 105d | 2025-09-24 A | 2026-02-17 |  | 95% | 32055d |  |
| 3347 |  | Sprint 0 Planning start date | 6d | 2025-09-24 A | 2025-10-01 A |  | 100% |  | start no earlier than 2025-09-24 |
| 3348 |  | Issue Envelope | 0d | 2025-10-01 A | 2025-10-01 A | 3347 | 100% |  |  |
| 3349 |  | Supplier Submission Deadline | 0d | 2025-10-08 A | 2025-10-08 A | 3348FS+5d | 100% |  |  |
| 3350 |  | Baseline Schedule Publication | 0d | 2025-10-15 A | 2025-10-15 A | 3349FS+5d | 100% |  |  |
| 3351 |  | Migration Sprint 0 Schedule Baselined | 0d | 2025-10-16 A | 2025-10-16 A | 3350 | 100% |  | finish no earlier than 2025-10-16 |
| 3352 |  | Sprint Execution Start | 0d | 2025-10-22 A | 2025-10-22 A | 3351FS+4d, 3453 | 100% |  | start no earlier than 2025-10-22 |
| 3353 |  | Sprint Execution | 75d | 2025-10-22 A | 2026-02-03 A |  | 100% |  | start no earlier than 2025-10-22 |
| 3354 |  | Sprint Execution End | 0d | 2026-02-03 A | 2026-02-03 A | 3353 | 100% |  |  |
| 3355 |  | Sprint 0 Retro | 10d | 2026-02-04 A | 2026-02-17 | 3354 | 50% | 32055d | start no earlier than 2026-02-04 |
| 3356 | 1.10.10.5.2 | **Migration Sprint 1** | 70d | 2026-01-07 A | 2026-04-14 |  | 18% | 32015d |  |
| 3357 |  | Sprint 1 Planning start date | 6d | 2026-01-07 A | 2026-01-14 A |  | 100% |  | start no earlier than 2026-01-07 |
| 3358 |  | Issue Envelope | 0d | 2026-01-14 A | 2026-01-14 A | 3357 | 100% |  |  |
| 3359 |  | Supplier Submission Deadline | 0d | 2026-01-21 A | 2026-01-21 A | 3358FS+5d | 100% |  |  |
| 3360 |  | Baseline Schedule Publication | 0d | 2026-01-28 A | 2026-01-28 A | 3359FS+5d | 100% |  |  |

| ID | WBS | Task | Duration | Start | Finish | Predecessors | Complete | Total float | Constraint |
| --- | --- | --- | --- | --- | --- | --- | --- | --- | --- |
| 3361 |  | Migration Sprint 1 Schedule Baselined | 0d | 2026-01-28 A | 2026-01-28 A | 3360 | 100% |  |  |
| 3362 |  | Sprint Execution Start | 0d | 2026-02-04 A | 2026-02-04 A | 3361FS+5d | 100% |  |  |
| 3363 |  | Sprint Execution | 39d | 2026-02-05 A | 2026-03-31 | 3362 | 10% | 32015d |  |
| 3364 |  | Sprint Execution End | 0d | 2026-03-31 | 2026-03-31 | 3363 |  | 32015d |  |
| 3365 |  | Sprint 1 Retro | 10d | 2026-04-01 | 2026-04-14 | 3364 |  | 32015d | start no earlier than 2026-04-01 |
| 3366 | 1.10.10.5.3 | **Migration Sprint 2** | 75d | 2026-03-04 | 2026-06-16 |  |  | 31970d |  |
| 3367 |  | Sprint 2 Planning start date | 6d | 2026-03-04 | 2026-03-11 |  |  | 31970d | start no earlier than 2026-03-04 |
| 3368 |  | Issue Envelope | 0d | 2026-03-11 | 2026-03-11 | 3367 |  | 31970d |  |
| 3369 |  | Supplier Submission Deadline | 0d | 2026-03-18 | 2026-03-18 | 3368FS+5d |  | 31970d |  |
| 3370 |  | Baseline Schedule Publication | 0d | 2026-03-25 | 2026-03-25 | 3369FS+5d |  | 31970d |  |
| 3371 |  | Migration Sprint 2 Schedule Baselined | 0d | 2026-03-25 | 2026-03-25 | 3370 |  | 31970d |  |
| 3372 |  | Sprint Execution Start | 0d | 2026-04-01 | 2026-04-01 | 3371FS+5d |  | 31970d |  |
| 3373 |  | Sprint Execution | 44d | 2026-04-02 | 2026-06-02 | 3372 |  | 31970d |  |
| 3374 |  | Non-SIT Participants Migration Start | 0d | 2026-05-15 | 2026-05-15 |  |  | 31992d | finish no earlier than 2026-05-15 |
| 3375 |  | Sprint Execution End | 0d | 2026-06-02 | 2026-06-02 | 3373 |  | 31970d |  |
| 3376 |  | Sprint 2 Retro | 10d | 2026-06-03 | 2026-06-16 | 3375 |  | 31970d |  |
| 3377 | 1.10.10.5.4 | **Migration Sprint 3** | 75d | 2026-05-06 | 2026-08-18 |  |  | 31925d |  |
| 3378 |  | Sprint 3 Planning start date | 6d | 2026-05-06 | 2026-05-13 |  |  | 31925d | start no earlier than 2026-05-06 |
| 3379 |  | Issue Envelope | 0d | 2026-05-13 | 2026-05-13 | 3378 |  | 31925d |  |
| 3380 |  | Supplier Submission Deadline | 0d | 2026-05-20 | 2026-05-20 | 3379FS+5d |  | 31925d |  |
| 3381 |  | Baseline Schedule Publication | 0d | 2026-05-27 | 2026-05-27 | 3380FS+5d |  | 31925d |  |
| 3382 |  | Migration Sprint 3 Schedule Baselined | 0d | 2026-05-27 | 2026-05-27 | 3381 |  | 31925d |  |
| 3383 |  | Sprint Execution Start | 0d | 2026-06-03 | 2026-06-03 | 3382FS+5d |  | 31925d |  |
| 3384 |  | Sprint Execution | 44d | 2026-06-04 | 2026-08-04 | 3383 |  | 31925d |  |
| 3385 |  | Sprint Execution End | 0d | 2026-08-04 | 2026-08-04 | 3384 |  | 31925d |  |
| 3386 |  | Sprint 3 Retro | 10d | 2026-08-05 | 2026-08-18 | 3385 |  | 31925d |  |
| 3387 | 1.10.10.5.5 | **Migration Sprint 4** | 75d | 2026-07-08 | 2026-10-20 |  |  | 31880d |  |
| 3388 |  | Sprint 4 Planning start date | 6d | 2026-07-08 | 2026-07-15 |  |  | 31880d | start no earlier than 2026-07-08 |
| 3389 |  | Issue Envelope | 0d | 2026-07-15 | 2026-07-15 | 3388 |  | 31880d |  |
| 3390 |  | Supplier Submission Deadline | 0d | 2026-07-22 | 2026-07-22 | 3389FS+5d |  | 31880d |  |
| 3391 |  | Baseline Schedule Publication | 0d | 2026-07-29 | 2026-07-29 | 3390FS+5d |  | 31880d |  |
| 3392 |  | Migration Sprint 4 Schedule Baselined | 0d | 2026-07-29 | 2026-07-29 | 3391 |  | 31880d |  |
| 3393 |  | Sprint Execution Start | 0d | 2026-08-05 | 2026-08-05 | 3392FS+5d |  | 31880d |  |
| 3394 |  | Sprint Execution | 44d | 2026-08-06 | 2026-10-06 | 3393 |  | 31880d |  |
| 3395 |  | Sprint Execution End | 0d | 2026-10-06 | 2026-10-06 | 3394 |  | 31880d |  |
| 3396 |  | Sprint 4 Retro | 10d | 2026-10-07 | 2026-10-20 | 3395 |  | 31880d |  |
| 3397 | 1.10.10.5.6 | **Migration Sprint 5** | 70d | 2026-09-09 | 2026-12-15 |  |  | 31840d |  |
| 3398 |  | Sprint 5 Planning start date | 6d | 2026-09-09 | 2026-09-16 |  |  | 31840d | start no earlier than 2026-09-09 |
| 3399 |  | Issue Envelope | 0d | 2026-09-16 | 2026-09-16 | 3398 |  | 31840d |  |
| 3400 |  | Supplier Submission Deadline | 0d | 2026-09-23 | 2026-09-23 | 3399FS+5d |  | 31840d |  |
| 3401 |  | Baseline Schedule Publication | 0d | 2026-09-30 | 2026-09-30 | 3400FS+5d |  | 31840d |  |
| 3402 |  | Migration Sprint 5 Schedule Baselined | 0d | 2026-09-30 | 2026-09-30 | 3401 |  | 31840d |  |
| 3403 |  | Sprint Execution Start | 0d | 2026-10-07 | 2026-10-07 | 3402FS+5d |  | 31840d |  |
| 3404 |  | Sprint Execution | 39d | 2026-10-08 | 2026-12-01 | 3403 |  | 31840d |  |
| 3405 |  | Sprint Execution End | 0d | 2026-12-01 | 2026-12-01 | 3404 |  | 31840d |  |
| 3406 |  | Sprint 5 Retro | 10d | 2026-12-02 | 2026-12-15 | 3405 |  | 31840d |  |
| 3407 | 1.10.10.5.7 | **Migration Sprint 6** | 75d | 2026-11-04 | 2027-02-16 |  |  | 31795d |  |
| 3408 |  | Sprint 6 Planning start date | 6d | 2026-11-04 | 2026-11-11 |  |  | 31795d | start no earlier than 2026-11-04 |
| 3409 |  | Issue Envelope | 0d | 2026-11-11 | 2026-11-11 | 3408 |  | 31795d |  |
| 3410 |  | Supplier Submission Deadline | 0d | 2026-11-18 | 2026-11-18 | 3409FS+5d |  | 31795d |  |
| 3411 |  | Baseline Schedule Publication | 0d | 2026-11-25 | 2026-11-25 | 3410FS+5d |  | 31795d |  |
| 3412 |  | Migration Sprint 6 Schedule Baselined | 0d | 2026-11-25 | 2026-11-25 | 3411 |  | 31795d |  |
| 3413 |  | Sprint Execution Start | 0d | 2026-12-02 | 2026-12-02 | 3412FS+5d |  | 31795d |  |
| 3414 |  | Sprint Execution | 44d | 2026-12-03 | 2027-02-02 | 3413 |  | 31795d |  |
| 3415 |  | Sprint Execution End | 0d | 2027-02-02 | 2027-02-02 | 3414 |  | 31795d |  |
| 3416 |  | Sprint 6 Retro | 10d | 2027-02-03 | 2027-02-16 | 3415 |  | 31795d |  |
| 3417 | 1.10.10.5.8 | **Migration Sprint 7** | 75d | 2027-01-06 | 2027-04-20 |  |  | 31750d |  |
| 3418 |  | Sprint 6 Planning start date | 6d | 2027-01-06 | 2027-01-13 |  |  | 31750d | start no earlier than 2027-01-06 |
| 3419 |  | Issue Envelope | 0d | 2027-01-13 | 2027-01-13 | 3418 |  | 31750d |  |
| 3420 |  | Supplier Submission Deadline | 0d | 2027-01-20 | 2027-01-20 | 3419FS+5d |  | 31750d |  |
| 3421 |  | Baseline Schedule Publication | 0d | 2027-01-27 | 2027-01-27 | 3420FS+5d |  | 31750d |  |
| 3422 |  | Migration Sprint 7 Schedule Baselined | 0d | 2027-01-27 | 2027-01-27 | 3421 |  | 31750d |  |
| 3423 |  | Sprint Execution Start | 0d | 2027-02-03 | 2027-02-03 | 3422FS+5d |  | 31750d |  |
| 3424 |  | Sprint Execution | 44d | 2027-02-04 | 2027-04-06 | 3423 |  | 31750d |  |
| 3425 |  | Sprint Execution End | 0d | 2027-04-06 | 2027-04-06 | 3424 |  | 31750d |  |
| 3426 |  | Sprint 7 Retro | 10d | 2027-04-07 | 2027-04-20 | 3425 |  | 31750d |  |
| 3427 | 1.10.10.5.9 | **Migration Sprint 8** | 59d | 2027-03-01 | 2027-05-20 |  |  | 31573d |  |
| 3428 |  | Sprint 8 Planning start date | 6d | 2027-03-01 | 2027-03-08 |  |  | 31573d | start no earlier than 2027-03-01 |
| 3429 |  | Issue Envelope | 0d | 2027-03-08 | 2027-03-08 | 3428 |  | 31573d |  |
| 3430 |  | Supplier Submission Deadline | 0d | 2027-03-15 | 2027-03-15 | 3429FS+5d |  | 31573d |  |

| ID | WBS | Task | Duration | Start | Finish | Predecessors | Complete | Total float | Constraint |
| --- | --- | --- | --- | --- | --- | --- | --- | --- | --- |
| 3431 |  | Baseline Schedule Publication | 0d | 2027-03-22 | 2027-03-22 | 3430FS+5d |  | 31573d |  |
| 3432 |  | Migration Sprint 8 Schedule Baselined | 0d | 2027-03-22 | 2027-03-22 | 3431 |  | 31573d |  |
| 3433 |  | Sprint Execution Start | 0d | 2027-03-29 | 2027-03-29 | 3432FS+5d |  | 31573d |  |
| 3434 |  | Sprint Execution | 27d | 2027-03-30 | 2027-05-05 | 3433 |  | 31573d |  |
| 3435 |  | Sprint Execution End | 0d | 2027-05-05 | 2027-05-05 | 3434 |  | 31573d |  |
| 3436 |  | Sprint 8 Retro | 10d | 2027-05-07 | 2027-05-20 | 3435 |  | 31728d | start no earlier than 2027-05-07 |
| 3437 | 1.10.11 | **External Programme Dependency Management** | 740d | 2022-10-31 A | 2025-08-29 A |  | 100% |  |  |
| 3438 | 1.10.11.1 | **BSC Mod P432 & REC CP R0015** | 392d | 2022-10-31 A | 2024-04-30 A |  | 100% |  |  |
| 3439 |  | MHHSP engagement with BSCCo until Ofgem decision | 316d | 2022-10-31 A | 2024-01-15 A |  | 100% |  |  |
| 3440 |  | Monitor progress and await implementation date | 76d | 2024-01-16 A | 2024-04-30 A | 3439 | 100% |  |  |
| 3441 | 1.10.11.2 | **BSC Mod P434** | 713d | 2022-10-31 A | 2025-07-23 A |  | 100% |  |  |
| 3442 |  | MHHSP engagement with BSCCo until Ofgem decision | 61d | 2022-10-31 A | 2023-01-23 A |  | 100% |  |  |
| 3443 |  | Monitor progress and await implementation date | 652d | 2023-01-24 A | 2025-07-23 A | 3442 | 100% |  |  |
| 3444 | 1.10.11.3 | **Elexon System Capacity Upgrade** | 697d | 2022-10-31 A | 2025-07-01 A |  | 100% |  |  |
| 3445 |  | Monitor progress to implementation | 697d | 2022-10-31 A | 2025-07-01 A |  | 100% |  |  |
| 3446 |  | Implementation date | 0d | 2025-07-01 A | 2025-07-01 A | 3445 | 100% |  |  |
| 3447 | 1.10.11.4 | **DCC System Capacity Upgrade** | 25d | 2025-07-28 A | 2025-08-29 A |  | 100% |  |  |
| 3448 |  | Assurance of DCC capacity upgrade to ensure suitability to support migration | 20d | 2025-07-28 A | 2025-08-22 A | 1802FF-21d | 100% |  |  |
| 3449 |  | DCC Capacity Upgrade Operational | 0d | 2025-08-29 A | 2025-08-29 A | 3448FS+5d | 100% |  |  |
| 3450 | 1.10.12 | **Migration - Tier 1 Milestones** | 490d | 2025-09-22 A | 2027-08-09 |  |  | 31671d |  |
| 3451 |  | Load Shaping Service switched on (M13) | 0d | 2025-09-22 A | 2025-09-22 A | 1802 | 100% |  |  |
| 3452 |  | Load Shaping Service switched on (M13*) - Late Exit | 0d | 2025-12-24 A | 2025-12-24 A | 3451FS+67d | 100% |  |  |
| 3453 |  | Start of 18-month migration for UMS / Advanced (M11) | 0d | 2025-10-22 A | 2025-10-22 A | 3451, 1802FS+22d, 3116 | 100% |  |  |
| 3454 |  | Start of 18-month migration for UMS / Advanced (M11*) - Late Exit | 0d | 2026-01-21 A | 2026-01-21 A | 3453FS+65d | 100% |  |  |
| 3455 |  | Start of 18-month migration for Smart / Non-smart (M12) | 0d | 2025-10-22 A | 2025-10-22 A | 3451, 1802FS+22d | 100% |  |  |
| 3456 |  | Start of 18-month migration for Smart / Non-smart (M12*) - Late Exit | 0d | 2026-01-21 A | 2026-01-21 A | 3455FS+65d | 100% |  |  |
| 3457 |  | Full transition complete (M15) | 0d | 2027-05-07 | 2027-05-07 | 3435FS+2d |  | 31573d |  |
| 3458 |  | Full transition complete (M15*) - Late Exit | 0d | 2027-08-09 | 2027-08-09 | 3457FS+66d |  | 31671d |  |
| 3459 | 1.11 | **BUSINESS & OPERATIONAL READINESS** | 1344d? | 2022-10-31 A | 2027-12-23 |  | 70% | 31573d |  |
| 3460 | 1.11.1 | **Service Management** | 1055d? | 2022-10-31 A | 2026-11-14 |  | 76% | 31862d |  |
| 3461 | 1.11.1.1 | **Service Management Strategy** | 116d | 2023-09-19 A | 2024-02-27 A |  | 100% |  |  |
| 3462 |  | Develop document with relevant participants (incl. review of the design baseline to ensure service management arrangements are in place across the solution architecture) | 84d | 2023-09-19 A | 2024-01-12 A |  | 100% |  | start no earlier than 2023-09-19 |
| 3463 |  | Artefact review (via relevant Advisory Group) and updates | 31d | 2024-01-15 A | 2024-02-26 A | 3462 | 100% |  |  |
| 3464 |  | Service Management Strategy approved | 0d | 2024-02-27 A | 2024-02-27 A | 3463FS+1d | 100% |  |  |
| 3465 | 1.11.1.2 | **Early Life Support Model** | 305d | 2024-02-28 A | 2025-04-29 A |  | 100% |  |  |
| 3466 |  | Draft Document | 252d | 2024-02-28 A | 2025-02-13 A | 3464 | 100% |  | finish no earlier than 2025-02-13 |
| 3467 |  | Share Document with SRO | 1d | 2025-02-14 A | 2025-02-14 A | 3466 | 100% |  |  |
| 3468 |  | Industry Consultation | 11d | 2025-02-21 A | 2025-03-07 A | 3467FS+4d | 100% |  |  |
| 3469 |  | Assurance Meeting | 1d | 2025-04-03 A | 2025-04-03 A | 3468FS+9d | 100% |  | finish no earlier than 2025-04-03 |
| 3470 |  | MCAG Approval of Early Life Support Model | 0d | 2025-04-29 A | 2025-04-29 A | 3469FS+10d | 100% |  | finish no earlier than 2025-04-29 |
| 3471 | 1.11.1.3 | **Service Management Arrangements Implementation** | 838d | 2022-10-31 A | 2026-01-14 A |  | 100% |  |  |
| 3472 |  | Hypercare post M10 | 82d | 2025-09-23 A | 2026-01-14 A | 1802 | 100% |  |  |
| 3473 |  | Monitor Elexon implementation of Service Management arrangements | 436d | 2022-10-31 A | 2024-07-01 A |  | 100% |  |  |
| 3474 | 1.11.1.4 | **Wave 1** | 39d? | 2026-03-31 | 2026-05-22 |  |  | 0d |  |
| 3475 | 1.11.1.4.1 | **Wave 1 - Service Activation Preparation Tasks** | 9d | 2026-03-31 | 2026-04-10 |  |  |  |  |
| 3476 |  | Review Entry/Exit Criteria & Lessons Learned | 0d | 2026-03-31 | 2026-03-31 |  |  | 32025d | finish no earlier than 2026-03-31 |
| 3477 |  | Identify Resources | 1d | 2026-03-31 | 2026-03-31 |  |  | 32025d | start no earlier than 2026-03-31 |
| 3478 |  | Confirmation from Qualification of Wave Participants Complete | 0d | 2026-03-31 | 2026-03-31 |  |  | 32025d | finish no earlier than 2026-03-31 |
| 3479 |  | Agree & Understand Support Model | 1d | 2026-04-01 | 2026-04-01 |  |  | 32024d | start no earlier than 2026-04-01 |
| 3480 |  | Training Confirmation | 1d | 2026-04-02 | 2026-04-02 |  |  | 32023d | start no earlier than 2026-04-02 |
| 3481 |  | Training Confirmation Completed | 0d | 2026-04-02 | 2026-04-02 |  |  | 32023d | finish no earlier than 2026-04-02 |
| 3482 |  | Engagement / Communications with Participants Completed | 0d | 2026-04-03 | 2026-04-03 |  |  | 32022d | finish no earlier than 2026-04-03 |
| 3483 | 1.11.1.4.1.8 | **Internal Communications** | 1d | 2026-04-06 | 2026-04-06 |  |  |  |  |
| 3484 |  | Agree Content for Livewire | 1d | 2026-04-06 | 2026-04-06 |  |  | 32021d | start no earlier than 2026-04-06 |
| 3485 |  | Publish Content for Livewire | 0d | 2026-04-06 | 2026-04-06 |  |  | 32021d | finish no earlier than 2026-04-06 |
| 3486 |  | Validate User Access | 1d | 2026-04-07 | 2026-04-07 |  |  | 32020d | start no earlier than 2026-04-07 |
| 3487 |  | Target Systems and Environments Ready | 1d | 2026-04-08 | 2026-04-08 |  |  | 32019d | start no earlier than 2026-04-08 |
| 3488 |  | Provide LWIs | 1d | 2026-04-09 | 2026-04-09 |  |  | 32018d | start no earlier than 2026-04-09 |
| 3489 |  | Business Readiness Governance Approval | 1d | 2026-04-10 | 2026-04-10 |  |  | 32017d | start no earlier than 2026-04-10 |
| 3490 |  | Wave 1 - Service Activation Preparation Tasks (M) | 0d | 2026-04-10 | 2026-04-10 |  |  | 32017d | finish no earlier than 2026-04-10 |
| 3491 | 1.11.1.4.2 | **Wave 1 - Service Activation Implementation** | 27d? | 2026-04-02 | 2026-05-08 |  |  | 31997d |  |
| 3492 |  | Market Entry to obtain Effective from Date from PP | 1d | 2026-04-02 | 2026-04-02 |  |  | 32023d | start no earlier than 2026-04-02 |
| 3493 |  | PP is Qualified by Code Bodies | 0d | 2026-04-15 | 2026-04-15 | 2722 |  | 32008d | finish no earlier than 2026-04-14 |
| 3494 |  | DIP Promoted to Production | 5d | 2026-04-16 | 2026-04-22 | 3493 |  | 32009d | start no earlier than 2026-04-16 |
| 3495 |  | Create M16 in Customer Solution | 1d | 2026-04-16 | 2026-04-16 |  |  | 32013d | start no earlier than 2026-04-16 |
| 3496 |  | MDD & ISD Publish | 1d | 2026-04-17 | 2026-04-17 | 3493, 3503 |  | 32007d | start no earlier than 2026-04-17 |
| 3497 |  | MDD & ISD Go-Live | 0d | 2026-04-24 | 2026-04-24 | 3496FS+5d |  | 32007d | start no earlier than 2026-04-24 |
| 3498 |  | Wave 1 - Service Activation Implementation Complete (M) | 0d | 2026-04-24 | 2026-04-24 | 3497 |  | 32007d | finish no earlier than 2025-09-05 |
| 3499 |  | Seondary Publish ISD | 1d? | 2026-05-01 | 2026-05-01 |  |  | 31997d | start no earlier than 2026-05-01 |
| 3500 |  | Secondary Go Live ISD | 0d | 2026-05-08 | 2026-05-08 | 3499FS+5d |  | 31997d |  |

| ID | WBS | Task | Duration | Start | Finish | Predecessors | Total float | Constraint |
| --- | --- | --- | --- | --- | --- | --- | --- | --- |
| 3501 | 1.11.1.4.3 | **Wave 1 - Service Activation Implementation MDD** | 2d | 2026-04-15 | 2026-04-16 |  | 32007d |  |
| 3502 |  | MDD Final Circular Completed | 0d | 2026-04-15 | 2026-04-15 |  | 32007d | start no earlier than 2026-04-15 |
| 3503 |  | MDD Manual Update | 2d | 2026-04-15 | 2026-04-16 | 3502 | 32007d |  |
| 3504 | 1.11.1.4.4 | **Wave 1 - Service Activation Hypercare** | 19d | 2026-04-16 | 2026-05-12 |  | 31995d |  |
| 3505 |  | Service& Process Monitoring | 19d | 2026-04-16 | 2026-05-12 |  | 31995d | start no earlier than 2026-04-16 |
| 3506 |  | Daily Reporting | 19d | 2026-04-16 | 2026-05-12 |  | 31995d | start no earlier than 2026-04-16 |
| 3507 |  | Issue Management | 19d | 2026-04-16 | 2026-05-12 |  | 31995d | start no earlier than 2026-04-16 |
| 3508 |  | SA Hypercare Close Down Activities | 2d | 2026-05-11 | 2026-05-12 |  | 31995d | start no earlier than 2026-05-11 |
| 3509 |  | Handover to MHHSP | 2d | 2026-05-11 | 2026-05-12 | 3508SS | 31995d | finish no earlier than 2025-09-18 |
| 3510 |  | Non-SIT LDSO Service Activation Hypercare Complete (M) | 0d | 2026-05-12 | 2026-05-12 | 3509 | 31995d | finish no earlier than 2026-05-12 |
| 3511 | 1.11.1.4.5 | **Wave 1 - Service Activation Retro & Go/No Go** | 9d | 2026-05-12 | 2026-05-22 |  | 31987d |  |
| 3512 |  | Review | 0d | 2026-05-12 | 2026-05-12 |  | 31996d | start no earlier than 2026-05-12 |
| 3513 |  | Lessons Learned | 5d | 2026-05-12 | 2026-05-18 | 3512FF | 31991d | start no earlier than 2026-05-12 |
| 3514 |  | Wave 2 - Service Activation Readiness Review Against Entry/Exit Criteria | 5d | 2026-05-18 | 2026-05-22 |  | 31987d | start no earlier than 2026-05-18 |
| 3515 | 1.11.1.5 | **Wave 2** | 950d | 2022-10-31 | 2026-06-19 |  | 0d |  |
| 3516 | 1.11.1.5.1 | **Wave 2 - Service Activation Implementation** | 16d | 2026-05-15 | 2026-06-08 |  | 31977d |  |
| 3517 |  | Market Entry to obtain Effective from Date from PP | 1d | 2026-05-15 | 2026-05-15 |  | 31992d | start no earlier than 2026-05-15 |
| 3518 |  | PP is Qualified by Code Bodies | 0d | 2026-05-28 | 2026-05-28 | 2760 | 31977d | start no earlier than 2026-05-27 |
| 3519 |  | DIP Promoted to Production | 5d | 2026-05-29 | 2026-06-04 | 3518 | 31978d | finish no earlier than 2025-11-06 |
| 3520 |  | Create M16 in Customer Solution | 1d | 2026-05-29 | 2026-05-29 | 3518 | 31982d | finish no earlier than 2025-11-07 |
| 3521 |  | MDD & ISD Publish | 1d | 2026-05-29 | 2026-05-29 | 3518 | 31977d | start no earlier than 2026-05-29 |
| 3522 |  | MDD & ISD Go-Live | 0d | 2026-06-05 | 2026-06-05 | 3521FS+5d | 31977d |  |
| 3523 |  | Wave 2 - Service Activation Implementation Complete (M) | 0d | 2026-06-08 | 2026-06-08 | 3521 | 31977d | start no earlier than 2026-06-08 |
| 3524 | 1.11.1.5.2 | **Wave 2 - Service Activation Implementation MDD** | 19d | 2022-10-31 | 2022-11-24 |  |  |  |
| 3525 |  | MDD Final Circular Completed | 0d | 2026-05-28 | 2026-05-28 |  | 31984d | start no earlier than 2026-05-28 |
| 3526 |  | MDD Manual Update | 2d | 2026-06-12 | 2026-06-15 |  | 31971d | start no earlier than 2026-06-12 |
| 3527 | 1.11.1.5.3 | **Wave 2 - Service Activation Hypercare** | 9d | 2026-05-27 | 2026-06-08 |  | 31976d |  |
| 3528 |  | Service& Process Monitoring | 9d | 2026-05-27 | 2026-06-08 |  | 31976d | start no earlier than 2026-05-27 |
| 3529 |  | Daily Reporting | 9d | 2026-05-27 | 2026-06-08 | 3528SS | 31976d | finish no earlier than 2025-11-20 |
| 3530 |  | Issue Management | 9d | 2026-05-27 | 2026-06-08 | 3529SS | 31976d | finish no earlier than 2025-11-20 |
| 3531 |  | SA Hypercare Close Down Activities | 3d | 2026-06-04 | 2026-06-08 |  | 31976d | start no earlier than 2026-06-04 |
| 3532 |  | Handover to MHHSP | 1d | 2026-06-08 | 2026-06-08 |  | 31976d | start no earlier than 2026-06-08 |
| 3533 |  | Wave 2 - Service Activation Hypercare Complete (M) | 0d | 2026-06-08 | 2026-06-08 |  | 31977d | start no earlier than 2026-06-08 |
| 3534 | 1.11.1.5.4 | **Wave 2 - Service Activation Retro & Go/No Go** | 10d | 2026-06-08 | 2026-06-19 |  | 31967d |  |
| 3535 |  | Review | 0d | 2026-06-08 | 2026-06-08 |  | 31977d | start no earlier than 2026-06-08 |
| 3536 |  | Lessons Learned | 5d | 2026-06-08 | 2026-06-12 |  | 31972d | start no earlier than 2026-06-08 |
| 3537 |  | Wave 3 - Service Activation Readiness Review Against Entry/Exit Criteria | 5d | 2026-06-15 | 2026-06-19 |  | 31967d | start no earlier than 2026-06-15 |
| 3538 | 1.11.1.6 | **Wave 3** | 990d? | 2022-10-31 | 2026-08-14 |  | 0d |  |
| 3539 | 1.11.1.6.1 | **Wave 3 - Service Activation Preparation Tasks** | 10d | 2026-07-13 | 2026-07-24 |  | 31942d |  |
| 3540 |  | Review Entry/Exit Criteria & Lessons Learned | 0d | 2026-07-13 | 2026-07-13 |  | 31952d | start no earlier than 2026-07-13 |
| 3541 |  | Identify Resources | 1d | 2026-07-13 | 2026-07-13 |  | 31951d | start no earlier than 2026-07-13 |
| 3542 |  | Confirmation from Qualification of Wave Participants Complete | 0d | 2026-07-13 | 2026-07-13 |  | 31952d | start no earlier than 2026-07-13 |
| 3543 |  | Review Handover from Wave 2 | 1d | 2026-07-14 | 2026-07-14 |  | 31950d | start no earlier than 2026-07-14 |
| 3544 |  | Agree & Understand Support Model | 1d | 2026-07-15 | 2026-07-15 |  | 31949d | start no earlier than 2026-07-15 |
| 3545 |  | Confirm Training complete | 1d | 2026-07-16 | 2026-07-16 |  | 31948d | start no earlier than 2026-07-16 |
| 3546 |  | Engagement / Communications with Participants | 1d | 2026-07-17 | 2026-07-17 |  | 31947d | start no earlier than 2026-07-17 |
| 3547 | 1.11.1.6.1.8 | **Internal Communications** | 1d | 2026-07-20 | 2026-07-20 |  | 31946d |  |
| 3548 |  | Agree Content for Livewire | 1d | 2026-07-20 | 2026-07-20 |  | 31946d | start no earlier than 2026-07-20 |
| 3549 |  | Publish Content for Livewire | 0d | 2026-07-20 | 2026-07-20 |  | 31947d | start no earlier than 2026-07-20 |
| 3550 |  | Validate User Access | 1d | 2026-07-21 | 2026-07-21 |  | 31945d | start no earlier than 2026-07-21 |
| 3551 |  | Target Systems and Environments Ready | 1d | 2026-07-22 | 2026-07-22 |  | 31944d | start no earlier than 2026-07-22 |
| 3552 |  | Provide LWIs | 1d | 2026-07-23 | 2026-07-23 |  | 31943d | start no earlier than 2026-07-23 |
| 3553 |  | Business Readiness Governance Approval | 1d | 2026-07-24 | 2026-07-24 |  | 31942d | finish no earlier than 2026-07-24 |
| 3554 |  | Wave 3 - Service Activation Preparation Tasks Completed | 0d | 2026-07-24 | 2026-07-24 | 3541, 3543, 3544, 3545, 3546, 3547, 3550, 3551, 3552, 3553 | 31942d | finish no earlier than 2026-07-24 |
| 3555 | 1.11.1.6.2 | **Wave 3 - Service Activation Implementation** | 16d | 2022-10-31 | 2022-11-21 |  |  |  |
| 3556 |  | Market Entry to obtain Effective from Date from PP | 1d | 2026-07-17 | 2026-07-17 |  | 31947d | start no earlier than 2026-07-17 |
| 3557 |  | PP Qualified by Code Bodies | 0d | 2026-07-30 | 2026-07-30 | 2798 | 31932d | start no earlier than 2026-07-29 |
| 3558 |  | DIP Promoted to Production | 5d | 2026-07-31 | 2026-08-06 | 3557 | 31933d | finish no earlier than 2025-12-30 |
| 3559 |  | Create M16 in Customer Solution | 1d | 2026-07-31 | 2026-07-31 | 3557 | 31937d | start no earlier than 2026-07-31 |
| 3560 |  | MDD & ISD Publish | 1d | 2026-07-31 | 2026-07-31 | 3557 | 31932d | finish no earlier than 2025-12-30 |
| 3561 |  | MDD & ISD Go-Live | 0d | 2026-08-07 | 2026-08-07 | 3560FS+5d | 31932d |  |
| 3562 | 1.11.1.6.3 | **Wave 3 - Service Activation Implementation MDD** | 12d? | 2026-07-30 | 2026-08-14 |  | 31927d |  |
| 3563 |  | MDD Final Circular Completed | 1d? | 2026-07-30 | 2026-07-30 |  | 31938d | start no earlier than 2026-07-30 |
| 3564 |  | MDD Manual Update | 1d? | 2026-08-14 | 2026-08-14 |  | 31927d | start no earlier than 2026-08-14 |
| 3565 | 1.11.1.6.4 | **Wave 3 - Service Activation Hypercare** | 9d | 2026-07-29 | 2026-08-10 |  | 31931d |  |
| 3566 |  | Service& Process Monitoring | 9d | 2026-07-29 | 2026-08-10 |  | 31931d | start no earlier than 2026-07-29 |
| 3567 |  | Daily Reporting | 9d | 2026-07-29 | 2026-08-10 | 3566SS | 31931d | finish no earlier than 2026-01-16 |
| 3568 |  | Issue Management | 9d | 2026-07-29 | 2026-08-10 | 3567SS | 31931d | finish no earlier than 2026-01-16 |
| 3569 |  | SA Hypercare Close Down Activities | 3d | 2026-08-06 | 2026-08-10 |  | 31931d | start no earlier than 2026-08-06 |
| 3570 |  | Handover to MHHSP | 1d | 2026-08-10 | 2026-08-10 |  | 31931d | start no earlier than 2026-08-10 |

| ID | WBS | Task | Duration | Start | Finish | Predecessors | Complete | Total float | Constraint |
| --- | --- | --- | --- | --- | --- | --- | --- | --- | --- |
| 3571 |  | Wave 3 Service Activation Hypercare Complete (M) | 0d | 2026-08-10 | 2026-08-10 | 3570 |  | 31931d |  |
| 3572 | 1.11.1.6.5 | **Wave 3 - Service Activation Retro & Go/No Go** | 43d | 2026-06-17 | 2026-08-14 |  |  | 31927d |  |
| 3573 |  | Review | 0d | 2026-08-10 | 2026-08-10 |  |  | 31932d | start no earlier than 2026-08-10 |
| 3574 |  | Lessons Learned | 5d | 2026-08-10 | 2026-08-14 |  |  | 31927d | start no earlier than 2026-08-10 |
| 3575 |  | Wave 4 - Service Activation Readiness Review Against Entry/Exit Criteria | 5d | 2026-06-17 | 2026-06-23 |  |  | 31965d | start no earlier than 2026-06-17 |
| 3576 | 1.11.1.7 | **Wave 4** | 1055d? | 2022-10-31 | 2026-11-14 |  |  | 0d |  |
| 3577 | 1.11.1.7.1 | **Wave 4 - Service Activation Preparation Tasks** | 10d | 2026-09-07 | 2026-09-18 |  |  | 31902d |  |
| 3578 |  | Review Entry/Exit Criteria & Lessons Learned | 0d | 2026-09-07 | 2026-09-07 |  |  | 31912d | start no earlier than 2026-09-07 |
| 3579 |  | Identify Resources | 1d | 2026-09-07 | 2026-09-07 |  |  | 31911d | start no earlier than 2026-09-07 |
| 3580 |  | Confirmation from Qualification of Wave Participants Complete | 0d | 2026-09-07 | 2026-09-07 |  |  | 31912d | start no earlier than 2026-09-07 |
| 3581 |  | Review Handover from Wave 3 | 1d | 2026-09-08 | 2026-09-08 |  |  | 31910d | finish no earlier than 2026-09-08 |
| 3582 |  | Agree & Understand Support Model | 1d | 2026-09-09 | 2026-09-09 |  |  | 31909d | start no earlier than 2026-09-09 |
| 3583 |  | Confirm Training complete | 1d | 2026-09-10 | 2026-09-10 |  |  | 31908d | start no earlier than 2026-09-10 |
| 3584 |  | Engagement / Communications with Participants | 1d | 2026-09-11 | 2026-09-11 |  |  | 31907d | start no earlier than 2026-09-11 |
| 3585 | 1.11.1.7.1.8 | **Internal Communications** | 1d | 2026-09-14 | 2026-09-14 |  |  | 31906d |  |
| 3586 |  | Agree Content for Livewire | 1d | 2026-09-14 | 2026-09-14 |  |  | 31906d | start no earlier than 2026-09-14 |
| 3587 |  | Publish Content for Livewire | 0d | 2026-09-14 | 2026-09-14 |  |  | 31907d | start no earlier than 2026-09-14 |
| 3588 |  | Validate User Access | 1d | 2026-09-15 | 2026-09-15 |  |  | 31905d | start no earlier than 2026-09-15 |
| 3589 |  | Target Systems and Environments Ready | 1d | 2026-09-16 | 2026-09-16 |  |  | 31904d | start no earlier than 2026-09-16 |
| 3590 |  | Provide LWIs | 1d | 2026-09-17 | 2026-09-17 |  |  | 31903d | finish no earlier than 2026-09-17 |
| 3591 |  | Business Readiness Governance Approval | 1d | 2026-09-18 | 2026-09-18 |  |  | 31902d | finish no earlier than 2026-09-18 |
| 3592 |  | Wave 4 - Service Activation Preparation Tasks Completed | 0d | 2026-09-18 | 2026-09-18 | 3579, 3581, 3582, 3583, 3584, 3585, 3588, 3589, 3590, 3591 |  | 31902d | finish no earlier than 2026-09-18 |
| 3593 | 1.11.1.7.2 | **Wave 4 - Service Activation Implementation** | 16d | 2022-10-31 | 2022-11-21 |  |  |  |  |
| 3594 |  | Market Entry to obtain Effective from Date from PP | 1d | 2026-09-11 | 2026-09-11 |  |  | 31907d | start no earlier than 2026-09-11 |
| 3595 |  | MHHSP Enabled Confirmation | 0d | 2026-09-24 | 2026-09-24 | 2829 |  | 31892d | start no earlier than 2026-09-23 |
| 3596 |  | DIP Promoted to Production | 5d | 2026-09-25 | 2026-10-01 | 3595 |  | 31893d | finish no earlier than 2026-03-05 |
| 3597 |  | Create M16 in Customer Solution | 1d | 2026-09-25 | 2026-09-25 | 3595 |  | 31892d | start no earlier than 2026-09-25 |
| 3598 |  | MDD & ISD Publish | 1d | 2026-09-25 | 2026-09-25 | 3597SS |  | 31892d | finish no earlier than 2026-03-06 |
| 3599 |  | MDD & ISD Go-Live | 0d | 2026-10-02 | 2026-10-02 | 3598FS+5d |  | 31892d |  |
| 3600 |  | Wave 4 - Service Activation Implementation Complete (M) | 0d | 2026-10-05 | 2026-10-05 | 3598 |  | 31892d | start no earlier than 2026-10-05 |
| 3601 | 1.11.1.7.3 | **Wave 4 - Service Activation Implementation MDD** | 17d? | 2026-09-24 | 2026-10-16 |  |  | 31882d |  |
| 3602 |  | MDD Final Circular Completed | 1d? | 2026-09-24 | 2026-09-24 |  |  | 31898d | start no earlier than 2026-09-24 |
| 3603 |  | MDD Manual Update | 1d? | 2026-10-16 | 2026-10-16 |  |  | 31882d | start no earlier than 2026-10-16 |
| 3604 | 1.11.1.7.4 | **Wave 4 - Service Activation Hypercare** | 38d | 2026-09-23 | 2026-11-14 |  |  | 31862d |  |
| 3605 |  | Service& Process Monitoring | 9d | 2026-09-23 | 2026-10-05 |  |  | 31891d | start no earlier than 2026-09-23 |
| 3606 |  | Daily Reporting | 9d | 2026-09-23 | 2026-10-05 |  |  | 31891d | start no earlier than 2026-09-23 |
| 3607 |  | Issue Management | 9d | 2026-09-23 | 2026-10-05 |  |  | 31891d | start no earlier than 2026-09-23 |
| 3608 |  | SA Hypercare Close Down Activities | 2d | 2026-10-02 | 2026-10-05 |  |  | 31891d | start no earlier than 2026-10-02 |
| 3609 |  | Handover to MHHSP | 1d | 2026-10-05 | 2026-10-05 |  |  | 31891d | start no earlier than 2026-10-05 |
| 3610 |  | Wave 4 - Service Activation Hypercare Complete (M) | 0d | 2026-10-05 | 2026-10-05 | 3609 |  | 31891d | finish no earlier than 2026-03-25 |
| 3611 | 1.11.1.7.4.7 | **Service Activation Transition Completion** | 25d | 2026-10-12 | 2026-11-14 |  |  | 31862d |  |
| 3612 |  | Lessons Learnt Review | 5d | 2026-10-12 | 2026-10-16 |  |  | 31862d | start no earlier than 2026-10-12 |
| 3613 |  | Document and circulate Lessons Learnt | 15d | 2026-10-19 | 2026-11-06 | 3612 |  | 31862d | finish no earlier than 2026-11-06 |
| 3614 |  | Handover to Elexon | 5d | 2026-11-09 | 2026-11-14 | 3613 |  | 31862d | finish no earlier than 2026-11-14 |
| 3615 |  | Service Activation Transition Completed | 0d | 2026-11-14 | 2026-11-14 | 3612, 3613, 3614 |  | 31862d | finish no earlier than 2026-11-14 |
| 3616 | 1.11.2 | **Implement Early Life Support Plan** | 55d | 2025-07-07 A | 2025-09-19 A |  | 100% |  |  |
| 3617 |  | Implement Early Life Support Plan | 55d | 2025-07-07 A | 2025-09-19 A |  | 100% |  | start no earlier than 2025-07-07 |
| 3618 | 1.11.3 | **Early Life Support Phase** | 81d | 2025-10-23 A | 2026-02-12 |  | 99% | 32058d |  |
| 3619 |  | Phase 1 End | 26d | 2025-10-23 A | 2025-11-27 A | 3453 | 100% |  |  |
| 3620 |  | Phase 2 End | 20d | 2025-11-21 A | 2025-12-18 A | 3619SS | 100% |  | start no earlier than 2025-11-21 |
| 3621 |  | Phase 3 End/Early Life Exit | 40d | 2025-12-19 A | 2026-02-12 | 3620 | 98% | 32058d | finish no earlier than 2026-02-12 |
| 3622 | 1.11.4 | **Business Continuity and Disaster Recovery Plan** | 40d | 2025-07-31 A | 2025-09-24 A |  | 100% |  |  |
| 3623 |  | Central Parties BCDRs in Place | 20d | 2025-07-31 A | 2025-08-27 A | 3022FS-38d | 100% |  |  |
| 3624 |  | Risk Based Assurance of Cental Party BCDRs | 20d | 2025-08-28 A | 2025-09-24 A | 3623 | 100% |  |  |
| 3625 | 1.11.5 | **PP Business Change** | 129d | 2025-02-03 A | 2025-07-31 A |  | 100% |  |  |
| 3626 |  | Plan stakeholder management | 129d | 2025-02-03 A | 2025-07-31 A |  | 100% |  | start no earlier than 2025-02-03 |
| 3627 |  | Manage stakeholders | 129d | 2025-02-03 A | 2025-07-31 A |  | 100% |  | start no earlier than 2025-02-03 |
| 3628 |  | Develop & implement changes to KPIs, organisation & people management | 129d | 2025-02-03 A | 2025-07-31 A |  | 100% |  | start no earlier than 2025-02-03 |
| 3629 |  | Develop & test changes to business processes | 129d | 2025-02-03 A | 2025-07-31 A |  | 100% |  | start no earlier than 2025-02-03 |
| 3630 |  | Develop and deliver training | 129d | 2025-02-03 A | 2025-07-31 A |  | 100% |  | start no earlier than 2025-02-03 |
| 3631 |  | Programme support for PP Business Change activities | 129d | 2025-02-03 A | 2025-07-31 A |  | 100% |  | start no earlier than 2025-02-03 |
| 3632 | 1.11.6 | **Transition to New Settlement Timetable (M16)** | 566d | 2025-10-22 A | 2027-12-23 |  | 7% | 31573d |  |
| 3633 |  | Elexon to produce Settlement Calendar for Settlement Year 2025/2026 | 0d | 2025-10-22 A | 2025-10-22 A | 3453 | 100% |  |  |
| 3634 |  | Elexon monitor settlement data of migrated MPANs | 436d | 2025-10-23 A | 2027-06-24 | 3633 | 9% | 31579d |  |
| 3635 |  | M16 Checkpoint 1 | 0d | 2026-06-25 | 2026-06-25 | 3633FS+176d |  | 31578d |  |
| 3636 |  | Confirm if M16 date retained as 07/12/2026 | 0d | 2026-07-23 | 2026-07-23 | 3635FS+20d |  | 31578d |  |
| 3637 |  | Readiness assessment of participants' readiness to transition to new Settlement Timetable | 0d | 2026-08-20 | 2026-08-20 | 3636FS+20d |  | 31578d |  |
| 3638 |  | Elexon to produce Settlement Calendar for Settlement Year 2026 up until day before M16 cutover | 0d | 2026-10-19 | 2026-10-19 | 3637FS+42d |  | 31578d |  |
| 3639 |  | M16 Checkpoint 2 | 0d | 2027-04-02 | 2027-04-02 | 3638FS+119d |  | 31578d |  |
| 3640 |  | Readiness assessment of participants' readiness to transition to new Settlement Timetable | 0d | 2027-04-19 | 2027-04-19 | 3639FS+11d |  | 31578d |  |

| ID | WBS | Task | Duration | Start | Finish | Predecessors | Complete | Total float | Constraint |
| --- | --- | --- | --- | --- | --- | --- | --- | --- | --- |
| 3641 |  | Confirm M16 Date | 0d | 2027-04-30 | 2027-04-30 | 3640FS+9d |  | 31578d |  |
| 3642 |  | Raise fast track change to ISD (November publish) | 0d | 2027-04-30 | 2027-04-30 | 3641 |  | 31618d |  |
| 3643 | 1.11.6.11 | **M16 Approval Window** | 129d | 2027-06-25 | 2027-12-23 |  |  | 31573d |  |
| 3644 |  | Panel approval that M16 criteria met | 0d | 2027-06-25 | 2027-06-25 | 3641FS+40d |  | 31578d |  |
| 3645 |  | Cut over to new settlement timetable (M16) | 0d | 2027-07-02 | 2027-07-02 | 3644, 3457FS+40d, 3634, 3642, 3252 |  | 31573d |  |
| 3646 |  | Maximum 6-month window for approval of M16 | 124d | 2027-07-05 | 2027-12-23 | 3645 |  | 31573d |  |
| 3647 |  | Cut over to new settlement timetable (M16*) - Late Exit | 0d | 2027-12-23 | 2027-12-23 | 3646 |  | 31573d |  |
| 3648 | 1.12 | **EARLY LIVE RUNNING** | 45d | 2027-05-10 | 2027-07-09 |  |  | 31692d |  |
| 3649 | 1.12.1 | **Early Live Running Stabilisation Period** | 45d | 2027-05-10 | 2027-07-09 |  |  | 31692d |  |
| 3650 |  | Manage Early Live Running stabilisation period | 45d | 2027-05-10 | 2027-07-09 | 3457 |  | 31692d |  |
| 3651 |  | Monitor Early Live Running stabilisation period | 45d | 2027-05-10 | 2027-07-09 | 3650SS |  | 31692d |  |
| 3652 | 1.13 | **PROGRAMME CLOSURE** | 80d | 2027-03-08 | 2027-06-25 |  |  | 31702d |  |
| 3653 | 1.13.1 | **Handover Pack** | 80d | 2027-03-08 | 2027-06-25 |  |  | 31702d |  |
| 3654 | 1.13.1.1 | **Draft Handover Pack (for M15)** | 40d | 2027-03-08 | 2027-04-30 |  |  | 31742d |  |
| 3655 |  | Develop document | 20d | 2027-03-08 | 2027-04-02 | 3457FS-45d |  | 31742d |  |
| 3656 |  | Document review and update | 20d | 2027-04-05 | 2027-04-30 | 3655 |  | 31742d |  |
| 3657 |  | Draft Handover Pack approved | 0d | 2027-04-30 | 2027-04-30 | 3656 |  | 31742d |  |
| 3658 | 1.13.1.2 | **Master Handover Pack (for M16)** | 40d | 2027-05-03 | 2027-06-25 |  |  | 31702d |  |
| 3659 |  | Update document | 20d | 2027-05-03 | 2027-05-28 | 3645FS-45d |  | 31702d |  |
| 3660 |  | Document review and update | 20d | 2027-05-31 | 2027-06-25 | 3659 |  | 31702d |  |
| 3661 |  | Master Handover Pack approved | 0d | 2027-06-25 | 2027-06-25 | 3660 |  | 31702d |  |
| 3662 | 1.13.2 | **Programme Lessons Learned** | 40d | 2027-03-08 | 2027-04-30 |  |  | 31742d |  |
| 3663 |  | Develop document | 20d | 2027-03-08 | 2027-04-02 | 3457FS-45d |  | 31742d |  |
| 3664 |  | Document review and update | 20d | 2027-04-05 | 2027-04-30 | 3663 |  | 31742d |  |
| 3665 |  | Programme Lessons Learned document approved | 0d | 2027-04-30 | 2027-04-30 | 3664 |  | 31742d |  |
| 3666 | 1.13.3 | **Programme Closure Report** | 40d | 2027-03-08 | 2027-04-30 |  |  | 31742d |  |
| 3667 |  | Develop document | 20d | 2027-03-08 | 2027-04-02 | 3457FS-45d |  | 31742d |  |
| 3668 |  | Document review and update | 20d | 2027-04-05 | 2027-04-30 | 3667 |  | 31742d |  |
| 3669 |  | Programme Closure Report approved | 0d | 2027-04-30 | 2027-04-30 | 3668 |  | 31742d |  |
| 3670 | 1.13.4 | **Benefit Realisation Report** | 45d | 2027-03-08 | 2027-05-07 |  |  | 31737d |  |
| 3671 |  | Develop document | 20d | 2027-03-08 | 2027-04-02 | 3457FS-45d |  | 31737d |  |
| 3672 |  | Document review and update | 20d | 2027-04-05 | 2027-04-30 | 3671 |  | 31737d |  |
| 3673 |  | Benefit Realisation Report approved | 0d | 2027-05-07 | 2027-05-07 | 3672FS+5d |  | 31737d |  |
| 3674 | 1.13.5 | **Operating Model Gap Review with recommendations** | 45d | 2027-03-08 | 2027-05-07 |  |  | 31737d |  |
| 3675 |  | Develop document | 20d | 2027-03-08 | 2027-04-02 | 3457FS-45d |  | 31737d |  |
| 3676 |  | Document review and update | 20d | 2027-04-05 | 2027-04-30 | 3675 |  | 31737d |  |
| 3677 |  | Operating Model Gap Review with recommendations approved | 0d | 2027-05-07 | 2027-05-07 | 3676FS+5d |  | 31737d |  |
| 3678 | 1.13.6 | **Post-Implementation Review** | 45d | 2027-03-08 | 2027-05-07 |  |  | 31737d |  |
| 3679 |  | Develop document | 20d | 2027-03-08 | 2027-04-02 | 3457FS-45d |  | 31737d |  |
| 3680 |  | Document review and update | 20d | 2027-04-05 | 2027-04-30 | 3679 |  | 31737d |  |
| 3681 |  | Post-Implementation Review approved | 0d | 2027-05-07 | 2027-05-07 | 3680FS+5d |  | 31737d |  |
| 3682 | 1.13.7 | **Reinforcement Guide** | 45d | 2027-03-08 | 2027-05-07 |  |  | 31737d |  |
| 3683 |  | Develop document | 20d | 2027-03-08 | 2027-04-02 | 3457FS-45d |  | 31737d |  |
| 3684 |  | Document review and update | 20d | 2027-04-05 | 2027-04-30 | 3683 |  | 31737d |  |
| 3685 |  | Reinforcement Guide approved | 0d | 2027-05-07 | 2027-05-07 | 3684FS+5d |  | 31737d |  |
| 3686 | 1.13.8 | **Material and Licenses Transfer** | 60d | 2027-04-05 | 2027-06-25 |  |  | 31702d |  |
| 3687 |  | Transfer of Programme material to Elexon and perpetual licenses as appropriate | 60d | 2027-04-05 | 2027-06-25 | 3645FF-5d |  | 31702d |  |
| 3688 | 1.14 | **READINESS ASSESSMENTS** | 1209d | 2022-10-31 A | 2027-06-17 |  | 44% | 31708d |  |
| 3689 | 1.14.1 | **Readiness Assessment 3 - Design and Build Progress Check and CP2 Check** | 60d | 2023-09-05 A | 2023-11-27 A |  | 100% |  |  |
| 3690 |  | Launch Readiness Assessment survey | 0d | 2023-09-05 A | 2023-09-05 A | 1483FS-40d | 100% |  |  |
| 3691 |  | PPs submit survey responses | 15d | 2023-09-05 A | 2023-09-25 A | 3690 | 100% |  |  |
| 3692 |  | Analyse survey responses | 15d | 2023-09-26 A | 2023-10-16 A | 3691 | 100% |  |  |
| 3693 |  | Conduct deep-dive interviews (sample of PPs) | 15d | 2023-09-26 A | 2023-10-16 A | 3691 | 100% |  |  |
| 3694 |  | Produce Readiness Assessment Reports (Overall Report & Individual Participant Reports) | 25d | 2023-10-17 A | 2023-11-20 A | 3692, 3693 | 100% |  |  |
| 3695 |  | Readiness Assessment 3 - Design & Build Checkpoint 1 - Completed (incl. Readiness Assessment Report approval) | 0d | 2023-11-27 A | 2023-11-27 A | 3694FS+5d | 100% |  |  |
| 3696 | 1.14.2 | **Readiness Assessment 5 / 6 - Start of Qualification and Participant Readiness for M10 and M11 and CP3/CP4 check** | 47d | 2025-04-28 A | 2025-07-01 A |  | 100% |  |  |
| 3697 |  | Launch Readiness Assessment survey | 0d | 2025-04-28 A | 2025-04-28 A |  | 100% |  | start no earlier than 2025-04-28 |
| 3698 |  | PPs submit survey responses | 15d | 2025-04-28 A | 2025-05-16 A | 3697 | 100% |  |  |
| 3699 |  | Analyse survey responses | 30d | 2025-05-19 A | 2025-06-27 A | 3698 | 100% |  |  |
| 3700 |  | Conduct deep-dive interviews (sample of PPs) | 30d | 2025-05-19 A | 2025-06-27 A |  | 100% |  | start no earlier than 2025-05-19 |
| 3701 |  | Produce Readiness Assessment Reports (Overall Report & Individual Participant Reports) | 15d | 2025-06-09 A | 2025-06-27 A |  | 100% |  | start no earlier than 2025-06-09 |
| 3702 |  | Readiness Assessment 5 / 6 - Start of Qualification and Participant Readiness for M10 and M11 and CP3/CP4 check (incl. Readiness Assessment Report approval) Completed | 0d | 2025-07-01 A | 2025-07-01 A | 3701FS+2d | 100% |  | finish no earlier than 2025-07-01 |
| 3703 | 1.14.3 | **Readiness Assessment 7 - Migration Checkpoint** | 45d | 2026-01-12 | 2026-03-13 |  |  | 32037d |  |
| 3704 |  | Launch Readiness Assessment survey | 0d | 2026-01-12 | 2026-01-12 |  |  | 32037d | start no earlier than 2026-01-12 |
| 3705 |  | PPs submit survey responses | 15d | 2026-01-12 | 2026-01-30 | 3704 |  | 32037d |  |
| 3706 |  | Analyse survey responses | 15d | 2026-02-02 | 2026-02-20 | 3705 |  | 32037d |  |
| 3707 |  | Conduct deep-dive interviews (sample of PPs) | 15d | 2026-02-02 | 2026-02-20 | 3705 |  | 32037d |  |
| 3708 |  | Produce Readiness Assessment Reports (Overall Report & Individual Participant Reports) | 15d | 2026-02-23 | 2026-03-13 | 3706, 3707 |  | 32037d |  |
| 3709 | 1.14.4 | **Readiness Assessment 7 - Migration Checkpoint** | 23d | 2026-03-02 | 2026-04-01 |  |  | 32024d |  |
| 3710 |  | Readiness Assessment 7 survey issued | 0d | 2026-03-02 | 2026-03-02 |  |  | 32024d | start no earlier than 2026-03-02 |

| ID | WBS | Task | Duration | Start | Finish | Predecessors | Complete | Total float | Constraint |
| --- | --- | --- | --- | --- | --- | --- | --- | --- | --- |
| 3711 |  | Draft response review point | 3d | 2026-03-06 | 2026-03-10 | 3710FS+4d |  | 32040d |  |
| 3712 |  | Evidence asessment | 19d | 2026-03-06 | 2026-04-01 |  |  | 32024d | start no earlier than 2026-03-06 |
| 3713 |  | Readiness Assessment 7 survey closes | 0d | 2026-03-16 | 2026-03-16 | 3710FS+11d |  | 32024d | start no earlier than 2026-03-11 |
| 3714 |  | Report on Readiness Assessment 7 findings at PSG | 0d | 2026-04-01 | 2026-04-01 | 3713FS+12d |  | 32024d |  |
| 3715 |  | Readiness Assessment 7 - Migration Checkpoint - Completed (incl. Readiness Assessment Report approval) | 0d | 2026-04-01 | 2026-04-01 | 3714 |  | 32024d |  |
| 3716 | 1.14.5 | **Readiness Assessment 8 - Ready to Accept New MPANs** | 49d | 2026-08-06 | 2026-10-13 |  |  | 31885d |  |
| 3717 |  | Launch Readiness Assessment survey | 0d | 2026-08-06 | 2026-08-06 | 2831FS-60d |  | 31885d |  |
| 3718 |  | PPs submit survey responses | 15d | 2026-08-06 | 2026-08-26 | 3717 |  | 31885d |  |
| 3719 |  | Analyse survey responses | 15d | 2026-08-27 | 2026-09-16 | 3718 |  | 31885d |  |
| 3720 |  | Conduct deep-dive interviews (sample of PPs) | 15d | 2026-08-27 | 2026-09-16 | 3718 |  | 31885d |  |
| 3721 |  | Produce Readiness Assessment Reports (Overall Report & Individual Participant Reports) | 15d | 2026-09-17 | 2026-10-07 | 3719, 3720 |  | 31885d |  |
| 3722 |  | Readiness Assessment 8 - Ready to Accept New MPANs - Completed (incl. Readiness Assessment Report approval) | 0d | 2026-10-13 | 2026-10-13 | 3721FS+4d |  | 31885d |  |
| 3723 | 1.14.6 | **Readiness Assessment 9 - Ready for New Settlement Timetable and CP5 Check** | 49d | 2027-04-12 | 2027-06-17 |  |  | 31708d |  |
| 3724 |  | Launch Readiness Assessment survey | 0d | 2027-04-12 | 2027-04-12 | 3645FS-60d |  | 31708d |  |
| 3725 |  | PPs submit survey responses | 15d | 2027-04-12 | 2027-04-30 | 3724 |  | 31708d |  |
| 3726 |  | Analyse survey responses | 15d | 2027-05-03 | 2027-05-21 | 3725 |  | 31708d |  |
| 3727 |  | Conduct deep-dive interviews (sample of PPs) | 15d | 2027-05-03 | 2027-05-21 | 3725 |  | 31708d |  |
| 3728 |  | Produce Readiness Assessment Reports (Overall Report & Individual Participant Reports) | 15d | 2027-05-24 | 2027-06-11 | 3726, 3727 |  | 31708d |  |
| 3729 |  | Readiness Assessment 9 - Readiness for New Settlement Timetable - Completed (incl. Readiness Assessment Report approval) | 0d | 2027-06-17 | 2027-06-17 | 3728FS+4d |  | 31708d |  |
| 3730 | 1.14.7 | **Readiness Assessments - Tier 1 Milestones** | 1209d | 2022-10-31 A | 2027-06-17 |  |  | 31708d |  |
| 3731 |  | Readiness Assessment 6 - Start of Migration - Completed (incl. Readiness Assessment Report approval) | 0d | 2025-07-01 A | 2025-07-01 A | 3702 | 100% |  | finish no earlier than 2025-04-04 |
| 3732 |  | Readiness Assessment 7 - Migration Checkpoint - Completed (incl. Readiness Assessment Report approval) | 0d | 2022-10-31 | 2022-10-31 |  |  | 32917d |  |
| 3733 |  | Readiness Assessment 8 - Ready to Accept New MPANs - Completed (incl. Readiness Assessment Report approval) | 0d | 2026-10-13 | 2026-10-13 | 3722 |  | 31885d |  |
| 3734 |  | Readiness Assessment 9 - Readiness for New Settlement Timetable - Completed (incl. Readiness Assessment Report approval) | 0d | 2027-06-17 | 2027-06-17 | 3729 |  | 31708d |  |
| 3735 | 1.15 | **CONTROL POINTS** | 1204d | 2022-11-10 A | 2027-06-23 |  | 79% | 31705d |  |
| 3736 | 1.15.1 | **Control Point 1 - Start of System Design, Build & Test** | 20d | 2022-11-10 A | 2022-12-07 A |  | 100% |  |  |
| 3737 |  | Control Point 1 Preparation (incl. Control Point Report development and review) | 15d | 2022-11-10 A | 2022-11-30 A | 3738SS-20d | 100% |  |  |
| 3738 |  | Control Point 1 - Start of System Design, Build & Test (incl. Control Point Report approval) | 0d | 2022-12-07 A | 2022-12-07 A |  | 100% |  | must finish on 2022-12-07 |
| 3739 | 1.15.2 | **Control Point 2 - Start of Integration & Test** | 20d | 2023-10-02 A | 2023-10-30 A |  | 100% |  |  |
| 3740 |  | Control Point 2 Preparation (incl. Control Point Report development and review) | 15d | 2023-10-02 A | 2023-10-20 A | 3741SS-20d | 100% |  |  |
| 3741 |  | Control Point 2 - Start of Integration & Test (incl. Control Point Report approval) | 0d | 2023-10-30 A | 2023-10-30 A | 1483 | 100% |  |  |
| 3742 | 1.15.3 | **Control Point 3/4 - Readiness for Migration** | 25d | 2025-08-21 A | 2025-09-24 A |  | 100% |  |  |
| 3743 |  | Control Point 3/4 Preparation (incl. Control Point Report development and review) | 25d | 2025-08-21 A | 2025-09-24 A | 3744SS-20d | 100% |  |  |
| 3744 |  | Control Point 3/4 - Readiness for Migration (incl. Control Point Report approval) | 0d | 2025-09-24 A | 2025-09-24 A | 1802FS-3d | 100% |  | finish no earlier than 2025-09-24 |
| 3745 | 1.15.4 | **Control Point 5 - Cut Over to New Settlement Timetable** | 20d | 2027-05-26 | 2027-06-23 |  |  | 31705d |  |
| 3746 |  | Control Point 5 Preparation (incl. Control Point Report development and review) | 15d | 2027-05-26 | 2027-06-15 | 3747SS-20d |  | 31710d |  |
| 3747 |  | Control Point 5 - Cut Over to New Settlement Timetable (incl. Control Point Report approval) | 0d | 2027-06-23 | 2027-06-23 | 3645FS-8d |  | 31705d |  |
| 3748 | 1.15.5 | **Control Points - Tier 1 Milestones** | 1184d | 2022-12-07 A | 2027-06-23 |  |  | 31705d |  |
| 3749 |  | Control Point 1 - Start of System Design, Build & Test (incl. Control Point Report approval) | 0d | 2022-12-07 A | 2022-12-07 A | 3738SS | 100% |  |  |
| 3750 |  | Control Point 2 - Start of Integration & Test (incl. Control Point Report approval) | 0d | 2023-10-30 A | 2023-10-30 A | 3741SS | 100% |  |  |
| 3751 |  | Control Point 3/4 - Readiness for Migration (incl. Control Point Report approval) | 0d | 2025-09-24 A | 2025-09-24 A | 3744SS | 100% |  |  |
| 3752 |  | Control Point 5 - Cut Over to New Settlement Timetable (incl. Control Point Report approval) | 0d | 2027-06-23 | 2027-06-23 | 3747SS |  | 31705d |  |
| 3753 | 1.16 | **MILESTONE RANGE CHECKPOINTS** | 442d | 2025-07-31 A | 2027-04-12 |  |  | 31757d |  |
| 3754 | 1.16.1 | **M10, M11, M12 and M13 milestone checkpoint** | 0d | 2025-07-31 A | 2025-07-31 A |  | 100% |  |  |
| 3755 |  | M10, M11, M12, and M13 milestone checkpoint - date approval | 0d | 2025-07-31 A | 2025-07-31 A | 3453FS-3mo, 3455FS-3mo, 3451FS-3mo, 1802FS-3mo | 100% |  |  |
| 3756 | 1.16.2 | **M14 milestone checkpoint** | 0d | 2026-08-06 | 2026-08-06 |  |  | 31934d |  |
| 3757 |  | M14 milestone checkpoint - date approval | 0d | 2026-08-06 | 2026-08-06 | 2831FS-3mo |  | 31934d |  |
| 3758 | 1.16.3 | **M15 milestone checkpoint** | 0d | 2027-02-15 | 2027-02-15 |  |  | 31797d |  |
| 3759 |  | M15 milestone checkpoint - date approval | 0d | 2027-02-15 | 2027-02-15 | 3457FS-3mo |  | 31797d |  |
| 3760 | 1.16.4 | **M16 milestone checkpoint** | 0d | 2027-04-12 | 2027-04-12 |  |  | 31757d |  |
| 3761 |  | M16 milestone checkpoint - date approval | 0d | 2027-04-12 | 2027-04-12 | 3645FS-3mo |  | 31757d |  |

## Version 22 (data date 2026-02-25, saved 2026-02-25, file MHHS-DEL1139 - MHHS Plan v6.44.mpp)

Last finish 2148-12-31 → 2027-12-23 (-44203d). Complete tasks 2620 → 2639.

Added:

| ID | Task | Duration | Start | Finish | Predecessors | Constraint |
| --- | --- | --- | --- | --- | --- | --- |
| 2350 | Business Validations Analysis | 10d | 2026-01-21 A | 2026-02-03 A | 2318 |  |
| 2357 | CR45 Code Merge | 10d | 2026-02-18 A | 2026-03-03 | 2320 |  |
| 2358 | Tech Debt DA2: Azure cost reduction, optimising data storage and processing | 40d | 2026-02-18 A | 2026-04-14 | 2320 |  |
| 2359 | Tech Debt DA4: Code maintainability enhancements | 40d | 2026-02-18 A | 2026-04-14 | 2320 |  |
| 2372 | VAS override functionality | 20d | 2026-02-18 A | 2026-03-17 | 2320 |  |
| 2373 | Pause & resume settlement day / run type | 20d | 2026-02-18 A | 2026-03-17 | 2320 |  |
| 2379 | P489 – Multiple MST Upload | 40d | 2026-02-18 A | 2026-04-14 | 2320 |  |
| 2380 | Catalogue Publish Improvement Analysis | 20d | 2026-02-18 A | 2026-03-17 | 2320 |  |
| 2381 | LLF Process Improvement Analysis | 20d | 2026-02-18 A | 2026-03-17 | 2320 |  |
| 2382 | ISD Refresh | 20d | 2026-02-18 A | 2026-03-17 | 2320 |  |
| 2383 | Tech Debt IA2 & IS2 Empty Catalogue Publication | 10d | 2026-02-18 A | 2026-03-03 | 2320 |  |
| 2386 | Tech Debt IA2 & IS2 Empty Catalogue Publication | 10d | 2026-02-18 A | 2026-03-03 |  | finish no earlier than 2026-03-03 |
| 2403 | SAT Prep / Analysis | 22d | 2026-04-01 | 2026-04-30 |  | start no earlier than 2026-04-01 |
| 2404 | SAT Functional Work / Bug Dependency | 21d | 2026-05-01 | 2026-05-29 | 2403 | start no earlier than 2026-05-01 |
| 2405 | SAT Test & Sign-off of Two Cases (Elexon Internal Sign-off) | 22d | 2026-06-01 | 2026-06-30 | 2404 | start no earlier than 2026-06-01 |
| 2406 | SAT Programme Assurance Review of Test Results | 65d | 2026-04-01 | 2026-06-30 |  | start no earlier than 2026-04-01 |

Removed: 3703 Readiness Assessment 7 - Migration Checkpoint; 3704 Launch Readiness Assessment survey; 3705 PPs submit survey responses; 3706 Analyse survey responses; 3707 Conduct deep-dive interviews (sample of PPs); 3708 Produce Readiness Assessment Reports (Overall Report & Individual Participant Reports)

Changed:

| ID | Task | Start | Finish | Duration | Complete | Total float | Predecessors | Other |
| --- | --- | --- | --- | --- | --- | --- | --- | --- |
| 1 | **PROGRAMME PLAN.** |  |  |  | 87% → 89% |  |  |  |
| 3 | **PROGRAMME MANAGEMENT** |  | 2148-12-31 → 2026-12-31 (-44560d) | 32917d → 1089d | 74% → 80% | 0d → 255d |  |  |
| 4 | **Programme Management** |  |  |  | 79% → 80% | 31828d → 255d |  |  |
| 5 | Sprint-based prioritisation planning and execution |  |  |  | 79% → 80% | 31828d → 255d |  |  |
| 6 | Programme governance secretariat |  |  |  | 79% → 80% | 31828d → 255d |  |  |
| 7 | RAID management and reporting |  |  |  | 79% → 80% | 31828d → 255d |  |  |
| 8 | Tracking against Programme outcomes and KPIs |  |  |  | 79% → 80% | 31828d → 255d |  |  |
| 9 | Change control and reporting |  |  |  | 79% → 80% | 31828d → 255d |  |  |
| 10 | Ongoing identification of lessons learned relating to the PMO and implementation of improvements |  |  |  | 79% → 80% | 31828d → 255d |  |  |
| 11 | **Programme Internal Assurance Reviews** |  |  |  | 79% → 80% | 31828d → 255d |  |  |
| 12 | Programme Internal Assurance Reviews |  |  |  | 79% → 80% | 31828d → 255d |  |  |
| 13 | **Engagement with PPs** |  | 2148-12-31 → 2026-12-31 (-44560d) | 32917d → 1089d | 67% → 80% | 0d → 255d |  |  |
| 14 | Ongoing PP liaison activities |  |  |  | 79% → 80% | 31828d → 255d |  |  |
| 15 | Milestone and Control Point objective setting |  |  |  | 79% → 80% | 31828d → 255d |  |  |
| 16 | Reporting |  |  |  | 79% → 80% | 31828d → 255d |  |  |
| 17 | **PP Engagement Events** |  |  |  | 79% → 80% | 31828d → 255d |  |  |
| 18 | Bilateral meetings |  |  |  | 79% → 80% | 31828d → 255d |  |  |
| 19 | Monthly webinars |  |  |  | 79% → 80% | 31828d → 255d |  |  |
| 20 | Open days |  |  |  | 79% → 80% | 31828d → 255d |  |  |
| 21 | **PP Communications** |  | 2148-12-31 → 2026-12-30 (-44561d) | 32917d → 1088d | 46% → 80% | 0d → 256d |  |  |
| 22 | The Clock updates (weekly) |  | 2148-12-31 → 2026-12-30 (-44561d) | 2654d → 1088d | 32% → 80% | 0d → 256d |  | constraint none → finish no earlier than 2026-12-30 |
| 23 | Maintain and update content on public-facing Portal (and ongoing feedback reviews to identify and implement Portal improvements) |  |  |  | 79% → 80% | 31829d → 256d |  |  |
| 24 | **Code Change Support / Other Programme Alignment** |  |  |  | 79% → 80% | 31828d → 255d |  |  |
| 25 | Support DCC/BEIS on SEC change |  |  |  | 79% → 80% | 31828d → 255d |  |  |
| 26 | Support on Smart Meters Act changes |  |  |  | 79% → 80% | 31828d → 255d |  |  |
| 27 | Support DCC/RECCo on CSS change |  |  |  | 79% → 80% | 31828d → 255d |  |  |
| 28 | Support Elexon on BSC change |  |  |  | 79% → 80% | 31828d → 255d |  |  |
| 29 | Support code change inside & outside CCIAG |  |  |  | 79% → 80% | 31828d → 255d |  |  |
| 30 | Support code change inside & outside CCAG |  |  |  | 79% → 80% | 31828d → 255d |  |  |
| 56 | **Establish Design Change Management Processes** |  |  |  | 77% → 78% | 31816d → 243d |  |  |
| 61 | Maintain E2E MHHS Design (post-M5 design change management processes operational) |  |  |  | 76% → 77% | 31816d → 243d |  |  |
| 1724 | **Onboarding and Test Data (Sandbox UIT)** |  |  |  | 67% → 69% | 31917d → 344d |  |  |
| 1726 | Supplier & Agent Onboarding and Test Data Creation and Support |  |  |  | 45% → 49% | 31917d → 344d |  |  |
| 1727 | **Sandbox Execution** |  |  |  | 71% → 73% | 31917d → 344d |  |  |
| 1737 | **Sandbox Testing Execution (UIT) - Supplier & Agent Participants** |  |  |  | 45% → 49% | 31917d → 344d |  |  |
| 1740 | Sandbox Testing Execution (UIT) - Supplier & Agent Participants |  |  |  | 45% → 49% | 31917d → 344d |  |  |
| 2309 | **ELEXON / HELIX M10 - M16** |  |  |  | 84% → 69% | 31844d → 271d |  |  |
| 2310 | **Solution Build Sprints** |  |  |  | 75% → 81% | 32025d → 452d |  |  |
| 2320 | 26.3 |  | 2026-02-17 A |  | 60% → 100% | 32025d → none |  |  |
| 2321 | 26.4 | 2026-02-18 A |  |  | 0% → 40% | 32025d → 452d |  |  |
| 2324 | **Release management deployment schedule** |  |  |  | 87% → 75% | 31844d → 271d |  |  |
| 2332 | 26.3.0 | 2026-02-19 A | 2026-02-19 A |  | 0% → 100% | 32053d → none |  |  |
| 2335 | **Work Package Development** |  |  |  | 87% → 75% | 31844d → 271d |  |  |
| 2336 | **DAH** |  | 2026-03-31 → 2026-04-14 (+14d) | 140d → 150d | 85% → 74% | 32025d → 442d |  |  |
| 2349 | Trading Disputes |  | 2026-02-17 → 2026-03-03 (+14d) | 20d → 30d | 70% → 47% | 32055d → 472d |  | constraint none → finish no earlier than 2026-03-03 |
| 2353 | Enable batching to DIP |  | 2026-02-17 A |  | 40% → 100% | 32055d → none |  |  |
| 2354 | Tech debt DA3 test suite improvements |  |  |  | 10% → 30% | 32025d → 452d |  | was named Trading disputes test suite |
| 2355 | Data lifecycle |  |  |  | 10% → 35% | 32025d → 452d |  |  |
| 2356 | Business Validations | 2026-01-21 A → 2026-02-18 A (+28d) | 2026-02-03 A → 2026-03-31 (+56d) | 10d → 30d | 100% → 13% | none → 452d | 2318 → 2320 | constraint none → start no earlier than 2026-02-18; baseline start 2026-01-21 → 2026-02-18; baseline finish 2026-02-03 → 2026-03-31 |
| 2360 | **WP2 (LSS/MDS/VAS/OP)** |  | 2026-02-17 → 2026-03-17 (+28d) | 110d → 130d | 97% → 86% | 32055d → 462d |  |  |
| 2371 | Operator portal override functionality |  | 2026-02-17 A |  | 40% → 100% | 32055d → none |  |  |
| 2374 | **ISD** |  | 2026-03-03 → 2026-04-14 (+42d) | 110d → 140d | 86% → 69% | 32045d → 442d |  |  |
| 2375 | **ISD Asure** |  | 2026-02-17 → 2026-04-14 (+56d) | 70d → 110d | 86% → 58% | 32055d → 442d |  |  |
| 2376 | Validation error messages (RT and CSAD) |  | 2026-02-17 → 2026-03-03 (+14d) | 70d → 80d | 91% → 80% | 32055d → 472d |  |  |
| 2377 | LLF publication and filter |  | 2026-02-17 A |  | 80% → 100% | 32055d → none |  |  |
| 2378 | DTID Data to EIS |  | 2026-02-17 A |  | 80% → 100% | 32055d → none |  |  |
| 2384 | **ISD Salesforce** |  |  |  | 85% → 92% | 32045d → 472d |  |  |
| 2385 | ISD UI Alignment |  | 2026-03-03 A |  | 85% → 100% | 32045d → none |  |  |
| 2387 | **Settlement Checks** |  |  |  | 58% → 67% | 31844d → 271d |  |  |
| 2394 | **M11** |  |  |  | 57% → 71% | 31844d → 271d |  |  |
| 2399 | R2 | 2026-02-13 A | 2026-02-13 A |  | 0% → 100% | 32057d → none |  |  |
| 2402 | **SAT M16 Test Case Execution** | 2026-07-01 → 2026-04-01 (-91d) | 2026-07-30 → 2026-06-30 (-30d) | 22d → 65d |  | 31938d → 387d |  | constraint start no earlier than 2026-07-01 → none |
| 2408 | **S & A QUALIFICATION** |  |  |  | 88% → 90% | 31808d → 235d |  |  |
| 2520 | **MHHS Qualification - Qualification Waves** |  |  |  | 85% → 88% | 31808d → 235d |  |  |
| 2521 | **Qualification Wave Prep** |  | 2026-02-19 A |  | 99% → 100% | 31820d → none |  |  |
| 2559 | **Qualification Testing Framework (Test Stubs and Supporting UI)** |  | 2026-02-19 A |  | 99% → 100% | 31820d → none |  |  |
| 2625 | **MPANs, DIP Messages, Settlement, Consumption, Reference** |  |  |  | 97% → 100% |  |  |  |
| 2680 | **Wave 4 Test Data** |  | 2026-02-19 A |  | 8% → 100% |  |  |  |
| 2681 | Test Data Request + Templates Completed |  | 2026-01-20 A |  | 50% → 100% | 1d → none |  |  |
| 2682 | Test Data Generated |  | 2026-01-22 A |  | 50% → 100% | 31820d → none |  |  |

| ID | Task | Start | Finish | Complete | Total float | Other |
| --- | --- | --- | --- | --- | --- | --- |
| 2683 | Test Data Loaded into QP Systems | 2026-01-23 A | 2026-02-12 A | 0% → 100% | 31820d → none |  |
| 2684 | Test Data Loaded into QTF + ADO | 2026-02-13 A | 2026-02-19 A | 0% → 100% | 31820d → none |  |
| 2739 | **Qualification Wave 2** |  |  | 78% → 86% | 31983d → 410d |  |
| 2740 | **Qualification Wave 2 QAD Prep** |  |  | 97% → 99% | 32142d → 569d |  |
| 2745 | Code Bodies review of Wave 2 Participants' Initial QAD |  |  | 90% → 95% | 32142d → 569d |  |
| 2766 | QualIfication Wave 2 QT Execution End |  |  |  | 31987d → 414d | was named Qualfication Wave 2 QT Execution End |
| 2767 | **Qualification Wave 2 Exit** |  |  | 33% → 58% | 31983d → 410d |  |
| 2770 | Qualification Wave 2 Participants submit their Final QAD |  |  | 35% → 70% | 31977d → 404d |  |
| 2777 | **Qualification Wave 3** |  |  | 52% → 60% | 31938d → 365d |  |
| 2785 | **Qualification Wave 3 Test Prep** |  |  | 82% → 95% | 32102d → 529d |  |
| 2796 | Review of Participants' PIT Test Completion Report |  |  | 28% → 80% | 32102d → 529d |  |
| 2798 | **Qualification Wave 3 QT Execution** |  |  | 41% → 65% |  |  |
| 2803 | Qualification Wave 3 QT Execution Window |  |  | 38% → 63% | 31932d → 359d |  |
| 2815 | **Qualification Wave 4** |  |  | 29% → 33% | 31808d → 235d |  |
| 2816 | **Qualification Wave 4 QAD Prep** |  |  | 83% → 84% | 31808d → 235d |  |
| 2818 | Qualification Wave 4 Participants Submit Initial QAD |  | 2026-01-16 A | 98% → 100% | 15d → none |  |
| 2819 | Qualification Wave 4 Participants have submitted their Initial QAD | 2026-01-16 A | 2026-01-16 A | 0% → 100% | 15d → none |  |
| 2822 | **Qualification Wave 4 Test Prep** |  |  | 41% → 53% | 31824d → 251d |  |
| 2824 | Qualification Wave 4 Participants DIP Onboarding Window |  | 2025-12-19 A | 81% → 100% | 31858d → none |  |
| 2825 | Confirmation from Qualification Wave 4 Participants that DIP onboarding has completed | 2025-12-19 A | 2025-12-19 A | 0% → 100% | 31858d → none |  |
| 2827 | Review of Participants' PIT Status and QT Test Plan |  |  | 69% → 94% | 31824d → 251d |  |
| 3044 | **MIGRATION** |  |  | 90% → 91% | 31671d → 98d |  |
| 3045 | **Regulatory Governance** |  |  | 96% → 99% | 32047d → 474d |  |
| 3048 | Ofgem Incentives Approval |  |  | 94% → 98% | 32047d → 474d |  |
| 3137 | **Migration Artefact Development and Publication** |  |  | 92% → 93% | 31874d → 301d |  |
| 3212 | **Traditional Meters installed on Current Transformers** |  |  | 63% → 64% | 31874d → 301d |  |
| 3217 | Suppliers to have completed meter exchanges for those MPANs in pot 1 |  |  | 50% → 52% | 31874d → 301d |  |
| 3269 | **Preparation for Cutover to Live** |  |  | 59% → 61% | 31728d → 155d |  |
| 3357 | **Migration Exclusion PPIR** | 2026-02-16 A |  | 0% → 40% | 32037d → 464d |  |
| 3358 | Publication of migration exclusion PPIR | 2026-02-16 A | 2026-02-16 A | 0% → 100% | 32037d → none |  |
| 3359 | Participant response window for PPIR | 2026-02-16 A |  | 0% → 40% | 32037d → 464d |  |
| 3361 | **Migration Sprints** |  |  | 18% → 21% | 31728d → 155d |  |
| 3362 | **Migration Sprint 0** |  | 2026-02-17 A | 95% → 100% | 32055d → none |  |
| 3371 | Sprint 0 Retro |  | 2026-02-17 A | 50% → 100% | 32055d → none |  |
| 3372 | **Migration Sprint 1** |  |  | 18% → 38% | 32015d → 442d |  |
| 3379 | Sprint Execution |  |  | 10% → 38% | 32015d → 442d |  |
| 3634 | **Early Life Support Phase** |  | 2026-02-12 A | 99% → 100% | 32058d → none |  |
| 3637 | Phase 3 End/Early Life Exit |  | 2026-02-12 A | 98% → 100% | 32058d → none |  |
| 3704 | **READINESS ASSESSMENTS** |  |  | 44% → 53% | 31708d → 135d |  |

## Version 23 (data date 2026-03-11, saved 2026-03-16, file MHHS-DEL1139 - MHHS Plan v6.45.mpp)

Last finish stays 2027-12-23. Complete tasks 2639 → 2671.

Added:

| ID | Task | Duration | Start | Finish | Predecessors | Constraint |
| --- | --- | --- | --- | --- | --- | --- |
| 2360 | SDR Discovery | 20d | 2026-03-04 A | 2026-03-31 | 2321 |  |
| 2361 | P0036A and P0036D | 10d | 2026-03-04 A | 2026-03-17 A | 2321 |  |
| 2376 | SCCS Trading Party ID | 20d | 2026-03-04 A | 2026-03-31 | 2321 |  |
| 2390 | Manage ISD Process Improvement Analysis | 20d | 2026-03-04 A | 2026-03-31 | 2321 |  |
| 2391 | ISD Refresh | 2d | 2026-03-23 | 2026-03-24 | 2334FS+1d | finish no earlier than 2026-03-24 |
| 3664 | **M16: Decision Approach** | 95d? | 2026-01-09 A | 2026-05-21 |  |  |
| 3665 | **Agree Approach M16 Decision Proposal** | 75d | 2026-01-09 A | 2026-04-23 |  |  |
| 3666 | M16 Decision Proposal Agreed | 0d | 2026-01-09 | 2026-01-09 |  | start no earlier than 2026-01-09 |
| 3667 | M16 Decision Approach Approved | 0d | 2026-04-23 A | 2026-04-23 A |  | start no earlier than 2026-04-23 |
| 3668 | 2026 Settlement Calendar Produced | 0d | 2026-04-01 | 2026-04-01 |  | start no earlier than 2026-04-01 |
| 3669 | **Consult and Agree with Industry** | 94d? | 2026-01-12 A | 2026-05-21 |  |  |
| 3670 | **M16 Working Group 1** | 39d | 2026-01-12 A | 2026-03-05 A |  |  |
| 3671 | Materials Prepared and Shared | 13d | 2026-01-12 A | 2026-01-28 A | 3666FS+1d | finish no earlier than 2026-01-28 |
| 3672 | M16 Working Group 1 Completed | 0d | 2026-02-06 A | 2026-02-06 A |  | start no earlier than 2026-02-06 |
| 3673 | Outline Work Packages and Activities for Tracking and Decision Choreography for Decision 1 | 20d | 2026-02-06 A | 2026-03-05 A | 3672 | finish no earlier than 2026-03-05 |
| 3674 | Replanning Session Post M16 Workshop 1 | 0d | 2026-02-09 A | 2026-02-09 A | 3672FS+2d | finish no earlier than 2026-02-09 |
| 3675 | **M16 Working Group 2** | 17d | 2026-02-06 A | 2026-03-02 A |  |  |
| 3676 | 2 Materials Prepared and Shared | 15d | 2026-02-06 A | 2026-02-26 A | 3672 | finish no earlier than 2026-02-26 |
| 3677 | M16 Working Group 2 Completed | 0d | 2026-02-26 A | 2026-02-26 A |  | finish no earlier than 2026-02-26 |
| 3678 | Replanning Session Post M16 Workshop 2 | 0d | 2026-03-02 A | 2026-03-02 A | 3677FS+2d | finish no earlier than 2026-03-02 |
| 3679 | **M16 Working Group 3** | 8d | 2026-03-03 A | 2026-03-12 |  |  |
| 3680 | Materials Prepared and Shared | 3d | 2026-03-03 A | 2026-03-05 A | 3678 | finish no earlier than 2026-03-05 |
| 3681 | M16 Working Group 3 Completed | 0d | 2026-03-12 | 2026-03-12 |  | finish no earlier than 2026-03-12 |
| 3682 | **M16 Working Group 4** | 10d | 2026-03-13 | 2026-03-26 |  |  |
| 3683 | Materials Prepared and Shared | 5d | 2026-03-13 | 2026-03-19 | 3681 | finish no earlier than 2026-03-19 |
| 3684 | M16 Working Group 4 Completed | 0d | 2026-03-26 | 2026-03-26 |  | finish no earlier than 2026-03-26 |
| 3685 | **M16 Decision Making and Monitoring Criteria Consultation** | 40d | 2026-03-27 | 2026-05-21 |  |  |
| 3686 | Prepare consultation material | 10d | 2026-03-27 | 2026-04-09 | 3684 | finish no earlier than 2026-04-09 |
| 3687 | Issue Consultation | 0d | 2026-04-10 | 2026-04-10 | 3686FS+1d | finish no earlier than 2026-04-10 |
| 3688 | Consultation Period | 20d | 2026-04-10 | 2026-05-07 | 3687FS-1d | finish no earlier than 2026-05-07 |
| 3689 | Consultation Period Completed | 0d | 2026-05-07 | 2026-05-07 | 3688 | finish no earlier than 2026-05-07 |
| 3690 | Materials Issued for Approval at eMCAG | 0d | 2026-05-14 | 2026-05-14 | 3689FS+5d | finish no earlier than 2026-05-14 |
| 3691 | Approved at eMCAG | 0d | 2026-05-21 | 2026-05-21 | 3690FS+5d | finish no earlier than 2026-05-21 |
| 3692 | **M16: Monitoring Period** | 277d | 2026-05-22 | 2027-06-14 | 3691FS+1d |  |
| 3693 | Prepare April STEG Monitoring Report | 5d | 2026-05-25 | 2026-05-29 |  | start no earlier than 2026-05-25 |
| 3694 | STEG - April | 0d | 2026-05-29 | 2026-05-29 | 3693 | start no earlier than 2026-05-29 |
| 3695 | Prepare May STEG Monitoring Report | 5d | 2026-05-25 | 2026-05-29 | 3696SS-5d | start no earlier than 2026-05-25 |
| 3696 | STEG - May | 0d | 2026-05-22 | 2026-05-22 |  | start no earlier than 2026-05-22 |
| 3697 | Prepare Jun STEG Monitoring Report | 5d | 2026-06-08 | 2026-06-12 | 3698SS-5d | finish no earlier than 2026-06-12 |
| 3698 | STEG - Jun | 0d | 2026-06-15 | 2026-06-15 |  | start no earlier than 2026-06-15 |
| 3699 | Prepare Jul STEG Monitoring Report | 5d | 2026-07-06 | 2026-07-10 | 3700SS-5d | finish no earlier than 2026-07-10 |
| 3700 | STEG - Jul | 0d | 2026-07-13 | 2026-07-13 |  | start no earlier than 2026-07-13 |
| 3701 | Prepare Aug STEG Monitoring Report | 5d | 2026-08-10 | 2026-08-14 | 3702SS-5d | finish no earlier than 2026-08-14 |
| 3702 | STEG Aug | 0d | 2026-08-17 | 2026-08-17 |  | start no earlier than 2026-08-17 |
| 3703 | Prepare SEP STEG Monitoring Report | 5d | 2026-09-07 | 2026-09-11 | 3704SS-5d | finish no earlier than 2026-09-11 |
| 3704 | STEG Sep | 0d | 2026-09-14 | 2026-09-14 |  | start no earlier than 2026-09-14 |
| 3705 | Prepare SEP STEG Monitoring Report | 5d | 2026-10-05 | 2026-10-09 | 3706SS-5d | finish no earlier than 2026-10-09 |
| 3706 | STEG Oct | 0d | 2026-10-12 | 2026-10-12 |  | start no earlier than 2026-10-12 |
| 3707 | Prepare SEP STEG Monitoring Report | 5d | 2026-11-09 | 2026-11-13 | 3708SS-5d | finish no earlier than 2026-11-13 |
| 3708 | STEG Noc | 0d | 2026-11-16 | 2026-11-16 |  | start no earlier than 2026-11-16 |
| 3709 | Prepare SEP STEG Monitoring Report | 5d | 2026-12-07 | 2026-12-11 | 3710SS-5d | finish no earlier than 2026-12-11 |
| 3710 | STEG Dec | 0d | 2026-12-14 | 2026-12-14 |  | start no earlier than 2026-12-14 |
| 3711 | Prepare SEP STEG Monitoring Report | 5d | 2027-01-04 | 2027-01-08 | 3712SS-5d | finish no earlier than 2027-01-08 |
| 3712 | STEG Jan | 0d | 2027-01-11 | 2027-01-11 |  | start no earlier than 2027-01-11 |
| 3713 | Prepare SEP STEG Monitoring Report | 5d | 2027-02-08 | 2027-02-12 | 3714SS-5d | finish no earlier than 2027-02-12 |
| 3714 | STEG Feb | 0d | 2027-02-15 | 2027-02-15 |  | start no earlier than 2027-02-15 |
| 3715 | Prepare SEP STEG Monitoring Report | 5d | 2027-03-08 | 2027-03-12 | 3716SS-5d | finish no earlier than 2027-03-12 |
| 3716 | STEG Mar | 0d | 2027-03-15 | 2027-03-15 |  | start no earlier than 2027-03-15 |
| 3717 | Prepare SEP STEG Monitoring Report | 5d | 2027-04-12 | 2027-04-16 | 3718SS-5d | finish no earlier than 2027-04-16 |
| 3718 | STEG Apr | 0d | 2027-04-19 | 2027-04-19 |  | start no earlier than 2027-04-19 |
| 3719 | Prepare SEP STEG Monitoring Report | 5d | 2027-05-10 | 2027-05-14 | 3720SS-5d | finish no earlier than 2027-05-14 |
| 3720 | STEG May - M16 Checkpoint 1 | 0d | 2027-05-17 | 2027-05-17 |  | start no earlier than 2027-05-17 |
| 3721 | Prepare SEP STEG Monitoring Report | 5d | 2027-06-07 | 2027-06-11 | 3722SS-5d | finish no earlier than 2027-06-11 |
| 3722 | STEG Jun | 0d | 2027-06-14 | 2027-06-14 |  | start no earlier than 2027-06-14 |
| 3723 | **M16: Decision Points** | 245d | 2026-07-13 | 2027-06-18 |  |  |
| 3724 | **STEG to Assess Monitoring Report and recommend interim position to MCAG on Decision 1** | 5d | 2026-07-13 | 2026-07-17 |  |  |
| 3725 | STEG Issue position to MCAG notifying Decision Checkpoint 1 On-track | 0d | 2026-07-13 | 2026-07-13 | 3700 | start no earlier than 2026-07-13 |
| 3726 | MCAG Endorses Assessment | 0d | 2026-07-17 | 2026-07-17 | 3725FS+5d | finish no earlier than 2026-07-17 |
| 3727 | Confidence Assessment 1 | 0d | 2026-07-17 | 2026-07-17 | 3726 | finish no earlier than 2026-07-17 |
| 3728 | **Prepare Readiness Assessment - Material Describing Transition Design and Queries to PPs guaging understanding an organisational readiness** | 31d | 2026-07-17 | 2026-08-28 | 3726FS-15d |  |
| 3729 | Issue Readiness Assessment Following Interim Recommendation | 0d | 2026-07-17 | 2026-07-17 | 3726 | finish no earlier than 2026-07-17 |
| 3730 | Readiness Assessment Consultation Period Complete | 0d | 2026-08-14 | 2026-08-14 | 3729FS+20d | finish no earlier than 2026-08-14 |
| 3731 | Readiness Assessment Complete | 0d | 2026-08-14 | 2026-08-14 | 3730 | finish no earlier than 2026-08-14 |
| 3732 | Assess Readines Assessment and Plan further enagement activity if required | 10d | 2026-08-17 | 2026-08-28 | 3730 | finish no earlier than 2026-08-28 |
| 3733 | **Decision 1 RF Change 7 to months from Settlement Day 01/10** | 5d | 2026-09-14 | 2026-09-18 |  |  |
| 3734 | STEG to compare Monitoring report against agreed assessment criteria | 0d | 2026-09-14 | 2026-09-14 | 3704 | start no earlier than 2026-09-14 |
| 3735 | STEG Issue recommendation to MCAG | 0d | 2026-09-14 | 2026-09-14 | 3734 | start no earlier than 2026-09-14 |
| 3736 | MCAG Approve Recommendation to change to RF 7 months calendar | 0d | 2026-09-18 | 2026-09-18 | 3734FS+5d | finish no earlier than 2026-09-18 |
| 3737 | Decision 1 - RF 7 Months | 0d | 2026-09-18 | 2026-09-18 | 3736 | finish no earlier than 2026-09-18 |
| 3738 | **Decision 2 RF Change to 4 months from Settlement Date 01/04** | 5d | 2027-03-15 | 2027-03-19 |  |  |
| 3739 | STEG to compare Monitoring report against agreed assessment criteria | 0d | 2027-03-15 | 2027-03-15 | 3716 | start no earlier than 2027-03-15 |
| 3740 | STEG Issue recommendation to MCAG | 0d | 2027-03-19 | 2027-03-19 | 3739FS+5d | finish no earlier than 2027-03-19 |
| 3741 | MCAG Approve recommendation | 0d | 2027-03-19 | 2027-03-19 | 3740 | finish no earlier than 2027-03-19 |
| 3742 | Decision 2 - RF 4 Months | 0d | 2027-03-19 | 2027-03-19 | 3741 | finish no earlier than 2027-03-19 |
| 3743 | **Decision 3 SF Change from 15WD to 7WD from Settlement Date 02/07** | 5d | 2027-06-14 | 2027-06-18 |  |  |
| 3744 | STEG to compare Monitoring report against agreed assessment criteria | 0d | 2027-06-14 | 2027-06-14 | 3716, 3718, 3720, 3722 | start no earlier than 2027-06-14 |
| 3745 | STEG Issue recommendation to MCAG | 0d | 2027-06-18 | 2027-06-18 | 3744FS+5d | finish no earlier than 2027-06-18 |
| 3746 | MCAG Approve Recommendation - Confrim M16 Date | 0d | 2027-06-18 | 2027-06-18 | 3745 | finish no earlier than 2027-06-18 |
| 3747 | Decision 3 - SF 7WD | 0d | 2027-06-18 | 2027-06-18 | 3746 | finish no earlier than 2027-06-18 |
| 3748 | **M16: Creation & Implementation of Updated Settelemnt Calendars** | 334d | 2026-03-09 | 2027-06-17 |  |  |
| 3749 | **Post Decision 1 & 2** | 55d | 2027-01-04 | 2027-03-19 |  |  |
| 3750 | **Prepare Calendars** | 20d | 2027-01-04 | 2027-01-29 |  |  |
| 3751 | Prepare Variant a) April-Jun 2027 Including change RF to 7& 4 Months | 20d | 2027-01-04 | 2027-01-29 |  | start no earlier than 2027-01-04 |
| 3752 | Prepare Variant b) April-Jun 2027 7 Month only where decision 2 Fails | 20d | 2027-01-04 | 2027-01-29 |  | start no earlier than 2027-01-04 |
| 3753 | Prepare Variant c) April-Jun 2027"No Change" Where both decisions fail | 20d | 2027-01-04 | 2027-01-29 |  | start no earlier than 2027-01-04 |
| 3754 | SVG Approval of Appropriate Calendar | 0d | 2027-02-26 | 2027-02-26 | 3750FS+20d | start no earlier than 2027-02-26 |
| 3755 | Implementation of April - Jun 2027 Calendar | 0d | 2027-03-19 | 2027-03-19 | 3736, 3741, 3754FS+10d | finish no earlier than 2027-03-19 |
| 3756 | **Post Decision 3** | 334d | 2026-03-09 | 2027-06-17 |  |  |
| 3757 | Prepare Variant Jul-27 - Mar-28 Including 4/7 Month and 7 Day SF | 20d | 2026-03-09 | 2026-04-03 |  | start no earlier than 2026-03-09 |
| 3758 | Prepare Variant Jul-27 - Sep-28 Excluding SF Change Contingency | 20d | 2026-03-09 | 2026-04-03 |  | start no earlier than 2026-03-09 |
| 3759 | SVG Approval of Appropriate Calendar | 0d | 2027-06-03 | 2027-06-03 | 3472FS+19d | finish no earlier than 2027-06-03 |
| 3760 | Implementation of Jul - Mar 2027 Calendar | 0d | 2027-06-17 | 2027-06-17 | 3759FS+10d | finish no earlier than 2027-06-17 |

Changed:

| ID | Task | Start | Finish | Duration | Complete | Total float | Predecessors | Other |
| --- | --- | --- | --- | --- | --- | --- | --- | --- |
| 1673 | **UIT Environment Preparation** |  |  |  | 95% → 96% |  |  |  |
| 1724 | **Onboarding and Test Data (Sandbox UIT)** |  |  |  | 69% → 72% |  |  |  |
| 1726 | Supplier & Agent Onboarding and Test Data Creation and Support |  |  |  | 49% → 53% |  |  |  |
| 1727 | **Sandbox Execution** |  |  |  | 73% → 75% |  |  |  |
| 1737 | **Sandbox Testing Execution (UIT) - Supplier & Agent Participants** |  |  |  | 49% → 53% |  |  |  |
| 1740 | Sandbox Testing Execution (UIT) - Supplier & Agent Participants |  |  |  | 49% → 53% |  |  |  |
| 2309 | **ELEXON / HELIX M10 - M16** |  |  |  | 69% → 81% |  |  |  |
| 2310 | **Solution Build Sprints** |  |  |  | 81% → 90% |  |  |  |
| 2321 | 26.4 |  | 2026-03-03 A |  | 40% → 100% | 452d → none |  |  |
| 2322 | 26.5 | 2026-03-04 A |  |  | 0% → 60% |  |  |  |
| 2324 | **Release management deployment schedule** |  |  |  | 75% → 88% |  |  |  |
| 2333 | 26.4.0 | 2026-03-05 A | 2026-03-05 A |  | 0% → 100% | 470d → none |  |  |
| 2335 | **Work Package Development** |  |  |  | 75% → 88% |  |  |  |
| 2336 | **DAH** |  |  |  | 74% → 89% |  |  |  |
| 2349 | Trading Disputes |  | 2026-03-03 A |  | 47% → 100% | 472d → none |  |  |
| 2354 | Tech debt DA3 test suite improvements |  |  |  | 30% → 65% |  |  |  |
| 2355 | Data lifecycle |  |  |  | 35% → 65% |  |  |  |
| 2356 | Business Validations |  |  |  | 13% → 53% |  |  |  |
| 2357 | CR45 Code Merge |  | 2026-03-03 A |  | 40% → 100% | 472d → none |  |  |
| 2358 | Tech Debt DA2: Azure cost reduction, optimising data storage and processing |  |  |  | 10% → 40% |  |  |  |
| 2359 | Tech Debt DA4: Code maintainability enhancements |  | 2026-04-14 A |  | 10% → 100% | 442d → none |  |  |
| 2362 | **WP2 (LSS/MDS/VAS/OP)** |  | 2026-03-17 → 2026-03-31 (+14d) | 130d → 140d | 86% → 93% | 462d → 452d |  |  |
| 2374 | VAS override functionality |  | 2026-03-17 A |  | 20% → 100% | 462d → none |  |  |
| 2375 | Pause & resume settlement day / run type |  |  |  | 10% → 80% |  |  |  |
| 2377 | **ISD** |  |  |  | 69% → 84% |  |  |  |
| 2378 | **ISD Asure** |  |  |  | 58% → 81% |  |  |  |
| 2379 | Validation error messages (RT and CSAD) |  | 2026-03-03 → 2026-03-17 (+14d) | 80d → 90d | 80% → 96% | 472d → 462d |  | baseline finish 2026-02-17 → 2026-03-17 |
| 2382 | P489 – Multiple MST Upload (Analysis) |  |  |  | 10% → 40% |  |  | was named P489 – Multiple MST Upload |
| 2383 | LLF Process Improvement Analysis |  | 2026-03-17 → 2026-03-31 (+14d) | 20d → 30d | 20% → 53% | 462d → 452d |  | baseline finish 2026-03-17 → 2026-03-31 |
| 2384 | ISD Refresh | 2026-02-18 A → 2026-03-23 (+33d) | 2026-03-17 → 2026-03-24 (+7d) | 20d → 2d | 20% → 0% | 462d → 457d | 2320 → 2334FS+1d | baseline start 2026-02-18 → 2026-03-23; baseline finish 2026-03-17 → 2026-03-24 |
| 2385 | Tech Debt IA2 & IS2 Empty Catalogue Publication |  | 2026-03-03 A |  | 40% → 100% | 472d → none |  |  |
| 2386 | **ISD Salesforce** |  | 2026-03-03 → 2026-03-31 (+28d) | 110d → 130d | 92% → 88% | 472d → 452d |  |  |
| 2388 | Tech Debt IA2 & IS2 Empty Catalogue Publication |  | 2026-03-03 A |  | 0% → 100% | 472d → none |  |  |
| 2389 | Catalogue Publish Improvement Analysis |  |  |  | 20% → 80% |  |  |  |
| 2413 | **S & A QUALIFICATION** |  |  |  | 90% → 92% |  |  |  |
| 2525 | **MHHS Qualification - Qualification Waves** |  |  |  | 88% → 90% |  |  |  |
| 2706 | **Qualification Wave 1** |  |  |  | 96% → 99% |  |  |  |
| 2734 | **Qualification Wave 1 Exit** |  |  |  | 89% → 99% |  |  |  |
| 2740 | Completion of Code Bodies review of Final QAD |  |  |  | 55% → 95% | 0.3d → 0.6d |  |  |
| 2741 | QAD Sign Off deadline |  |  |  | 30% → 60% |  |  |  |
| 2742 | 80% of M14 Critical Wave 1 Participants Qualification approved by BSC PAB and REC Manager | 2026-04-15 A |  |  | 0% → 20% |  |  |  |
| 2743 | All M14 Critical Wave 1 Participants Qualification approved by BSC PAB and REC Manager | 2026-04-15 A |  |  | 0% → 20% |  |  |  |
| 2744 | **Qualification Wave 2** |  |  |  | 86% → 92% |  |  |  |
| 2745 | **Qualification Wave 2 QAD Prep** |  | 2025-10-17 A |  | 99% → 100% | 569d → none |  |  |
| 2750 | Code Bodies review of Wave 2 Participants' Initial QAD |  | 2025-10-17 A |  | 95% → 100% | 569d → none |  |  |
| 2751 | Completion of Code Bodies review of Initial QAD | 2025-10-17 A | 2025-10-17 A |  | 0% → 100% | 569d → none |  |  |
| 2765 | **Qualification Wave 2 QT Execution** |  | 2026-02-20 A |  | 99% → 100% | 414d → none |  |  |
| 2770 | Qualification Wave 2 QT Execution Window |  | 2026-02-20 A |  | 99% → 100% | 414d → none |  |  |
| 2771 | QualIfication Wave 2 QT Execution End | 2026-02-20 A | 2026-02-20 A |  | 0% → 100% | 414d → none |  |  |
| 2772 | **Qualification Wave 2 Exit** |  |  |  | 58% → 75% |  |  |  |
| 2775 | Qualification Wave 2 Participants submit their Final QAD |  |  |  | 70% → 90% | 404d → 469d |  |  |
| 2776 | 80% of M14 Critical Qualification Wave 2 Participants have submitted their final QAD | 2026-03-06 A | 2026-03-06 A |  | 0% → 100% | 404d → none |  |  |
| 2777 | All Qualification Wave 2 Participants have submitted their final QAD | 2026-03-06 A |  |  | 0% → 90% |  |  |  |
| 2778 | Completion of Code Bodies review of Final QAD | 2026-03-09 A |  |  | 0% → 12% |  |  |  |
| 2782 | **Qualification Wave 3** |  |  |  | 60% → 64% |  |  |  |
| 2803 | **Qualification Wave 3 QT Execution** |  |  |  | 65% → 80% |  |  |  |
| 2808 | Qualification Wave 3 QT Execution Window |  |  |  | 63% → 79% |  |  |  |
| 2820 | **Qualification Wave 4** |  |  |  | 33% → 39% |  |  |  |
| 2827 | **Qualification Wave 4 Test Prep** |  |  |  | 53% → 76% | 251d → 484d |  |  |
| 2836 | Onboarding to QTF & ADO | 2026-01-12 A | 2026-02-13 A |  | 0% → 100% | 251d → none |  |  |
| 2837 | **Qualification Wave 4 QT Execution** | 2026-03-02 A |  |  | 0% → 1% | 235d → 379d |  |  |
| 2840 | Qualification Wave 4 QT Execution Start | 2026-03-09 A | 2026-03-09 A |  | 0% → 100% | 235d → none |  |  |
| 2841 | Qualification Wave 4 QT Execution Window | 2026-03-09 A |  |  | 0% → 1% |  |  |  |
| 2843 | **Qualification Wave 4 Exit** | 2026-03-09 A |  |  |  |  |  |  |
| 2845 | Final QAD Submission window opens | 2026-03-09 A | 2026-03-09 A |  | 0% → 100% | 235d → none |  |  |
| 2878 | PAB2026/03 | 2026-02-26 A | 2026-02-26 A |  | 0% → 100% | 475d → none |  |  |
| 2879 | PAB2026/04 | 2026-03-11 A | 2026-03-11 A |  | 0% → 100% | 466d → none |  |  |
| 3050 | **Regulatory Governance** |  | 2026-02-27 → 2026-03-31 (+32d) | 500d → 522d | 99% → 94% | 474d → 452d |  |  |
| 3053 | Ofgem Incentives Approval |  | 2026-02-27 → 2026-03-31 (+32d) | 186d → 208d | 98% → 91% | 474d → 452d |  | constraint finish no earlier than 2026-02-27 → finish no earlier than 2026-03-31; baseline finish 2026-02-27 → 2026-03-31 |
| 3054 | Incentives Implementation | 2026-02-27 → 2026-03-31 (+32d) | 2026-02-27 → 2026-03-31 (+32d) |  |  | 474d → 452d |  | constraint finish no earlier than 2026-02-27 → start no earlier than 2026-03-31; baseline start 2026-01-23 → 2026-03-31; baseline finish 2026-02-27 → 2026-03-31 |

| ID | Task | Start | Finish | Duration | Complete | Total float | Predecessors |
| --- | --- | --- | --- | --- | --- | --- | --- |
| 3216 | **Connection Type and Meter Type Misalignments** |  |  |  | 84% → 85% |  |  |
| 3217 | **Traditional Meters installed on Current Transformers** |  |  |  | 64% → 66% |  |  |
| 3222 | Suppliers to have completed meter exchanges for those MPANs in pot 1 |  |  |  | 52% → 55% |  |  |
| 3252 | **Migration Period Planning** |  | 2026-07-31 → 2024-06-04 A (-787d) | 805d → 242d | 98% → 100% | 240d → none |  |
| 3253 | **Migration Implementation Plan (incl. Migration Exit Criteria)** |  | 2026-07-31 → 2024-06-04 A (-787d) | 805d → 242d | 98% → 100% | 240d → none |  |
| 3268 | **Preparation for Cutover to Live** |  |  |  | 61% → 63% |  |  |
| 3356 | **Migration Exclusion PPIR** |  |  |  | 40% → 90% |  |  |
| 3358 | Participant response window for PPIR |  |  |  | 40% → 90% |  |  |
| 3360 | **Migration Sprints** |  |  |  | 21% → 23% |  |  |
| 3371 | **Migration Sprint 1** |  |  |  | 38% → 55% |  |  |
| 3378 | Sprint Execution |  |  |  | 38% → 62% |  |  |
| 3381 | **Migration Sprint 2** | 2026-03-04 A |  |  | 0% → 10% |  |  |
| 3382 | Sprint 2 Planning start date | 2026-03-04 A | 2026-03-11 A |  | 0% → 100% | 397d → none |  |
| 3383 | Issue Envelope | 2026-03-11 A | 2026-03-11 A |  | 0% → 100% | 397d → none |  |
| 3474 | **BUSINESS & OPERATIONAL READINESS** |  |  |  | 70% → 68% |  |  |
| 3647 | **Transition to New Settlement Timetable (M16)** | 2025-10-22 A → 2024-07-31 A (-448d) |  | 566d → 887d? | 7% → 32% |  |  |
| 3763 | Cut over to new settlement timetable (M16) |  |  |  |  |  | 3762, 3472FS+40d, 3649, 3657, 3663 → 3762, 3472FS+40d, 3649, 3760, 3657, 3663 |
| 3806 | **READINESS ASSESSMENTS** |  |  |  | 53% → 55% |  |  |
| 3821 | **Readiness Assessment 7 - Migration Checkpoint** | 2026-03-02 A |  |  | 0% → 32% |  |  |
| 3822 | Readiness Assessment 7 survey issued | 2026-03-02 A | 2026-03-02 A |  | 0% → 100% | 451d → none |  |
| 3823 | Draft response review point | 2026-03-06 A | 2026-03-10 A |  | 0% → 100% | 467d → none |  |
| 3824 | Evidence asessment | 2026-03-06 A |  |  | 0% → 21% |  |  |

## Version 24 (data date 2026-03-25, saved 2026-03-25, file MHHS-DEL1139 - MHHS Plan v6.46.mpp)

Last finish stays 2027-12-23. Complete tasks 2671 → 2695.

Added:

| ID | Task | Duration | Start | Finish | Predecessors |
| --- | --- | --- | --- | --- | --- |
| 2324 | 26.7 | 10d | 2026-04-01 | 2026-04-14 | 2323 |
| 2325 | 26.8 | 10d | 2026-04-15 | 2026-04-28 | 2324 |
| 2326 | 26.9 | 10d | 2026-04-29 | 2026-05-12 | 2325 |
| 2327 | 26.10 | 10d | 2026-05-13 | 2026-05-26 | 2326 |
| 2328 | 26.11 | 10d | 2026-05-27 | 2026-06-09 | 2327 |
| 2329 | 26.12 | 10d | 2026-06-10 | 2026-06-23 | 2328 |
| 2341 | 26.6.0 | 11d | 2026-03-18 A | 2026-04-01 | 2322 |
| 2342 | 26.7.0 | 16d | 2026-04-01 | 2026-04-22 | 2323 |
| 2370 | Electralink improvement | 20d | 2026-03-18 A | 2026-04-14 | 2322 |
| 2371 | REP009 CoS Updates | 10d | 2026-04-15 | 2026-04-28 | 2324 |
| 2372 | I022 incremental sequence | 10d | 2026-04-15 | 2026-04-28 | 2324 |
| 2373 | Smart Data Repository | 40d | 2026-04-01 | 2026-05-26 | 2323 |
| 2389 | OP: Edit configuration parameters from UI | 30d | 2026-03-18 A | 2026-04-28 | 2322 |
| 2390 | MDS (remove IF-96) | 10d | 2026-04-01 | 2026-04-14 | 2323 |
| 2391 | Make VAS run during transition mode without legacy data | 20d | 2026-04-15 | 2026-05-12 | 2324 |
| 2401 | ISD Navigation Analysis | 10d | 2026-03-18 A | 2026-03-31 | 2322 |

Removed: 3647 Transition to New Settlement Timetable (M16); 3648 Elexon to produce Settlement Calendar for Settlement Year 2025/2026; 3649 Elexon monitor settlement data of migrated MPANs; 3650 M16 Checkpoint 1; 3651 Confirm if M16 date retained as 07/12/2026; 3652 Readiness assessment of participants' readiness to transition to new Settlement Timetable; 3653 Elexon to produce Settlement Calendar for Settlement Year 2026 up until day before M16 cutover; 3654 M16 Checkpoint 2; 3655 Readiness assessment of participants' readiness to transition to new Settlement Timetable; 3656 Confirm M16 Date; 3657 Raise fast track change to ISD (November publish)

Changed:

| ID | Task | Start | Finish | Duration | Complete | Total float | Other |
| --- | --- | --- | --- | --- | --- | --- | --- |
| 1 | **PROGRAMME PLAN.** |  |  |  | 89% → 90% |  |  |
| 3 | **PROGRAMME MANAGEMENT** |  |  |  | 80% → 82% |  |  |
| 4 | **Programme Management** |  |  |  | 80% → 82% |  |  |
| 5 | Sprint-based prioritisation planning and execution |  |  |  | 80% → 82% |  |  |
| 6 | Programme governance secretariat |  |  |  | 80% → 82% |  |  |
| 7 | RAID management and reporting |  |  |  | 80% → 82% |  |  |
| 8 | Tracking against Programme outcomes and KPIs |  |  |  | 80% → 82% |  |  |
| 9 | Change control and reporting |  |  |  | 80% → 82% |  |  |
| 10 | Ongoing identification of lessons learned relating to the PMO and implementation of improvements |  |  |  | 80% → 82% |  |  |
| 11 | **Programme Internal Assurance Reviews** |  |  |  | 80% → 82% |  |  |
| 12 | Programme Internal Assurance Reviews |  |  |  | 80% → 82% |  |  |
| 13 | **Engagement with PPs** |  |  |  | 80% → 82% |  |  |
| 14 | Ongoing PP liaison activities |  |  |  | 80% → 82% |  |  |
| 15 | Milestone and Control Point objective setting |  |  |  | 80% → 82% |  |  |
| 16 | Reporting |  |  |  | 80% → 82% |  |  |
| 17 | **PP Engagement Events** |  |  |  | 80% → 82% |  |  |
| 18 | Bilateral meetings |  |  |  | 80% → 82% |  |  |
| 19 | Monthly webinars |  |  |  | 80% → 82% |  |  |
| 20 | Open days |  |  |  | 80% → 82% |  |  |
| 21 | **PP Communications** |  |  |  | 80% → 82% |  |  |
| 22 | The Clock updates (weekly) |  |  |  | 80% → 82% |  |  |
| 23 | Maintain and update content on public-facing Portal (and ongoing feedback reviews to identify and implement Portal improvements) |  |  |  | 80% → 82% |  |  |
| 24 | **Code Change Support / Other Programme Alignment** |  |  |  | 80% → 82% |  |  |
| 25 | Support DCC/BEIS on SEC change |  |  |  | 80% → 82% |  |  |
| 26 | Support on Smart Meters Act changes |  |  |  | 80% → 82% |  |  |
| 27 | Support DCC/RECCo on CSS change |  |  |  | 80% → 82% |  |  |
| 28 | Support Elexon on BSC change |  |  |  | 80% → 82% |  |  |
| 29 | Support code change inside & outside CCIAG |  |  |  | 80% → 82% |  |  |
| 30 | Support code change inside & outside CCAG |  |  |  | 80% → 82% |  |  |
| 45 | **DESIGN, BUILD & TEST (PIT)** |  |  |  | 97% → 98% |  |  |
| 46 | **Design Baseline & Enduring PP Support** |  |  |  | 90% → 91% |  |  |
| 56 | **Establish Design Change Management Processes** |  |  |  | 78% → 80% |  |  |
| 61 | Maintain E2E MHHS Design (post-M5 design change management processes operational) |  |  |  | 77% → 79% |  |  |
| 2309 | **ELEXON / HELIX M10 - M16** |  |  |  | 81% → 74% |  |  |
| 2310 | **Solution Build Sprints** |  | 2026-03-31 → 2026-06-23 (+84d) | 150d → 210d | 90% → 67% | 452d → 392d |  |
| 2322 | 26.5 |  | 2026-03-17 A |  | 60% → 100% | 452d → none |  |
| 2323 | 26.6 | 2026-03-18 A |  |  | 0% → 50% | 452d → 392d |  |
| 2330 | **Release management deployment schedule** |  |  |  | 88% → 81% |  |  |
| 2340 | 26.5.0 | 2026-03-19 A | 2026-03-19 A |  | 0% → 100% | 457d → none |  |
| 2343 | **Work Package Development** |  |  |  | 88% → 82% |  |  |
| 2344 | **DAH** |  | 2026-04-14 → 2026-06-30 (+77d) | 150d → 205d | 89% → 78% | 442d → 387d |  |
| 2362 | Tech debt DA3 test suite improvements |  |  |  | 65% → 88% |  |  |
| 2363 | Data lifecycle |  |  |  | 65% → 88% |  |  |
| 2364 | Business Validations |  | 2026-03-31 → 2026-06-30 (+91d) | 30d → 95d | 53% → 17% | 452d → 387d | constraint start no earlier than 2026-02-18 → finish no earlier than 2026-06-30 |
| 2366 | Tech Debt DA2: Azure cost reduction, optimising data storage and processing |  |  |  | 40% → 63% |  |  |
| 2368 | SDR Discovery |  |  |  | 30% → 75% |  |  |
| 2374 | **WP2 (LSS/MDS/VAS/OP)** |  | 2026-03-31 → 2026-05-12 (+42d) | 140d → 170d | 93% → 76% | 452d → 422d |  |
| 2387 | Pause & resume settlement day / run type |  | 2026-03-17 A |  | 80% → 100% | 462d → none |  |
| 2388 | SCCS Trading Party ID |  | 2026-03-31 → 2026-04-14 (+14d) | 20d → 30d | 30% → 20% | 452d → 442d |  |
| 2392 | **ISD** |  |  |  | 84% → 95% |  |  |
| 2393 | **ISD Asure** |  |  |  | 81% → 95% |  |  |
| 2394 | Validation error messages (RT and CSAD) |  | 2026-03-17 A |  | 96% → 100% | 462d → none |  |
| 2397 | P489 – Multiple MST Upload (Analysis) |  | 2026-04-14 A |  | 40% → 100% | 442d → none |  |
| 2398 | LLF Process Improvement Analysis |  |  |  | 53% → 83% |  |  |
| 2402 | **ISD Salesforce** |  |  |  | 88% → 96% |  |  |
| 2405 | Catalogue Publish Improvement Analysis |  | 2026-03-17 A |  | 80% → 100% | 462d → none |  |
| 2406 | Manage ISD Process Improvement Analysis |  |  |  | 30% → 75% |  |  |
| 2429 | **S & A QUALIFICATION** |  |  |  | 92% → 93% |  |  |
| 2541 | **MHHS Qualification - Qualification Waves** |  |  |  | 90% → 91% |  |  |
| 2756 | Completion of Code Bodies review of Final QAD |  | 2026-03-06 A |  | 95% → 100% | 0.6d → none |  |
| 2757 | QAD Sign Off deadline |  |  |  | 60% → 92% |  |  |
| 2760 | **Qualification Wave 2** |  |  |  | 92% → 96% |  |  |
| 2788 | **Qualification Wave 2 Exit** |  |  |  | 75% → 89% |  |  |
| 2791 | Qualification Wave 2 Participants submit their Final QAD |  | 2026-03-06 A |  | 90% → 100% | 469d → none |  |
| 2793 | All Qualification Wave 2 Participants have submitted their final QAD |  | 2026-03-06 A |  | 90% → 100% | 463d → none |  |
| 2794 | Completion of Code Bodies review of Final QAD |  |  |  | 12% → 46% |  |  |
| 2798 | **Qualification Wave 3** |  |  |  | 64% → 65% |  |  |
| 2819 | **Qualification Wave 3 QT Execution** |  |  |  | 80% → 88% |  |  |
| 2824 | Qualification Wave 3 QT Execution Window |  |  |  | 79% → 87% |  |  |
| 2836 | **Qualification Wave 4** |  |  |  | 39% → 49% |  |  |

| ID | Task | Start | Finish | Duration | Complete | Total float | Predecessors | Other |
| --- | --- | --- | --- | --- | --- | --- | --- | --- |
| 2837 | **Qualification Wave 4 QAD Prep** |  |  |  | 84% → 76% | 0.9d → 474d |  |  |
| 2841 | Code Bodies review of Wave 4 Participants' Initial QAD |  |  |  | 50% → 23% | 0.9d → 474d |  |  |
| 2843 | **Qualification Wave 4 Test Prep** |  | 2026-02-13 A |  | 76% → 100% | 484d → none |  |  |
| 2847 | Qualification Wave 4 Participants' to provide status of PIT completion and submit QT Test Plan | 2025-12-08 A | 2025-12-08 A |  | 0% → 100% | 23.5d → none |  |  |
| 2848 | Review of Participants' PIT Status and QT Test Plan |  | 2026-01-09 A |  | 94% → 100% | 484d → none |  |  |
| 2849 | Qualification Test Plans for Qualification Wave 4 Participants approved | 2026-01-09 A | 2026-01-09 A |  | 0% → 100% | 484d → none |  |  |
| 2850 | Qualification Wave 4 Participants have submitted PIT Test Completion Report and evidence for QT entry | 2026-01-09 A | 2026-01-09 A |  | 0% → 100% | 484d → none |  |  |
| 2851 | Review of Participants' PIT Test Completion Report | 2026-01-12 A | 2026-02-13 A |  | 0% → 100% | 484d → none |  |  |
| 2853 | **Qualification Wave 4 QT Execution** |  |  |  | 1% → 26% | 379d → 235d |  |  |
| 2854 | Review Entry Criteria Evidence for each Wave 4 Participant | 2026-03-02 A | 2026-03-06 A |  | 0% → 100% | 0.9d → none |  |  |
| 2855 | Qualification Wave 4 Participant Test Readiness Confirmed | 2026-03-06 A | 2026-03-06 A |  | 0% → 100% | 469d → none |  |  |
| 2857 | Qualification Wave 4 QT Execution Window |  |  |  | 1% → 22% |  |  |  |
| 2859 | **Qualification Wave 4 Exit** |  |  |  | 0% → 2% |  |  |  |
| 2862 | Qualification Wave 4 Participants submit their Final QAD | 2026-03-09 A |  |  | 0% → 2% |  |  |  |
| 3066 | **Regulatory Governance** |  | 2026-03-31 → 2026-04-30 (+30d) | 522d → 544d | 94% → 88% | 452d → 430d |  |  |
| 3069 | Ofgem Incentives Approval |  | 2026-03-31 → 2026-04-30 (+30d) | 208d → 230d | 91% → 82% | 452d → 430d |  | constraint finish no earlier than 2026-03-31 → finish no earlier than 2026-04-30; baseline finish 2026-03-31 → 2026-04-30 |
| 3070 | Incentives Implementation | 2026-03-31 → 2026-04-30 (+30d) | 2026-03-31 → 2026-04-30 (+30d) |  |  | 452d → 430d |  | baseline start 2026-03-31 → 2026-04-30; baseline finish 2026-03-31 → 2026-04-30 |
| 3158 | **Migration Artefact Development and Publication** |  |  |  | 93% → 94% |  |  |  |
| 3232 | **Connection Type and Meter Type Misalignments** |  |  |  | 85% → 86% |  |  |  |
| 3233 | **Traditional Meters installed on Current Transformers** |  |  |  | 66% → 68% |  |  |  |
| 3238 | Suppliers to have completed meter exchanges for those MPANs in pot 1 |  |  |  | 55% → 58% |  |  |  |
| 3284 | **Preparation for Cutover to Live** |  |  |  | 63% → 64% |  |  |  |
| 3372 | **Migration Exclusion PPIR** |  | 2026-03-13 A |  | 90% → 100% | 464d → none |  |  |
| 3374 | Participant response window for PPIR |  | 2026-03-13 A |  | 90% → 100% | 464d → none |  |  |
| 3375 | PPIR consultation window closed | 2026-03-13 A | 2026-03-13 A |  | 0% → 100% | 464d → none |  |  |
| 3376 | **Migration Sprints** |  |  |  | 23% → 25% |  |  |  |
| 3387 | **Migration Sprint 1** |  |  |  | 55% → 73% |  |  |  |
| 3394 | Sprint Execution |  |  |  | 62% → 87% |  |  |  |
| 3400 | Supplier Submission Deadline | 2026-03-18 A | 2026-03-18 A |  | 0% → 100% | 397d → none |  |  |
| 3401 | Baseline Schedule Publication | 2026-03-25 A | 2026-03-25 A |  | 0% → 100% | 397d → none |  |  |
| 3402 | Migration Sprint 2 Schedule Baselined | 2026-03-25 A | 2026-03-25 A |  | 0% → 100% | 397d → none |  |  |
| 3490 | **BUSINESS & OPERATIONAL READINESS** |  |  |  | 68% → 78% |  |  |  |
| 3669 | **M16: Decision Approach** |  |  |  | 59% → 65% |  |  |  |
| 3671 | M16 Decision Proposal Agreed | 2026-01-09 A | 2026-01-09 A |  | 0% → 100% | 510d → none |  |  |
| 3674 | **Consult and Agree with Industry** |  |  |  | 59% → 65% |  |  |  |
| 3684 | **M16 Working Group 3** |  | 2026-03-12 A |  | 99% → 100% | 460d → none |  |  |
| 3686 | M16 Working Group 3 Completed | 2026-03-12 A | 2026-03-12 A |  | 0% → 100% | 460d → none |  |  |
| 3687 | **M16 Working Group 4** | 2026-03-13 A |  |  | 0% → 99% | 389d → 280d |  |  |
| 3688 | Materials Prepared and Shared | 2026-03-13 A | 2026-03-19 A |  | 0% → 100% | 460d → none |  |  |
| 3696 | M16 Approach Approved at MCAG |  |  |  |  | 379d → 280d |  | was named Approved at eMCAG |
| 3713 | STEG Nov |  |  |  |  |  |  | was named STEG Noc |
| 3738 | **Decision 1 RF Change to 7 months from Settlement Day 01/10** |  |  |  |  |  |  | was named Decision 1 RF Change 7 to months from Settlement Day 01/10 |
| 3751 | MCAG Approve Recommendation - Confirm M16 Date |  |  |  |  | 134d → 5d |  | was named MCAG Approve Recommendation - Confrim M16 Date |
| 3753 | **M16: Creation & Implementation of Updated Settlement Calendars** |  |  |  |  |  |  | was named M16: Creation & Implementation of Updated Settelemnt Calendars |
| 3767 | Panel approval that M16 criteria met |  |  |  |  |  | Confirm M16 DateFS+40d → 3751FS+5d |  |
| 3768 | Cut over to new settlement timetable (M16) |  |  |  |  |  | 3767, 3488FS+40d, Elexon monitor settlement data of migrated MPANs, 3765, Raise fast track change to ISD (November publish), 3668 → 3767, 3488FS+40d, 3765, 3668 |  |
| 3811 | **READINESS ASSESSMENTS** | 2022-10-31 A → 2023-09-05 A (+309d) |  | 1209d → 988d | 55% → 58% |  |  |  |
| 3826 | **Readiness Assessment 7 - Migration Checkpoint** |  |  |  | 32% → 73% |  |  |  |
| 3829 | Evidence asessment |  |  |  | 21% → 68% |  |  |  |
| 3830 | Readiness Assessment 7 survey closes | 2026-03-16 A | 2026-03-16 A |  | 0% → 100% | 451d → none |  |  |
| 3847 | **Readiness Assessments - Tier 1 Milestones** | 2022-10-31 A → 2025-07-01 A (+974d) |  | 1209d → 512d |  |  |  |  |
| 3849 | Readiness Assessment 7 - Migration Checkpoint - Completed (incl. Readiness Assessment Report approval) | 2022-10-31 → 2026-04-01 (+1248d) | 2022-10-31 → 2026-04-01 (+1248d) |  |  | 1344d → 451d |  | constraint none → finish no earlier than 2026-04-01; baseline start 2026-03-19 → 2026-04-01; baseline finish 2026-03-19 → 2026-04-01 |

## Version 25 (data date 2026-04-08, saved 2026-04-08, file MHHS-DEL1139 - MHHS Plan v6.47.mpp)

Last finish stays 2027-12-23. Complete tasks 2695 → 2727.

Added:

| ID | Task | Duration | Start | Finish | Predecessors |
| --- | --- | --- | --- | --- | --- |
| 2330 | 26.13 | 10d? | 2026-06-24 | 2026-07-07 | 2329 |
| 2409 | Catalogue Publish Improvement Development | 40d | 2026-04-01 A | 2026-05-26 | 2323 |
| 2410 | Manage ISD Process Improvement Development | 60d | 2026-04-01 A | 2026-06-23 | 2323 |

Removed: 3663 M16 Methodology; 3664 Draft Document; 3665 Share Document with SRO; 3666 Industry Consultation; 3667 Assurance Meeting; 3668 M16 methodology approved

Changed:

| ID | Task | Start | Finish | Duration | Complete | Total float | Predecessors | Other |
| --- | --- | --- | --- | --- | --- | --- | --- | --- |
| 3 | **PROGRAMME MANAGEMENT** |  |  |  | 82% → 83% |  |  |  |
| 21 | **PP Communications** |  |  |  | 82% → 83% |  |  |  |
| 22 | The Clock updates (weekly) |  |  |  | 82% → 83% |  |  |  |
| 23 | Maintain and update content on public-facing Portal (and ongoing feedback reviews to identify and implement Portal improvements) |  |  |  | 82% → 83% |  |  |  |
| 56 | **Establish Design Change Management Processes** |  |  |  | 80% → 81% |  |  |  |
| 61 | Maintain E2E MHHS Design (post-M5 design change management processes operational) |  |  |  | 79% → 80% |  |  |  |
| 507 | **SYSTEMS INTEGRATION TESTING (SIT)** |  |  |  | 98% → 99% |  |  |  |
| 1724 | **Onboarding and Test Data (Sandbox UIT)** |  |  |  | 72% → 76% |  |  |  |
| 1726 | Supplier & Agent Onboarding and Test Data Creation and Support |  |  |  | 53% → 61% |  |  |  |
| 1727 | **Sandbox Execution** |  |  |  | 75% → 79% |  |  |  |
| 1737 | **Sandbox Testing Execution (UIT) - Supplier & Agent Participants** |  |  |  | 53% → 61% |  |  |  |
| 1740 | Sandbox Testing Execution (UIT) - Supplier & Agent Participants |  |  |  | 53% → 61% |  |  |  |
| 2309 | **ELEXON / HELIX M10 - M16** |  |  | 331d → 331d? | 74% → 77% |  |  |  |
| 2310 | **Solution Build Sprints** |  | 2026-06-23 → 2026-07-07 (+14d) | 210d → 220d? | 67% → 69% | 392d → 382d |  |  |
| 2323 | 26.6 |  | 2026-03-31 A |  | 50% → 100% | 392d → none |  |  |
| 2324 | 26.7 | 2026-04-01 A |  |  | 0% → 60% | 392d → 382d |  |  |
| 2331 | **Release management deployment schedule** |  |  |  | 81% → 82% |  |  |  |
| 2342 | 26.6.0 |  | 2026-04-01 → 2026-04-09 (+8d) | 11d → 17d | 45% → 29% | 451d → 445d |  |  |
| 2343 | 26.7.0 | 2026-04-01 A |  |  | 0% → 38% |  |  |  |
| 2344 | **Work Package Development** |  |  |  | 82% → 83% |  |  |  |
| 2345 | **DAH** |  |  |  | 78% → 85% |  |  |  |
| 2363 | Tech debt DA3 test suite improvements |  | 2026-03-31 → 2026-04-14 (+14d) | 40d → 50d | 88% → 92% | 452d → 442d |  | baseline finish 2026-03-31 → 2026-04-14 |
| 2364 | Data lifecycle |  | 2026-03-31 A |  | 88% → 100% | 452d → none |  |  |
| 2365 | Business Validations |  |  |  | 17% → 37% |  |  |  |
| 2367 | Tech Debt DA2: Azure cost reduction, optimising data storage and processing |  |  |  | 63% → 90% |  |  |  |
| 2369 | SDR Discovery |  | 2026-03-31 A |  | 75% → 100% | 452d → none |  |  |
| 2371 | Electralink improvement |  |  |  | 25% → 80% |  |  |  |
| 2374 | Smart Data Repository | 2026-04-01 A |  |  | 0% → 15% |  |  |  |
| 2375 | **WP2 (LSS/MDS/VAS/OP)** |  |  |  | 76% → 86% |  |  |  |
| 2389 | SCCS Trading Party ID |  |  |  | 20% → 87% |  |  | baseline finish 2026-03-31 → 2026-04-14 |
| 2390 | OP: Edit configuration parameters from UI |  |  |  | 17% → 53% |  |  |  |
| 2391 | MDS (remove IF-96) | 2026-04-01 → 2026-04-15 (+14d) | 2026-04-14 → 2026-04-28 (+14d) |  |  | 442d → 432d | 2323 → 2324 | baseline start 2026-04-01 → 2026-04-15; baseline finish 2026-04-14 → 2026-04-28 |
| 2393 | **ISD** |  | 2026-04-14 → 2026-06-23 (+70d) | 140d → 190d | 95% → 78% | 442d → 392d |  |  |
| 2394 | **ISD Asure** |  | 2026-04-14 → 2026-04-28 (+14d) | 110d → 120d | 95% → 94% | 442d → 432d |  |  |
| 2399 | LLF Process Improvement Analysis |  | 2026-03-31 A |  | 83% → 100% | 452d → none |  |  |
| 2400 | ISD Refresh | 2026-03-23 → 2026-04-01 A (+9d) | 2026-03-24 → 2026-04-28 (+35d) | 2d → 20d | 0% → 25% | 457d → 432d | 2341FS+1d → 2323 |  |
| 2402 | ISD Navigation Analysis |  | 2026-03-31 A |  | 50% → 100% | 452d → none |  |  |
| 2403 | **ISD Salesforce** |  | 2026-03-31 → 2026-06-23 (+84d) | 130d → 190d | 96% → 64% | 452d → 392d |  |  |
| 2407 | Manage ISD Process Improvement Analysis |  | 2026-03-31 A |  | 75% → 100% | 452d → none |  |  |
| 2408 | ISD Refresh | 2026-03-23 → 2026-04-01 A (+9d) | 2026-03-24 → 2026-04-28 (+35d) | 2d → 20d | 0% → 30% | 457d → 432d | 2341FS+1d → 2323 | baseline start 2026-03-23 → 2026-04-01; baseline finish 2026-03-24 → 2026-04-28 |
| 2426 | **SAT M16 Test Case Execution** | 2026-04-01 A |  |  | 0% → 9% |  |  |  |
| 2427 | SAT Prep / Analysis | 2026-04-01 A |  |  | 0% → 27% |  |  |  |
| 2430 | SAT Programme Assurance Review of Test Results | 2026-04-01 A |  |  | 0% → 9% |  |  |  |
| 2431 | LSS provides Load Shape data that is publicly accessible - Business Requirement MHHSP-37 | 2026-04-08 A | 2026-04-08 A |  | 0% → 100% | 446d → none |  |  |
| 2432 | **S & A QUALIFICATION** |  |  |  | 93% → 94% |  |  |  |
| 2544 | **MHHS Qualification - Qualification Waves** |  |  |  | 91% → 92% |  |  |  |
| 2760 | QAD Sign Off deadline |  | 2026-03-20 A |  | 92% → 100% | 435d → none |  |  |
| 2763 | **Qualification Wave 2** |  |  |  | 96% → 99% |  |  |  |
| 2791 | **Qualification Wave 2 Exit** |  |  |  | 89% → 96% |  |  |  |
| 2797 | Completion of Code Bodies review of Final QAD |  |  |  | 46% → 85% |  |  |  |
| 2801 | **Qualification Wave 3** |  |  |  | 65% → 68% |  |  |  |
| 2822 | **Qualification Wave 3 QT Execution** |  |  |  | 88% → 92% |  |  |  |
| 2827 | Qualification Wave 3 QT Execution Window |  |  |  | 87% → 91% |  |  |  |
| 2829 | **Qualification Wave 3 Exit** |  |  |  | 2% → 8% |  |  |  |
| 2832 | Qualification Wave 3 Participants submit their Final QAD |  |  |  | 2% → 10% |  |  |  |
| 2839 | **Qualification Wave 4** |  |  |  | 49% → 54% |  |  |  |
| 2840 | **Qualification Wave 4 QAD Prep** |  |  |  | 76% → 80% |  |  |  |
| 2844 | Code Bodies review of Wave 4 Participants' Initial QAD |  |  |  | 23% → 38% |  |  |  |
| 2856 | **Qualification Wave 4 QT Execution** |  |  |  | 26% → 47% |  |  |  |
| 2860 | Qualification Wave 4 QT Execution Window |  |  |  | 22% → 44% |  |  |  |
| 2899 | PAB2026/05 | 2026-03-26 A | 2026-03-26 A |  | 0% → 100% | 455d → none |  |  |
| 3068 | **MIGRATION** |  |  |  | 91% → 92% |  |  |  |
| 3069 | **Regulatory Governance** |  |  |  | 88% → 95% |  |  |  |
| 3072 | Ofgem Incentives Approval |  |  |  | 82% → 93% |  |  |  |
| 3235 | **Connection Type and Meter Type Misalignments** |  |  |  | 86% → 87% |  |  |  |
| 3236 | **Traditional Meters installed on Current Transformers** |  |  |  | 68% → 70% |  |  |  |
| 3241 | Suppliers to have completed meter exchanges for those MPANs in pot 1 |  |  |  | 58% → 60% |  |  |  |
| 3287 | **Preparation for Cutover to Live** |  |  |  | 64% → 66% |  |  |  |
| 3379 | **Migration Sprints** |  |  |  | 25% → 28% |  |  |  |
| 3390 | **Migration Sprint 1** |  |  |  | 73% → 93% |  |  |  |

| ID | Task | Start | Finish | Duration | Complete | Total float | Predecessors | Other |
| --- | --- | --- | --- | --- | --- | --- | --- | --- |
| 3397 | Sprint Execution |  | 2026-03-31 A |  | 87% → 100% | 442d → none |  |  |
| 3398 | Sprint Execution End | 2026-03-31 A | 2026-03-31 A |  | 0% → 100% | 442d → none |  |  |
| 3399 | Sprint 1 Retro | 2026-04-01 A |  |  | 0% → 60% |  |  |  |
| 3400 | **Migration Sprint 2** |  |  |  | 10% → 18% |  |  |  |
| 3406 | Sprint Execution Start | 2026-04-01 A | 2026-04-01 A |  | 0% → 100% | 397d → none |  |  |
| 3407 | Sprint Execution | 2026-04-02 A |  |  | 0% → 11% |  |  |  |
| 3493 | **BUSINESS & OPERATIONAL READINESS** |  |  |  | 78% → 76% |  |  |  |
| 3494 | **Service Management** |  |  |  | 76% → 77% |  |  |  |
| 3508 | **Wave 1** | 2026-03-31 A |  |  | 0% → 10% | 0d → 414d |  |  |
| 3509 | **Wave 1 - Service Activation Preparation Tasks** | 2026-03-31 A | 2026-04-10 A |  | 0% → 100% |  |  |  |
| 3510 | Review Entry/Exit Criteria & Lessons Learned | 2026-03-31 A | 2026-03-31 A |  | 0% → 100% | 452d → none |  |  |
| 3511 | Identify Resources | 2026-03-31 A | 2026-03-31 A |  | 0% → 100% | 452d → none |  |  |
| 3512 | Confirmation from Qualification of Wave Participants Complete | 2026-03-31 A | 2026-03-31 A |  | 0% → 100% | 452d → none |  |  |
| 3513 | Agree & Understand Support Model | 2026-04-01 A | 2026-04-01 A |  | 0% → 100% | 451d → none |  |  |
| 3514 | Training Confirmation | 2026-04-02 A | 2026-04-02 A |  | 0% → 100% | 450d → none |  |  |
| 3515 | Training Confirmation Completed | 2026-04-02 A | 2026-04-02 A |  | 0% → 100% | 450d → none |  |  |
| 3516 | Engagement / Communications with Participants Completed | 2026-04-03 A | 2026-04-03 A |  | 0% → 100% | 449d → none |  |  |
| 3517 | **Internal Communications** | 2026-04-06 A | 2026-04-06 A |  | 0% → 100% |  |  |  |
| 3518 | Agree Content for Livewire | 2026-04-06 A | 2026-04-06 A |  | 0% → 100% | 448d → none |  |  |
| 3519 | Publish Content for Livewire | 2026-04-06 A | 2026-04-06 A |  | 0% → 100% | 448d → none |  |  |
| 3520 | Validate User Access | 2026-04-07 A | 2026-04-07 A |  | 0% → 100% | 447d → none |  |  |
| 3521 | Target Systems and Environments Ready | 2026-04-08 A | 2026-04-08 A |  | 0% → 100% | 446d → none |  |  |
| 3522 | Provide LWIs | 2026-04-09 A | 2026-04-09 A |  | 0% → 100% | 445d → none |  |  |
| 3523 | Business Readiness Governance Approval | 2026-04-10 A | 2026-04-10 A |  | 0% → 100% | 444d → none |  |  |
| 3524 | Wave 1 - Service Activation Preparation Tasks (M) | 2026-04-10 A | 2026-04-10 A |  | 0% → 100% | 444d → none |  |  |
| 3525 | **Wave 1 - Service Activation Implementation** | 2026-04-02 A |  |  | 0% → 11% |  |  |  |
| 3526 | Market Entry to obtain Effective from Date from PP | 2026-04-02 A | 2026-04-02 A |  | 0% → 100% | 450d → none |  |  |
| 3666 | **M16: Decision Approach** |  |  |  | 65% → 77% |  |  |  |
| 3667 | **Agree Approach M16 Decision Proposal** |  | 2026-04-23 A |  | 0% → 100% |  |  |  |
| 3670 | 2026 Settlement Calendar Produced | 2026-04-01 A | 2026-04-01 A |  | 0% → 100% | 452d → none |  |  |
| 3671 | **Consult and Agree with Industry** |  |  |  | 65% → 77% |  |  |  |
| 3684 | **M16 Working Group 4** |  | 2026-03-26 A |  | 99% → 100% | 280d → none |  |  |
| 3686 | M16 Working Group 4 Completed | 2026-03-26 A | 2026-03-26 A |  | 0% → 100% | 280d → none |  |  |
| 3687 | **M16 Decision Making and Monitoring Criteria Consultation** | 2026-03-27 A | 2026-05-21 → 2026-06-05 (+15d) | 40d → 51d | 0% → 33% | 280d → 269d |  |  |
| 3688 | Prepare consultation material | 2026-03-27 A | 2026-04-09 A |  | 0% → 100% | 280d → none |  |  |
| 3689 | Issue Consultation | 2026-04-10 → 2026-04-27 (+17d) | 2026-04-10 → 2026-04-27 (+17d) |  |  | 280d → 269d |  | constraint finish no earlier than 2026-04-10 → finish no earlier than 2026-04-27 |
| 3690 | Consultation Period | 2026-04-10 → 2026-04-27 (+17d) | 2026-05-07 → 2026-05-22 (+15d) |  |  | 280d → 269d |  |  |
| 3691 | Consultation Period Completed | 2026-05-07 → 2026-05-22 (+15d) | 2026-05-07 → 2026-05-22 (+15d) |  |  | 280d → 269d |  |  |
| 3692 | Materials Issued for Approval at eMCAG | 2026-05-14 → 2026-05-29 (+15d) | 2026-05-14 → 2026-05-29 (+15d) |  |  | 280d → 269d |  |  |
| 3693 | M16 Approach Approved at MCAG | 2026-05-21 → 2026-06-05 (+15d) | 2026-05-21 → 2026-06-05 (+15d) |  |  | 280d → 269d |  |  |
| 3758 | **Post Decision 3** | 2026-03-09 → 2027-03-08 (+364d) | 2027-06-17 → 2027-04-02 (-76d) | 334d → 20d |  |  |  | baseline start 2026-03-09 → 2027-04-02 |
| 3759 | Prepare Variant Jul-27 - Mar-28 Including 4/7 Month and 7 Day SF | 2026-03-09 → 2027-03-08 (+364d) | 2026-04-03 → 2027-04-02 (+364d) |  |  | 449d → 189d |  | constraint start no earlier than 2026-03-09 → start no earlier than 2027-03-08; baseline start 2026-03-09 → 2027-03-08; baseline finish 2026-04-03 → 2027-04-02 |
| 3760 | Prepare Variant Jul-27 - Sep-28 Excluding SF Change Contingency | 2026-03-09 → 2027-03-08 (+364d) | 2026-04-03 → 2027-04-02 (+364d) |  |  | 449d → 189d |  | constraint start no earlier than 2026-03-09 → start no earlier than 2027-03-08; baseline start 2026-03-09 → 2027-03-08; baseline finish 2026-04-03 → 2027-04-02 |
| 3765 | Cut over to new settlement timetable (M16) |  |  |  |  |  | 3764, 3491FS+40d, 3762, M16 methodology approved → 3764, 3491FS+40d, 3762 |  |
| 3808 | **READINESS ASSESSMENTS** |  |  |  | 58% → 60% |  |  |  |
| 3823 | **Readiness Assessment 7 - Migration Checkpoint** |  | 2026-04-01 A |  | 73% → 100% | 451d → none |  |  |
| 3826 | Evidence asessment |  | 2026-04-01 A |  | 68% → 100% | 451d → none |  |  |
| 3828 | Report on Readiness Assessment 7 findings at PSG | 2026-04-01 A | 2026-04-01 A |  | 0% → 100% | 451d → none |  |  |
| 3829 | Readiness Assessment 7 - Migration Checkpoint - Completed (incl. Readiness Assessment Report approval) | 2026-04-01 A | 2026-04-01 A |  | 0% → 100% | 451d → none |  |  |
| 3846 | Readiness Assessment 7 - Migration Checkpoint - Completed (incl. Readiness Assessment Report approval) | 2026-04-01 A | 2026-04-01 A |  | 0% → 100% | 451d → none |  |  |

## Version 26 (data date 2026-04-22, saved 2026-04-22, file MHHS-DEL1139 - MHHS Plan v6.48.mpp)

Last finish stays 2027-12-23. Complete tasks 2727 → 2742.

Added:

| ID | Task | Duration | Start | Finish | Constraint |
| --- | --- | --- | --- | --- | --- |
| 2344 | 26.8.0 | 1d? | 2026-04-30 | 2026-04-30 | start no earlier than 2026-04-30 |
| 2345 | 26.9.0 | 1d? | 2026-05-14 | 2026-05-14 | start no earlier than 2026-05-14 |
| 2346 | 26.10.0 | 1d? | 2026-05-28 | 2026-05-28 | start no earlier than 2026-05-28 |
| 2347 | 26.11.0 | 1d? | 2026-06-11 | 2026-06-11 | start no earlier than 2026-06-11 |
| 2348 | 26.12.0 | 1d? | 2026-06-25 | 2026-06-25 | start no earlier than 2026-06-25 |
| 2349 | 26.13.0 | 1d? | 2026-07-09 | 2026-07-09 | start no earlier than 2026-07-09 |
| 2350 | 26.14.0 | 1d? | 2026-07-23 | 2026-07-23 | start no earlier than 2026-07-23 |

Changed:

| ID | Task | Start | Finish | Duration | Complete | Total float | Other |
| --- | --- | --- | --- | --- | --- | --- | --- |
| 1 | **PROGRAMME PLAN.** |  |  |  | 90% → 91% |  |  |
| 3 | **PROGRAMME MANAGEMENT** |  |  |  | 83% → 84% |  |  |
| 4 | **Programme Management** |  |  |  | 82% → 83% |  |  |
| 5 | Sprint-based prioritisation planning and execution |  |  |  | 82% → 83% |  |  |
| 6 | Programme governance secretariat |  |  |  | 82% → 83% |  |  |
| 7 | RAID management and reporting |  |  |  | 82% → 83% |  |  |
| 8 | Tracking against Programme outcomes and KPIs |  |  |  | 82% → 83% |  |  |
| 9 | Change control and reporting |  |  |  | 82% → 83% |  |  |
| 10 | Ongoing identification of lessons learned relating to the PMO and implementation of improvements |  |  |  | 82% → 83% |  |  |
| 11 | **Programme Internal Assurance Reviews** |  |  |  | 82% → 83% |  |  |
| 12 | Programme Internal Assurance Reviews |  |  |  | 82% → 83% |  |  |
| 13 | **Engagement with PPs** |  |  |  | 82% → 83% |  |  |
| 14 | Ongoing PP liaison activities |  |  |  | 82% → 83% |  |  |
| 15 | Milestone and Control Point objective setting |  |  |  | 82% → 83% |  |  |
| 16 | Reporting |  |  |  | 82% → 83% |  |  |
| 17 | **PP Engagement Events** |  |  |  | 82% → 83% |  |  |
| 18 | Bilateral meetings |  |  |  | 82% → 83% |  |  |
| 19 | Monthly webinars |  |  |  | 82% → 83% |  |  |
| 20 | Open days |  |  |  | 82% → 83% |  |  |
| 24 | **Code Change Support / Other Programme Alignment** |  |  |  | 82% → 83% |  |  |
| 25 | Support DCC/BEIS on SEC change |  |  |  | 82% → 83% |  |  |
| 26 | Support on Smart Meters Act changes |  |  |  | 82% → 83% |  |  |
| 27 | Support DCC/RECCo on CSS change |  |  |  | 82% → 83% |  |  |
| 28 | Support Elexon on BSC change |  |  |  | 82% → 83% |  |  |
| 29 | Support code change inside & outside CCIAG |  |  |  | 82% → 83% |  |  |
| 30 | Support code change inside & outside CCAG |  |  |  | 82% → 83% |  |  |
| 46 | **Design Baseline & Enduring PP Support** |  |  |  | 91% → 92% |  |  |
| 56 | **Establish Design Change Management Processes** |  |  |  | 81% → 82% |  |  |
| 61 | Maintain E2E MHHS Design (post-M5 design change management processes operational) |  |  |  | 80% → 81% |  |  |
| 1673 | **UIT Environment Preparation** |  |  |  | 96% → 97% |  |  |
| 1724 | **Onboarding and Test Data (Sandbox UIT)** |  |  |  | 76% → 79% |  |  |
| 1726 | Supplier & Agent Onboarding and Test Data Creation and Support |  |  |  | 61% → 65% |  |  |
| 1727 | **Sandbox Execution** |  |  |  | 79% → 81% |  |  |
| 1737 | **Sandbox Testing Execution (UIT) - Supplier & Agent Participants** |  |  |  | 61% → 65% |  |  |
| 1740 | Sandbox Testing Execution (UIT) - Supplier & Agent Participants |  |  |  | 61% → 65% |  |  |
| 2310 | **Solution Build Sprints** |  |  |  | 69% → 74% |  |  |
| 2324 | 26.7 |  | 2026-04-14 A |  | 60% → 100% | 382d → none |  |
| 2325 | 26.8 | 2026-04-15 A |  |  | 0% → 60% |  |  |
| 2331 | **Release management deployment schedule** |  |  | 321d → 321d? | 82% → 81% |  |  |
| 2342 | 26.6.0 |  | 2026-04-09 A |  | 29% → 100% | 445d → none |  |
| 2343 | 26.7.0 |  | 2026-04-22 A |  | 38% → 100% | 436d → none |  |
| 2351 | **Work Package Development** |  |  |  | 83% → 81% |  |  |
| 2352 | **DAH** |  | 2026-06-30 → 2026-07-21 (+21d) | 205d → 220d | 85% → 78% | 387d → 372d |  |
| 2370 | Tech debt DA3 test suite improvements |  | 2026-04-14 → 2026-07-07 (+84d) | 50d → 110d | 92% → 42% | 442d → 382d | baseline finish 2026-04-14 → 2026-07-07 |
| 2372 | Business Validations |  |  |  | 37% → 48% |  |  |
| 2374 | Tech Debt DA2: Azure cost reduction, optimising data storage and processing |  | 2026-04-14 → 2026-07-21 (+98d) | 40d → 110d | 90% → 33% | 442d → 372d |  |
| 2378 | Electralink improvement |  | 2026-04-14 A |  | 80% → 100% | 442d → none |  |
| 2379 | REP009 CoS Updates | 2026-04-15 A |  |  | 0% → 60% |  |  |
| 2380 | I022 incremental sequence | 2026-04-15 A |  |  | 0% → 60% |  |  |
| 2381 | Smart Data Repository |  |  |  | 15% → 40% |  |  |
| 2382 | **WP2 (LSS/MDS/VAS/OP)** |  |  |  | 86% → 93% |  |  |
| 2396 | SCCS Trading Party ID |  | 2026-04-14 A |  | 87% → 100% | 442d → none |  |
| 2397 | OP: Edit configuration parameters from UI |  |  |  | 53% → 87% |  |  |
| 2398 | MDS (remove IF-96) | 2026-04-15 A |  |  | 0% → 60% |  |  |
| 2399 | Make VAS run during transition mode without legacy data | 2026-04-15 A |  |  | 0% → 30% |  |  |
| 2400 | **ISD** |  |  |  | 78% → 80% |  |  |
| 2401 | **ISD Asure** |  | 2026-04-28 → 2026-05-07 (+9d) | 120d → 127d | 94% → 92% | 432d → 425d |  |
| 2407 | ISD Refresh |  | 2026-04-28 → 2026-05-07 (+9d) | 20d → 27d | 25% → 19% | 432d → 425d |  |
| 2410 | **ISD Salesforce** |  |  |  | 64% → 69% |  |  |
| 2415 | ISD Refresh |  | 2026-04-28 → 2026-05-07 (+9d) | 20d → 27d | 30% → 22% | 432d → 425d |  |
| 2416 | Catalogue Publish Improvement Development |  |  |  | 15% → 40% |  |  |
| 2417 | Manage ISD Process Improvement Development |  |  |  | 10% → 27% |  |  |
| 2433 | **SAT M16 Test Case Execution** |  |  |  | 9% → 25% |  |  |
| 2434 | SAT Prep / Analysis |  |  |  | 27% → 73% |  |  |
| 2437 | SAT Programme Assurance Review of Test Results |  |  |  | 9% → 25% |  |  |
| 2551 | **MHHS Qualification - Qualification Waves** |  |  |  | 92% → 93% |  |  |
| 2732 | **Qualification Wave 1** |  | 2026-04-15 A |  | 99% → 100% | 441d → none |  |
| 2760 | **Qualification Wave 1 Exit** |  | 2026-04-15 A |  | 99% → 100% | 441d → none |  |
| 2768 | 80% of M14 Critical Wave 1 Participants Qualification approved by BSC PAB and REC Manager |  | 2026-04-15 A |  | 20% → 100% | 441d → none |  |
| 2769 | All M14 Critical Wave 1 Participants Qualification approved by BSC PAB and REC Manager |  | 2026-04-15 A |  | 20% → 100% | 435d → none |  |

| ID | Task | Start | Finish | Duration | Complete | Total float | Predecessors | Other |
| --- | --- | --- | --- | --- | --- | --- | --- | --- |
| 2808 | **Qualification Wave 3** |  |  |  | 68% → 67% |  |  |  |
| 2809 | **Qualification Wave 3 QAD Prep** |  |  |  | 98% → 92% |  |  |  |
| 2814 | Code Bodies review of Wave 3 Participants' Initial QAD |  |  |  | 93% → 74% |  |  |  |
| 2846 | **Qualification Wave 4** |  |  |  | 54% → 61% |  |  |  |
| 2847 | **Qualification Wave 4 QAD Prep** |  |  |  | 80% → 79% |  |  |  |
| 2851 | Code Bodies review of Wave 4 Participants' Initial QAD |  |  |  | 38% → 33% |  |  |  |
| 2863 | **Qualification Wave 4 QT Execution** |  |  |  | 47% → 77% |  |  |  |
| 2867 | Qualification Wave 4 QT Execution Window |  |  |  | 44% → 76% |  |  |  |
| 2907 | PAB2026/06 | 2026-04-15 A | 2026-04-15 A |  | 0% → 100% | 441d → none |  |  |
| 3075 | **MIGRATION** |  |  |  | 92% → 94% |  |  |  |
| 3076 | **Regulatory Governance** |  |  |  | 95% → 98% |  |  |  |
| 3079 | Ofgem Incentives Approval |  |  |  | 93% → 97% |  |  |  |
| 3168 | **Migration Artefact Development and Publication** |  | 2026-10-28 A |  | 94% → 100% | 301d → none |  |  |
| 3242 | **Connection Type and Meter Type Misalignments** |  | 2026-10-28 A |  | 87% → 100% | 301d → none |  |  |
| 3243 | **Traditional Meters installed on Current Transformers** |  | 2026-10-28 A |  | 70% → 100% | 301d → none |  |  |
| 3248 | Suppliers to have completed meter exchanges for those MPANs in pot 1 |  | 2026-10-28 A |  | 60% → 100% | 301d → none |  |  |
| 3249 | Traditional Meters installed on Current Transformers complete | 2026-10-28 A | 2026-10-28 A |  | 0% → 100% | 301d → none |  |  |
| 3294 | **Preparation for Cutover to Live** |  |  |  | 66% → 67% |  |  |  |
| 3386 | **Migration Sprints** |  |  |  | 28% → 31% |  |  |  |
| 3397 | **Migration Sprint 1** |  | 2026-04-14 A |  | 93% → 100% | 442d → none |  |  |
| 3406 | Sprint 1 Retro |  | 2026-04-14 A |  | 60% → 100% | 442d → none |  |  |
| 3407 | **Migration Sprint 2** |  |  |  | 18% → 33% |  |  |  |
| 3414 | Sprint Execution |  |  |  | 11% → 32% |  |  |  |
| 3515 | **Wave 1** |  |  |  | 10% → 13% |  |  |  |
| 3532 | **Wave 1 - Service Activation Implementation** |  |  |  | 11% → 22% |  |  |  |
| 3534 | PP is Qualified by Code Bodies | 2026-04-15 A | 2026-04-15 A |  | 0% → 100% | 435d → none |  |  |
| 3536 | Create M16 in Customer Solution | 2026-04-16 A | 2026-04-16 A |  | 0% → 100% | 440d → none |  |  |
| 3542 | **Wave 1 - Service Activation Implementation MDD** | 2026-04-15 A | 2026-04-16 A |  | 0% → 100% | 434d → none |  |  |
| 3543 | MDD Final Circular Completed | 2026-04-15 A | 2026-04-15 A |  | 0% → 100% | 434d → none |  |  |
| 3544 | MDD Manual Update | 2026-04-15 A | 2026-04-16 A |  | 0% → 100% | 434d → none |  |  |
| 3694 | **M16 Decision Making and Monitoring Criteria Consultation** |  | 2026-06-05 → 2026-06-23 (+18d) | 51d → 62d |  | 269d → 258d |  |  |
| 3696 | Issue Consultation | 2026-04-27 → 2026-04-29 (+2d) | 2026-04-27 → 2026-04-29 (+2d) |  |  | 269d → 268d |  | constraint finish no earlier than 2026-04-27 → start no earlier than 2026-04-29 |
| 3697 | Consultation Period | 2026-04-27 → 2026-04-29 (+2d) | 2026-05-22 → 2026-05-26 (+4d) |  |  | 269d → 267d |  | constraint finish no earlier than 2026-05-07 → start no earlier than 2026-04-29 |
| 3698 | Consultation Period Completed | 2026-05-22 → 2026-05-26 (+4d) | 2026-05-22 → 2026-05-26 (+4d) |  |  | 269d → 267d |  |  |
| 3699 | Materials Issued for Approval at MCAG | 2026-05-29 → 2026-06-02 (+4d) | 2026-05-29 → 2026-06-02 (+4d) |  |  | 269d → 267d |  | was named Materials Issued for Approval at eMCAG |
| 3700 | M16 Approach Approved at MCAG | 2026-06-05 → 2026-06-23 (+18d) | 2026-06-05 → 2026-06-23 (+18d) |  |  | 269d → 258d |  | constraint finish no earlier than 2026-05-21 → start no earlier than 2026-06-23 |
| 3729 | STEG May - M16 Checkpoint 2 |  |  |  |  |  |  | was named STEG May - M16 Checkpoint 1 |
| 3734 | STEG Issue position to MCAG notifying Decision Checkpoint 1 On-track | 2026-07-13 → 2026-07-15 (+2d) | 2026-07-13 → 2026-07-15 (+2d) |  |  |  |  | constraint start no earlier than 2026-07-13 → start no earlier than 2026-07-15; baseline start 2026-07-13 → 2026-07-15; baseline finish 2026-07-13 → 2026-07-15 |
| 3735 | MCAG Endorses Assessment |  |  |  |  |  | 3734FS+5d → 3734FS+3d | constraint finish no earlier than 2026-07-17 → start no earlier than 2026-07-15 |
| 3736 | M16 Checkpoint 1 |  |  |  |  |  |  | was named Confidence Assessment 1 |

## Version 27 (data date 2026-05-06, saved 2026-05-06, file MHHS-DEL1139 - MHHS Plan v6.49.mpp)

Last finish stays 2027-12-23. Complete tasks 2742 → 2752.

Removed: 3702 Prepare April STEG Monitoring Report; 3704 Prepare May STEG Monitoring Report; 3706 Prepare Jun STEG Monitoring Report; 3708 Prepare Jul STEG Monitoring Report; 3710 Prepare Aug STEG Monitoring Report; 3712 Prepare SEP STEG Monitoring Report; 3714 Prepare SEP STEG Monitoring Report; 3716 Prepare SEP STEG Monitoring Report; 3718 Prepare SEP STEG Monitoring Report; 3720 Prepare SEP STEG Monitoring Report; 3722 Prepare SEP STEG Monitoring Report; 3724 Prepare SEP STEG Monitoring Report; 3726 Prepare SEP STEG Monitoring Report; 3728 Prepare SEP STEG Monitoring Report; 3730 Prepare SEP STEG Monitoring Report

Changed:

| ID | Task | Start | Finish | Duration | Complete | Total float | Other |
| --- | --- | --- | --- | --- | --- | --- | --- |
| 1 | **PROGRAMME PLAN.** |  |  |  | 91% → 92% |  |  |
| 4 | **Programme Management** |  |  |  | 83% → 84% |  |  |
| 5 | Sprint-based prioritisation planning and execution |  |  |  | 83% → 84% |  |  |
| 6 | Programme governance secretariat |  |  |  | 83% → 84% |  |  |
| 7 | RAID management and reporting |  |  |  | 83% → 84% |  |  |
| 8 | Tracking against Programme outcomes and KPIs |  |  |  | 83% → 84% |  |  |
| 9 | Change control and reporting |  |  |  | 83% → 84% |  |  |
| 10 | Ongoing identification of lessons learned relating to the PMO and implementation of improvements |  |  |  | 83% → 84% |  |  |
| 11 | **Programme Internal Assurance Reviews** |  |  |  | 83% → 84% |  |  |
| 12 | Programme Internal Assurance Reviews |  |  |  | 83% → 84% |  |  |
| 13 | **Engagement with PPs** |  |  |  | 83% → 84% |  |  |
| 14 | Ongoing PP liaison activities |  |  |  | 83% → 84% |  |  |
| 15 | Milestone and Control Point objective setting |  |  |  | 83% → 84% |  |  |
| 16 | Reporting |  |  |  | 83% → 84% |  |  |
| 17 | **PP Engagement Events** |  |  |  | 83% → 84% |  |  |
| 18 | Bilateral meetings |  |  |  | 83% → 84% |  |  |
| 19 | Monthly webinars |  |  |  | 83% → 84% |  |  |
| 20 | Open days |  |  |  | 83% → 84% |  |  |
| 21 | **PP Communications** |  |  |  | 83% → 84% |  |  |
| 22 | The Clock updates (weekly) |  |  |  | 83% → 84% |  |  |
| 23 | Maintain and update content on public-facing Portal (and ongoing feedback reviews to identify and implement Portal improvements) |  |  |  | 83% → 84% |  |  |
| 24 | **Code Change Support / Other Programme Alignment** |  |  |  | 83% → 84% |  |  |
| 25 | Support DCC/BEIS on SEC change |  |  |  | 83% → 84% |  |  |
| 26 | Support on Smart Meters Act changes |  |  |  | 83% → 84% |  |  |
| 27 | Support DCC/RECCo on CSS change |  |  |  | 83% → 84% |  |  |
| 28 | Support Elexon on BSC change |  |  |  | 83% → 84% |  |  |
| 29 | Support code change inside & outside CCIAG |  |  |  | 83% → 84% |  |  |
| 30 | Support code change inside & outside CCAG |  |  |  | 83% → 84% |  |  |
| 56 | **Establish Design Change Management Processes** |  |  |  | 82% → 83% |  |  |
| 61 | Maintain E2E MHHS Design (post-M5 design change management processes operational) |  |  |  | 81% → 82% |  |  |
| 1724 | **Onboarding and Test Data (Sandbox UIT)** |  |  |  | 79% → 81% |  |  |
| 1726 | Supplier & Agent Onboarding and Test Data Creation and Support |  |  |  | 65% → 68% |  |  |
| 1727 | **Sandbox Execution** |  |  |  | 81% → 83% |  |  |
| 1737 | **Sandbox Testing Execution (UIT) - Supplier & Agent Participants** |  |  |  | 65% → 68% |  |  |
| 1740 | Sandbox Testing Execution (UIT) - Supplier & Agent Participants |  |  |  | 65% → 68% |  |  |
| 2309 | **ELEXON / HELIX M10 - M16** |  |  |  | 77% → 81% |  |  |
| 2310 | **Solution Build Sprints** |  |  |  | 74% → 79% |  |  |
| 2325 | 26.8 |  | 2026-04-28 A |  | 60% → 100% | 382d → none |  |
| 2326 | 26.9 | 2026-04-29 A |  |  | 0% → 60% |  |  |
| 2331 | **Release management deployment schedule** |  |  |  | 81% → 84% |  |  |
| 2344 | 26.8.0 | 2026-04-30 A | 2026-04-30 A |  | 0% → 100% | 430d → none |  |
| 2351 | **Work Package Development** |  |  |  | 81% → 84% |  |  |
| 2352 | **DAH** |  |  |  | 78% → 80% |  |  |
| 2379 | REP009 CoS Updates |  | 2026-04-28 A |  | 60% → 100% | 432d → none |  |
| 2380 | I022 incremental sequence |  | 2026-04-28 A |  | 60% → 100% | 432d → none |  |
| 2381 | Smart Data Repository |  |  |  | 40% → 65% |  |  |
| 2382 | **WP2 (LSS/MDS/VAS/OP)** |  |  |  | 93% → 95% |  |  |
| 2397 | OP: Edit configuration parameters from UI |  | 2026-04-28 → 2026-05-12 (+14d) | 30d → 40d | 87% → 90% | 432d → 422d | constraint none → finish no earlier than 2026-05-12 |
| 2398 | MDS (remove IF-96) |  | 2026-04-28 A |  | 60% → 100% | 432d → none |  |
| 2400 | **ISD** |  |  |  | 80% → 84% |  |  |
| 2410 | **ISD Salesforce** |  |  |  | 69% → 76% |  |  |
| 2416 | Catalogue Publish Improvement Development |  |  |  | 40% → 65% |  |  |
| 2417 | Manage ISD Process Improvement Development |  |  |  | 27% → 43% |  |  |
| 2418 | **Settlement Checks** |  |  |  | 67% → 75% |  |  |
| 2419 | **M10** |  |  |  | 60% → 80% |  |  |
| 2423 | R3 | 2026-04-24 A | 2026-04-24 A |  | 0% → 100% | 434d → none |  |
| 2433 | **SAT M16 Test Case Execution** |  |  |  | 25% → 37% |  |  |
| 2434 | SAT Prep / Analysis |  | 2026-04-30 A |  | 73% → 100% | 387d → none |  |
| 2437 | SAT Programme Assurance Review of Test Results |  |  |  | 25% → 40% |  |  |
| 2439 | **S & A QUALIFICATION** |  |  |  | 94% → 95% |  |  |
| 2797 | Qualification Wave 2 QT Projected Execution End |  |  |  |  |  | was named QualIfication Wave 2 QT Execution End |
| 2798 | **Qualification Wave 2 Exit** |  |  |  | 96% → 97% |  |  |
| 2804 | Completion of Code Bodies review of Final QAD |  |  |  | 85% → 89% |  |  |
| 2808 | **Qualification Wave 3** |  |  |  | 67% → 69% |  |  |
| 2809 | **Qualification Wave 3 QAD Prep** |  |  |  | 92% → 93% |  |  |
| 2814 | Code Bodies review of Wave 3 Participants' Initial QAD |  |  |  | 74% → 77% |  |  |
| 2829 | **Qualification Wave 3 QT Execution** |  |  |  | 92% → 99% |  |  |
| 2834 | Qualification Wave 3 QT Execution Window |  | 2026-05-08 A |  | 91% → 100% | 359d → none |  |
| 2846 | **Qualification Wave 4** |  |  |  | 61% → 64% |  |  |
| 2863 | **Qualification Wave 4 QT Execution** |  |  |  | 77% → 92% |  |  |

| ID | Task | Start | Finish | Duration | Complete | Total float | Predecessors | Other |
| --- | --- | --- | --- | --- | --- | --- | --- | --- |
| 2867 | Qualification Wave 4 QT Execution Window |  |  |  | 76% → 92% |  |  |  |
| 2868 | Qualification Wave 4 Projected Execution End |  |  |  |  |  |  | baseline start 2026-07-17 → 2026-07-10; baseline finish 2026-07-17 → 2026-07-10 |
| 2908 | PAB2026/07 | 2026-04-30 A | 2026-04-30 A |  | 0% → 100% | 430d → none |  |  |
| 3294 | **Preparation for Cutover to Live** |  |  |  | 67% → 68% |  |  |  |
| 3386 | **Migration Sprints** |  |  |  | 31% → 33% |  |  |  |
| 3407 | **Migration Sprint 2** |  |  |  | 33% → 52% |  |  |  |
| 3414 | Sprint Execution |  |  |  | 32% → 57% |  |  |  |
| 3500 | **BUSINESS & OPERATIONAL READINESS** |  |  |  | 76% → 79% |  |  |  |
| 3501 | **Service Management** |  |  |  | 77% → 78% |  |  |  |
| 3515 | **Wave 1** |  |  |  | 13% → 19% |  |  |  |
| 3532 | **Wave 1 - Service Activation Implementation** |  | 2026-05-08 → 2026-05-15 (+7d) | 27d? → 31d? | 22% → 78% | 424d → 420d |  | baseline start 2026-04-14 → 2026-04-02; baseline finish 2026-04-24 → 2026-05-15 |
| 3535 | DIP Promoted to Production | 2026-04-16 A | 2026-04-22 A |  | 0% → 100% | 436d → none |  |  |
| 3537 | MDD & ISD Publish | 2026-04-17 → 2026-05-07 (+20d) | 2026-04-17 → 2026-05-07 (+20d) |  |  | 434d → 420d |  | constraint start no earlier than 2026-04-17 → start no earlier than 2026-05-07; baseline start 2026-04-17 → 2026-05-07; baseline finish 2026-04-24 → 2026-05-07 |
| 3538 | MDD & ISD Go-Live | 2026-04-24 → 2026-05-14 (+20d) | 2026-04-24 → 2026-05-14 (+20d) |  |  | 434d → 420d |  | constraint start no earlier than 2026-04-24 → start no earlier than 2026-05-14; baseline start 2026-04-24 → 2026-05-14; baseline finish 2026-04-24 → 2026-05-14 |
| 3539 | Wave 1 - Service Activation Implementation Complete (M) | 2026-04-24 → 2026-05-15 (+21d) | 2026-04-24 → 2026-05-15 (+21d) |  |  | 434d → 420d |  | constraint finish no earlier than 2025-09-05 → start no earlier than 2026-05-15; baseline start 2026-04-24 → 2026-05-15; baseline finish 2026-04-24 → 2026-05-15 |
| 3540 | Secondary Publish ISD |  |  |  |  |  |  | was named Seondary Publish ISD |
| 3702 | STEG - April |  |  |  |  | 409d → 410d | Prepare April STEG Monitoring Report → none |  |

## Version 28 (data date 2026-05-27, saved 2026-05-28, file MHHS-DEL1139 - MHHS Plan v6.50.mpp)

Last finish stays 2027-12-23. Complete tasks 2752 → 2792.

Added:

| ID | Task | Duration | Start | Finish | Predecessors | Constraint |
| --- | --- | --- | --- | --- | --- | --- |
| 2382 | [OP] – Trading Dispute Tab for Legacy File | 20d | 2026-06-10 | 2026-07-07 | 2328 |  |
| 2383 | Trading Dispute CR | 20d | 2026-06-10 | 2026-07-07 | 2328 |  |
| 2402 | MDS defaulting invalid consumption | 50d | 2026-04-29 A | 2026-07-07 | 2325 |  |
| 2403 | VAS – Introduce Pre-Runs (analysis) | 30d | 2026-04-29 A | 2026-06-09 | 2325 |  |
| 2404 | E2E Settlement Run Automated Test Suite – Add 7 JSON reports to comparison process | 50d | 2026-04-29 A | 2026-07-07 | 2325 |  |
| 2415 | LLF Validation Messages Improvement | 70d | 2026-04-01 A | 2026-07-07 | 2323 |  |
| 2416 | LLF Submissions Improvement | 40d | 2026-06-10 | 2026-08-04 | 2328 |  |
| 3540 | Market Entry to confirm PP's Effective from Date | 1d | 2026-04-02 A | 2026-04-02 A |  | start no earlier than 2026-04-02 |
| 3563 | PP to agree Effective from Date 40WD ahead of target PAB | 1d | 2026-03-27 A | 2026-03-27 A |  | start no earlier than 2026-04-02 |
| 3564 | Market Entry to confirm PP's Effective from Date | 1d | 2026-05-13 A | 2026-05-13 A |  |  |
| 3568 | ISD Publish | 1d | 2026-06-01 | 2026-06-01 | 3565 | start no earlier than 2026-06-01 |
| 3569 | ISD Go-Live | 0d | 2026-06-08 | 2026-06-08 | 3568FS+5d | start no earlier than 2026-06-05 |
| 3603 | PP to agree Effective from Date 40WD ahead of target PAB | 0d | 2026-04-16 A | 2026-04-16 A |  | start no earlier than 2026-04-24 |
| 3604 | PP to submit MDD Change Request | 5d | 2026-04-16 A | 2026-04-22 A |  | start no earlier than 2026-04-24 |
| 3611 | MP5 - Service Activation Implementation Complete (M) | 0d | 2026-06-23 | 2026-06-23 |  | start no earlier than 2026-06-23 |
| 3617 | PP to agree Effective from Date 40WD ahead of target PAB | 1d | 2026-04-24 A | 2026-04-24 A |  | start no earlier than 2026-04-24 |
| 3622 | ISD Publish | 1d | 2026-06-29 | 2026-06-29 | 3621SS | start no earlier than 2026-06-29 |
| 3623 | ISD Go-Live | 0d | 2026-07-06 | 2026-07-06 | 3622FS+5d | start no earlier than 2026-07-06 |
| 3628 | **Migration Pathway 7 (MP7)** | 48d | 2026-05-21 A | 2026-07-28 |  |  |
| 3629 | **MP7 - Service Activation Implementation** | 48d | 2026-05-21 A | 2026-07-28 |  |  |
| 3630 | PP to agree Effective from Date 40WD ahead of target PAB | 1d | 2026-05-21 A | 2026-05-21 A |  | start no earlier than 2026-05-21 |
| 3631 | PP to submit MDD Change Request | 5d | 2026-05-21 A | 2026-05-27 A |  | start no earlier than 2026-05-21 |
| 3633 | PP Qualified by Code Bodies | 0d | 2026-07-15 | 2026-07-15 | 2883 | start no earlier than 2026-07-15 |
| 3634 | DIP Promoted to Production | 5d | 2026-07-16 | 2026-07-22 | 3633 | start no earlier than 2026-07-16 |
| 3635 | Create M16 in Customer Solution | 1d | 2026-07-16 | 2026-07-16 | 3633 | start no earlier than 2026-07-16 |
| 3638 | MP7 - Service Activation Implementation Complete (M) | 0d | 2026-07-28 | 2026-07-28 | 3636 | start no earlier than 2026-07-28 |
| 3639 | **MP7 - Service Activation Implementation MDD** | 2d | 2026-07-16 | 2026-07-17 |  |  |
| 3640 | MDD Final Circular Completed | 0d | 2026-07-17 | 2026-07-17 |  | start no earlier than 2026-07-17 |
| 3641 | MDD Manual Update | 2d | 2026-07-16 | 2026-07-17 |  | start no earlier than 2026-07-16 |
| 3642 | **Migration Pathway 8 (MP8)** | 48d | 2026-06-04 | 2026-08-11 |  |  |
| 3643 | **MP8 - Service Activation Implementation** | 48d | 2026-06-04 | 2026-08-11 |  |  |
| 3644 | PP to agree Effective from Date 40WD ahead of target PAB | 1d | 2026-06-04 | 2026-06-04 |  | start no earlier than 2026-06-04 |
| 3646 | PP Qualified by Code Bodies | 0d | 2026-07-30 | 2026-07-30 | 2883 | start no earlier than 2026-07-30 |
| 3647 | DIP Promoted to Production | 5d | 2026-07-31 | 2026-08-06 | 3646 | start no earlier than 2026-07-31 |
| 3648 | Create M16 in Customer Solution | 1d | 2026-07-31 | 2026-07-31 | 3646 | start no earlier than 2026-07-31 |
| 3649 | ISD Publish | 1d | 2026-08-03 | 2026-08-03 | 3648SS | start no earlier than 2026-08-03 |
| 3650 | ISD Go-Live | 0d | 2026-08-10 | 2026-08-10 | 3649FS+5d |  |
| 3651 | MP8 - Service Activation Implementation Complete (M) | 0d | 2026-08-11 | 2026-08-11 | 3649 | start no earlier than 2026-08-11 |
| 3652 | **Migration Pathway 9 (MP9)** | 48d | 2026-06-18 | 2026-08-25 |  |  |
| 3653 | **MP9 - Service Activation Implementation** | 48d | 2026-06-18 | 2026-08-25 |  |  |
| 3654 | PP to agree Effective from Date 40WD ahead of target PAB | 1d | 2026-06-18 | 2026-06-18 |  | start no earlier than 2026-06-18 |
| 3655 | PP to submit MDD Change Request | 5d | 2026-06-18 | 2026-06-24 |  | start no earlier than 2026-06-18 |
| 3656 | Market Entry to obtain Effective from Date from PP | 1d | 2026-07-29 | 2026-07-29 |  | start no earlier than 2026-07-29 |
| 3657 | PP Qualified by Code Bodies | 0d | 2026-08-12 | 2026-08-12 | 2883 | start no earlier than 2026-08-12 |
| 3658 | DIP Promoted to Production | 5d | 2026-08-13 | 2026-08-19 | 3657 | start no earlier than 2026-08-13 |
| 3659 | Create M16 in Customer Solution | 1d | 2026-08-13 | 2026-08-13 | 3657 | start no earlier than 2026-08-13 |
| 3662 | MP9 - Service Activation Implementation Complete (M) | 0d | 2026-08-25 | 2026-08-25 | 3660 | start no earlier than 2026-08-25 |
| 3663 | **MP9 - Service Activation Implementation MDD** | 2d | 2026-08-13 | 2026-08-14 |  |  |
| 3664 | MDD Final Circular Completed | 0d | 2026-08-14 | 2026-08-14 |  | start no earlier than 2026-08-14 |
| 3665 | MDD Manual Update | 2d | 2026-08-13 | 2026-08-14 |  | start no earlier than 2026-08-13 |
| 3666 | **Migration Pathway 10 (MP10)** | 48d | 2026-07-03 | 2026-09-08 |  |  |
| 3667 | **MP10 - Service Activation Implementation** | 48d | 2026-07-03 | 2026-09-08 |  |  |
| 3668 | PP to agree Effective from Date 40WD ahead of target PAB | 1d | 2026-07-03 | 2026-07-03 |  | start no earlier than 2026-07-03 |
| 3669 | Market Entry to obtain Effective from Date from PP | 1d | 2026-08-13 | 2026-08-13 |  | start no earlier than 2026-08-13 |
| 3670 | PP Qualified by Code Bodies | 0d | 2026-08-27 | 2026-08-27 | 2883 | start no earlier than 2026-08-27 |
| 3671 | DIP Promoted to Production | 5d | 2026-08-28 | 2026-09-03 | 3670 | start no earlier than 2026-08-28 |
| 3672 | Create M16 in Customer Solution | 1d | 2026-08-28 | 2026-08-28 | 3670 | start no earlier than 2026-08-28 |
| 3673 | ISD Publish | 1d | 2026-09-01 | 2026-09-01 | 3672SS | start no earlier than 2026-09-01 |
| 3674 | ISD Go-Live | 0d | 2026-09-08 | 2026-09-08 | 3673FS+5d | start no earlier than 2026-09-08 |
| 3675 | MP10 - Service Activation Implementation Complete (M) | 0d | 2026-09-09 | 2026-09-09 | 3673 | start no earlier than 2026-09-09 |
| 3676 | **Migration Pathway 11 (MP11)** | 51d | 2026-07-13 | 2026-09-22 |  |  |
| 3677 | **MP11 - Service Activation Implementation** | 51d | 2026-07-13 | 2026-09-22 |  |  |
| 3678 | PP to agree Effective from Date 40WD ahead of target PAB | 1d | 2026-07-13 | 2026-07-13 |  | start no earlier than 2026-07-13 |
| 3679 | PP to submit MDD Change Request | 5d | 2026-07-13 | 2026-07-17 |  | start no earlier than 2026-07-13 |
| 3680 | Market Entry to obtain Effective from Date from PP | 1d | 2026-08-25 | 2026-08-25 |  | start no earlier than 2026-08-25 |
| 3681 | PP Qualified by Code Bodies | 0d | 2026-09-09 | 2026-09-09 | 2883 | start no earlier than 2026-09-09 |
| 3682 | DIP Promoted to Production | 5d | 2026-09-10 | 2026-09-16 | 3681 | start no earlier than 2026-09-10 |
| 3683 | Create M16 in Customer Solution | 1d | 2026-09-10 | 2026-09-10 | 3681 | start no earlier than 2026-09-10 |
| 3684 | MDD & ISD Publish | 1d | 2026-09-14 | 2026-09-14 | 3683SS | start no earlier than 2026-09-14 |
| 3685 | MDD & ISD Go-Live | 0d | 2026-09-21 | 2026-09-21 | 3684FS+5d | start no earlier than 2026-09-21 |
| 3686 | MP11 - Service Activation Implementation Complete (M) | 0d | 2026-09-22 | 2026-09-22 | 3684 | start no earlier than 2026-09-22 |
| 3687 | **MP11 - Service Activation Implementation MDD** | 2d | 2026-08-13 | 2026-08-14 |  |  |
| 3688 | MDD Final Circular Completed | 0d | 2026-09-11 | 2026-09-11 |  | start no earlier than 2026-09-11 |
| 3689 | MDD Manual Update | 2d | 2026-08-13 | 2026-08-14 |  | finish no earlier than 2026-08-14 |
| 3690 | **Migration Pathway 12a (MP12a)** | 49d | 2026-07-29 | 2026-10-06 |  |  |
| 3691 | **MP12a - Service Activation Implementation** | 49d | 2026-07-29 | 2026-10-06 |  |  |
| 3692 | PP to agree Effective from Date 40WD ahead of target PAB | 1d | 2026-07-29 | 2026-07-29 |  | start no earlier than 2026-07-29 |
| 3693 | Market Entry to obtain Effective from Date from PP | 1d | 2026-09-10 | 2026-09-10 |  | start no earlier than 2026-09-10 |
| 3694 | PP Qualified by Code Bodies | 0d | 2026-09-24 | 2026-09-24 | 2883 | start no earlier than 2026-09-23 |
| 3695 | DIP Promoted to Production | 5d | 2026-09-25 | 2026-10-01 | 3694 | finish no earlier than 2026-03-05 |
| 3696 | Create M16 in Customer Solution | 1d | 2026-09-25 | 2026-09-25 | 3694 | start no earlier than 2026-09-25 |
| 3697 | ISD Publish | 1d | 2026-09-28 | 2026-09-28 | 3696SS | start no earlier than 2026-09-28 |
| 3698 | ISD Go-Live | 0d | 2026-10-05 | 2026-10-05 | 3697FS+5d |  |
| 3699 | MP12a - Service Activation Implementation Complete (M) | 0d | 2026-10-06 | 2026-10-06 | 3697 | start no earlier than 2026-10-06 |
| 3700 | **Migration Pathway 12b (MP12b)** | 64d | 2026-07-29 | 2026-10-27 |  |  |
| 3701 | **MP12b - Service Activation Implementation** | 64d | 2026-07-29 | 2026-10-27 |  |  |
| 3702 | PP to agree Effective from Date 40WD ahead of target PAB | 1d | 2026-07-29 | 2026-07-29 |  | start no earlier than 2026-07-29 |
| 3703 | PP to submit MDD Change Request | 5d | 2026-07-29 | 2026-08-04 |  | start no earlier than 2026-07-29 |
| 3704 | Market Entry to obtain Effective from Date from PP | 1d | 2026-09-10 | 2026-09-10 |  | start no earlier than 2026-09-10 |
| 3705 | PP Qualified by Code Bodies | 0d | 2026-09-24 | 2026-09-24 | 2883 | start no earlier than 2026-09-23 |
| 3706 | DIP Promoted to Production | 5d | 2026-09-25 | 2026-10-01 | 3705 | finish no earlier than 2026-03-05 |
| 3707 | Create M16 in Customer Solution | 1d | 2026-09-25 | 2026-09-25 | 3705 | start no earlier than 2026-09-25 |
| 3708 | MDD & ISD Publish | 1d | 2026-10-19 | 2026-10-19 | 3707SS | start no earlier than 2026-10-19 |
| 3709 | MDD & ISD Go-Live | 0d | 2026-10-26 | 2026-10-26 | 3708FS+5d | start no earlier than 2026-10-26 |
| 3710 | MP12a - Service Activation Implementation Complete (M) | 0d | 2026-10-27 | 2026-10-27 | 3708 | start no earlier than 2026-10-27 |
| 3711 | **MP12b - Service Activation Implementation MDD** | 2d | 2026-10-15 | 2026-10-16 |  |  |
| 3712 | MDD Final Circular Completed | 0d | 2026-10-16 | 2026-10-16 |  | start no earlier than 2026-10-16 |
| 3713 | MDD Manual Update | 2d | 2026-10-15 | 2026-10-16 |  | start no earlier than 2026-10-15 |
| 3761 | STEG 3 | 0d | 2026-06-03 | 2026-06-03 |  | start no earlier than 2026-06-03 |
| 3763 | STEG 5 | 0d | 2026-06-24 | 2026-06-24 |  | start no earlier than 2026-06-24 |
| 3765 | STEG 7 | 0d | 2026-07-22 | 2026-07-22 |  | start no earlier than 2026-07-22 |
| 3767 | STEG 9 | 0d | 2026-08-19 | 2026-08-19 |  | start no earlier than 2026-08-19 |
| 3769 | STEG 11 | 0d | 2026-09-16 | 2026-09-16 |  | start no earlier than 2026-09-16 |
| 3770 | STEG 12 | 0d | 2026-09-30 | 2026-09-30 |  | start no earlier than 2026-09-30 |
| 3772 | STEG 14 | 0d | 2026-10-28 | 2026-10-28 |  | start no earlier than 2026-10-28 |
| 3774 | STEG 16 | 0d | 2026-11-25 | 2026-11-25 |  | start no earlier than 2026-11-25 |
| 3776 | STEG 18 | 0d | 2026-12-23 | 2026-12-23 |  | start no earlier than 2026-12-23 |
| 3778 | STEG 20 | 0d | 2027-01-20 | 2027-01-20 |  | start no earlier than 2027-01-20 |
| 3780 | STEG 22 | 0d | 2027-02-17 | 2027-02-17 |  | start no earlier than 2027-02-17 |
| 3782 | STEG 24 | 0d | 2027-03-17 | 2027-03-17 |  | start no earlier than 2027-03-17 |
| 3784 | STEG 26 | 0d | 2027-04-14 | 2027-04-14 |  | start no earlier than 2027-04-14 |
| 3785 | STEG 27 | 0d | 2027-04-28 | 2027-04-28 |  | start no earlier than 2027-04-28 |

Removed: 3540 Secondary Publish ISD; 3541 Secondary Go Live ISD; 3606 Wave 3 - Service Activation Hypercare; 3607 Service& Process Monitoring; 3608 Daily Reporting; 3609 Issue Management; 3610 SA Hypercare Close Down Activities; 3611 Handover to MHHSP; 3612 Wave 3 Service Activation Hypercare Complete (M); 3613 Wave 3 - Service Activation Retro & Go/No Go; 3614 Review; 3615 Lessons Learned; 3616 Wave 4 - Service Activation Readiness Review Against Entry/Exit Criteria; 3618 Wave 4 - Service Activation Preparation Tasks; 3619 Review Entry/Exit Criteria & Lessons Learned; 3620 Identify Resources; 3621 Confirmation from Qualification of Wave Participants Complete; 3622 Review Handover from Wave 3; 3623 Agree & Understand Support Model; 3624 Confirm Training complete; 3625 Engagement / Communications with Participants; 3626 Internal Communications; 3627 Agree Content for Livewire; 3628 Publish Content for Livewire; 3629 Validate User Access; 3630 Target Systems and Environments Ready; 3631 Provide LWIs; 3632 Business Readiness Governance Approval; 3633 Wave 4 - Service Activation Preparation Tasks Completed; 3645 Wave 4 - Service Activation Hypercare; 3646 Service& Process Monitoring; 3647 Daily Reporting; 3648 Issue Management; 3649 SA Hypercare Close Down Activities; 3650 Handover to MHHSP; 3651 Wave 4 - Service Activation Hypercare Complete (M); 3652 Service Activation Transition Completion; 3653 Lessons Learnt Review; 3654 Document and circulate Lessons Learnt; 3655 Handover to Elexon; 3656 Service Activation Transition Completed

Changed:

| ID | Task | Start | Finish | Duration | Complete | Total float | Other |
| --- | --- | --- | --- | --- | --- | --- | --- |
| 3 | **PROGRAMME MANAGEMENT** |  |  |  | 84% → 85% |  |  |
| 4 | **Programme Management** |  |  |  | 84% → 85% |  |  |
| 5 | Sprint-based prioritisation planning and execution |  |  |  | 84% → 85% |  |  |
| 6 | Programme governance secretariat |  |  |  | 84% → 85% |  |  |
| 7 | RAID management and reporting |  |  |  | 84% → 85% |  |  |
| 8 | Tracking against Programme outcomes and KPIs |  |  |  | 84% → 85% |  |  |
| 9 | Change control and reporting |  |  |  | 84% → 85% |  |  |
| 10 | Ongoing identification of lessons learned relating to the PMO and implementation of improvements |  |  |  | 84% → 85% |  |  |
| 11 | **Programme Internal Assurance Reviews** |  |  |  | 84% → 85% |  |  |
| 12 | Programme Internal Assurance Reviews |  |  |  | 84% → 85% |  |  |
| 13 | **Engagement with PPs** |  |  |  | 84% → 85% |  |  |
| 14 | Ongoing PP liaison activities |  |  |  | 84% → 85% |  |  |
| 15 | Milestone and Control Point objective setting |  |  |  | 84% → 85% |  |  |
| 16 | Reporting |  |  |  | 84% → 85% |  |  |
| 17 | **PP Engagement Events** |  |  |  | 84% → 85% |  |  |
| 18 | Bilateral meetings |  |  |  | 84% → 85% |  |  |
| 19 | Monthly webinars |  |  |  | 84% → 85% |  |  |
| 20 | Open days |  |  |  | 84% → 85% |  |  |
| 21 | **PP Communications** |  |  |  | 84% → 85% |  |  |
| 22 | The Clock updates (weekly) |  |  |  | 84% → 85% |  |  |
| 23 | Maintain and update content on public-facing Portal (and ongoing feedback reviews to identify and implement Portal improvements) |  |  |  | 84% → 85% |  |  |
| 24 | **Code Change Support / Other Programme Alignment** |  |  |  | 84% → 85% |  |  |
| 25 | Support DCC/BEIS on SEC change |  |  |  | 84% → 85% |  |  |
| 26 | Support on Smart Meters Act changes |  |  |  | 84% → 85% |  |  |
| 27 | Support DCC/RECCo on CSS change |  |  |  | 84% → 85% |  |  |
| 28 | Support Elexon on BSC change |  |  |  | 84% → 85% |  |  |
| 29 | Support code change inside & outside CCIAG |  |  |  | 84% → 85% |  |  |
| 30 | Support code change inside & outside CCAG |  |  |  | 84% → 85% |  |  |
| 46 | **Design Baseline & Enduring PP Support** |  |  |  | 92% → 93% |  |  |
| 56 | **Establish Design Change Management Processes** |  |  |  | 83% → 84% |  |  |
| 61 | Maintain E2E MHHS Design (post-M5 design change management processes operational) |  |  |  | 82% → 83% |  |  |
| 1471 | **ADO Changes - Review Stage** |  |  | 19d? → 19d |  |  |  |
| 1472 | Review implementation with SI LDP leads |  |  | 1d? → 1d |  |  |  |
| 1473 | Review implementation with SRO |  |  | 1d? → 1d |  |  |  |
| 1475 | SRO Review - ADO User Guide, Training Materials |  |  | 1d? → 1d |  |  |  |
| 1476 | LDP Review - Config doc |  |  | 1d? → 1d |  |  |  |
| 1477 | SRO Review - Config doc |  |  | 1d? → 1d |  |  |  |
| 1478 | SRO Sign-off of all changes |  |  | 1d? → 1d |  |  |  |
| 1480 | Final task rollout |  |  | 1d? → 1d |  |  |  |
| 1481 | ADO Training Drop-in Session ahead of Cycle 3 |  |  | 1d? → 1d |  |  |  |
| 1724 | **Onboarding and Test Data (Sandbox UIT)** |  |  |  | 81% → 83% |  |  |
| 1726 | Supplier & Agent Onboarding and Test Data Creation and Support |  |  |  | 68% → 72% |  |  |
| 1727 | **Sandbox Execution** |  |  |  | 83% → 85% |  |  |
| 1737 | **Sandbox Testing Execution (UIT) - Supplier & Agent Participants** |  |  |  | 68% → 72% |  |  |
| 1740 | Sandbox Testing Execution (UIT) - Supplier & Agent Participants |  |  |  | 68% → 72% |  |  |
| 2309 | **ELEXON / HELIX M10 - M16** |  |  |  | 81% → 76% |  |  |
| 2310 | **Solution Build Sprints** |  |  |  | 79% → 84% |  |  |
| 2326 | 26.9 |  | 2026-05-12 A |  | 60% → 100% | 382d → none |  |
| 2327 | 26.10 | 2026-05-13 A |  |  | 0% → 60% | 382d → 362d |  |
| 2331 | **Release management deployment schedule** |  |  |  | 84% → 77% |  |  |
| 2345 | 26.9.0 | 2026-05-14 A | 2026-05-14 A |  | 0% → 100% | 420d → none |  |
| 2351 | **Work Package Development** |  |  |  | 84% → 77% |  |  |
| 2352 | **DAH** |  |  |  | 80% → 85% |  |  |
| 2370 | Tech debt DA3 test suite improvements |  |  |  | 42% → 69% |  |  |
| 2372 | Business Validations |  |  |  | 48% → 69% |  |  |
| 2374 | Tech Debt DA2: Azure cost reduction, optimising data storage and processing |  |  |  | 33% → 60% |  |  |
| 2381 | Smart Data Repository |  |  |  | 65% → 90% |  |  |
| 2384 | **WP2 (LSS/MDS/VAS/OP)** |  | 2026-05-12 → 2026-07-07 (+56d) | 170d → 210d | 95% → 78% | 422d → 382d |  |
| 2399 | OP: Edit configuration parameters from UI |  | 2026-05-12 A |  | 90% → 100% | 422d → none |  |
| 2401 | Make VAS run during transition mode without legacy data |  | 2026-05-12 → 2026-05-26 (+14d) | 20d → 30d | 30% → 20% | 422d → 412d |  |
| 2405 | **ISD** |  | 2026-06-23 → 2026-08-04 (+42d) | 190d → 220d | 84% → 65% | 392d → 362d |  |
| 2406 | **ISD Asure** |  | 2026-05-07 → 2026-08-04 (+89d) | 127d → 190d | 92% → 71% | 425d → 362d |  |
| 2412 | ISD Refresh |  | 2026-05-07 → 2026-06-04 (+28d) | 27d → 47d | 19% → 11% | 425d → 405d |  |
| 2417 | **ISD Salesforce** |  | 2026-06-23 → 2026-08-04 (+42d) | 190d → 220d | 76% → 59% | 392d → 362d |  |
| 2422 | ISD Refresh |  | 2026-05-07 → 2026-06-04 (+28d) | 27d → 47d | 22% → 13% | 425d → 405d | baseline finish 2026-04-28 → 2026-05-07 |
| 2423 | Catalogue Publish Improvement Development |  | 2026-05-26 → 2026-07-07 (+42d) | 40d → 70d | 65% → 37% | 412d → 382d | baseline finish 2026-05-26 → 2026-07-07 |
| 2424 | Manage ISD Process Improvement Development |  | 2026-06-23 → 2026-08-04 (+42d) | 60d → 90d | 43% → 29% | 392d → 362d | baseline finish 2026-06-23 → 2026-08-04 |
| 2440 | **SAT M16 Test Case Execution** |  |  |  |  |  | baseline start 2026-07-01 → 2026-04-01; baseline finish 2026-07-30 → 2026-06-30 |
| 2446 | **S & A QUALIFICATION** |  |  |  | 95% → 97% |  |  |
| 2558 | **MHHS Qualification - Qualification Waves** |  |  |  | 93% → 96% |  |  |

| ID | Task | Start | Finish | Duration | Complete | Total float | Predecessors | Other |
| --- | --- | --- | --- | --- | --- | --- | --- | --- |
| 2804 | Qualification Wave 2 QT Projected Execution End |  |  | 0d → 1d |  |  |  |  |
| 2805 | **Qualification Wave 2 Exit** |  |  |  | 97% → 99% |  |  |  |
| 2811 | Completion of Code Bodies review of Final QAD |  | 2026-04-13 A |  | 89% → 100% | 404d → none |  |  |
| 2812 | QAD Sign Off deadline | 2026-04-20 A | 2026-04-20 A |  | 0% → 100% | 404d → none |  |  |
| 2815 | **Qualification Wave 3** |  |  |  | 69% → 91% |  |  |  |
| 2816 | **Qualification Wave 3 QAD Prep** |  |  |  | 93% → 97% |  |  |  |
| 2821 | Code Bodies review of Wave 3 Participants' Initial QAD |  |  |  | 77% → 90% |  |  |  |
| 2823 | **Qualification Wave 3 Test Prep** |  | 2025-12-12 A |  | 95% → 100% | 529d → none |  |  |
| 2834 | Review of Participants' PIT Test Completion Report |  | 2025-12-12 A |  | 80% → 100% | 529d → none |  |  |
| 2836 | **Qualification Wave 3 QT Execution** |  |  |  | 99% → 100% |  |  |  |
| 2842 | Qualification Wave 3 Projected Execution End | 2026-05-08 A | 2026-05-08 A |  | 0% → 100% | 359d → none |  |  |
| 2843 | **Qualification Wave 3 Exit** |  |  |  | 8% → 74% |  |  |  |
| 2844 | Assurance on PP Test Completion Report | 2026-05-11 A | 2026-05-22 A |  | 0% → 100% | 359d → none |  |  |
| 2846 | Qualification Wave 3 Participants submit their Final QAD |  |  |  | 10% → 87% | 359d → 414d |  |  |
| 2847 | 80% of M14 Critical Qualification Wave 3 Participants have submitted their Final QAD | 2026-05-22 A | 2026-05-22 A |  | 0% → 100% | 359d → none |  |  |
| 2853 | **Qualification Wave 4** |  |  |  | 64% → 67% |  |  |  |
| 2854 | **Qualification Wave 4 QAD Prep** |  |  |  | 79% → 82% |  |  |  |
| 2858 | Code Bodies review of Wave 4 Participants' Initial QAD |  |  |  | 33% → 42% |  |  |  |
| 2870 | **Qualification Wave 4 QT Execution** |  |  |  | 92% → 98% | 235d → 0.4d |  |  |
| 2874 | Qualification Wave 4 QT Execution Window |  |  |  | 92% → 98% | 235d → 0.4d |  |  |
| 2876 | **Qualification Wave 4 Exit** |  |  |  | 2% → 4% |  |  |  |
| 2879 | Qualification Wave 4 Participants submit their Final QAD |  |  |  | 2% → 5% | 235d → 0.4d |  |  |
| 2881 | Completion of Code Bodies review of Final QAD | 2026-07-27 A |  |  | 0% → 2% |  |  |  |
| 2916 | PAB2026/08 | 2026-05-13 A | 2026-05-13 A |  | 0% → 100% | 421d → none |  |  |
| 3082 | **MIGRATION** |  |  |  | 94% → 95% |  |  |  |
| 3083 | **Regulatory Governance** |  |  |  | 98% → 99% |  |  |  |
| 3086 | Ofgem Incentives Approval |  | 2026-04-30 A |  | 97% → 100% | 430d → none |  |  |
| 3087 | Incentives Implementation |  |  |  |  |  |  | constraint start no earlier than 2026-03-31 → none; baseline start 2026-04-30 → 2026-06-25; baseline finish 2026-04-30 → 2026-06-25 |
| 3301 | **Preparation for Cutover to Live** |  |  |  | 68% → 69% |  |  |  |
| 3393 | **Migration Sprints** |  |  |  | 33% → 35% |  |  |  |
| 3414 | **Migration Sprint 2** |  |  |  | 52% → 67% |  |  |  |
| 3421 | Sprint Execution |  |  |  | 57% → 77% |  |  |  |
| 3422 | Non-SIT Participants Migration Start | 2026-05-15 A | 2026-05-15 A |  | 0% → 100% | 419d → none |  |  |
| 3425 | **Migration Sprint 3** | 2026-05-06 A |  |  | 0% → 10% |  |  |  |
| 3426 | Sprint 3 Planning start date | 2026-05-06 A | 2026-05-13 A |  | 0% → 100% | 352d → none |  |  |
| 3427 | Issue Envelope | 2026-05-13 A | 2026-05-13 A |  | 0% → 100% | 352d → none |  |  |
| 3428 | Supplier Submission Deadline | 2026-05-20 A | 2026-05-20 A |  | 0% → 100% | 352d → none |  |  |
| 3429 | Baseline Schedule Publication | 2026-05-27 A | 2026-05-27 A |  | 0% → 100% | 352d → none |  |  |
| 3430 | Migration Sprint 3 Schedule Baselined | 2026-05-27 A | 2026-05-27 A |  | 0% → 100% | 352d → none |  |  |
| 3507 | **BUSINESS & OPERATIONAL READINESS** |  |  | 1344d? → 1344d | 79% → 83% |  |  |  |
| 3508 | **Service Management** |  | 2026-11-14 → 2026-10-27 (-18d) | 1055d? → 1041d | 78% → 86% | 289d → 303d |  |  |
| 3522 | **Migration Pathway (MP1) and Migration Pathway 2 (MP2)** |  | 2026-05-22 A | 39d? → 39d | 19% → 100% | 414d → none |  | was named Wave 1; baseline start 2022-10-31 → 2026-03-31; baseline finish 2026-05-12 → 2026-05-22 |
| 3523 | **MP1 and MP2 - Service Activation Preparation Tasks** |  |  |  |  |  |  | was named Wave 1 - Service Activation Preparation Tasks |
| 3538 | MP1 and MP2 - Service Activation Preparation Tasks (M) |  |  |  |  |  |  | was named Wave 1 - Service Activation Preparation Tasks (M) |
| 3539 | **MP1 and MP2 - Service Activation Implementation** |  | 2026-05-15 A | 31d? → 31d | 78% → 100% | 420d → none |  | was named Wave 1 - Service Activation Implementation |
| 3544 | MDD & ISD Publish | 2026-05-07 A | 2026-05-07 A |  | 0% → 100% | 420d → none |  |  |
| 3545 | MDD & ISD Go-Live | 2026-05-14 A | 2026-05-14 A |  | 0% → 100% | 420d → none |  |  |
| 3546 | MP1 and MP2 - Service Activation Implementation Complete (M) | 2026-05-15 A | 2026-05-15 A |  | 0% → 100% | 420d → none |  | was named Wave 1 - Service Activation Implementation Complete (M) |
| 3547 | **MP1 and MP2 - Service Activation Implementation MDD** | 2026-04-15 A → 2026-05-06 (+21d) | 2026-04-16 A → 2026-05-07 (+21d) |  |  |  |  | was named Wave 1 - Service Activation Implementation MDD; baseline start 2026-04-17 → 2026-05-06; baseline finish 2026-05-11 → 2026-05-06 |
| 3548 | MDD Final Circular Completed | 2026-04-15 A → 2026-05-06 A (+21d) | 2026-04-15 A → 2026-05-06 A (+21d) |  |  |  |  | baseline start 2026-04-15 → 2026-05-06; baseline finish 2026-04-15 → 2026-05-06 |
| 3549 | MDD Manual Update | 2026-04-15 A → 2026-05-05 A (+20d) | 2026-04-16 A → 2026-05-06 A (+20d) |  |  |  |  | baseline start 2026-04-15 → 2026-05-05; baseline finish 2026-04-16 → 2026-05-06 |
| 3550 | **Wave 1 - Service Activation Hypercare** | 2026-04-16 A | 2026-05-12 A |  | 0% → 100% | 422d → none |  |  |
| 3551 | Service& Process Monitoring | 2026-04-16 A | 2026-05-12 A |  | 0% → 100% | 422d → none |  |  |
| 3552 | Daily Reporting | 2026-04-16 A | 2026-05-12 A |  | 0% → 100% | 422d → none |  |  |
| 3553 | Issue Management | 2026-04-16 A | 2026-05-12 A |  | 0% → 100% | 422d → none |  |  |
| 3554 | SA Hypercare Close Down Activities | 2026-05-11 A | 2026-05-12 A |  | 0% → 100% | 422d → none |  |  |
| 3555 | Handover to MHHSP | 2026-05-11 A | 2026-05-12 A |  | 0% → 100% | 422d → none |  |  |
| 3556 | Non-SIT LDSO Service Activation Hypercare Complete (M) | 2026-05-12 A | 2026-05-12 A |  | 0% → 100% | 422d → none |  |  |
| 3557 | **Wave 1 - Service Activation Retro & Go/No Go** | 2026-05-12 A | 2026-05-22 A |  | 0% → 100% | 414d → none |  |  |
| 3558 | Review | 2026-05-12 A | 2026-05-12 A |  | 0% → 100% | 423d → none |  |  |
| 3559 | Lessons Learned | 2026-05-12 A | 2026-05-18 A |  | 0% → 100% | 418d → none |  |  |
| 3560 | Wave 2 - Service Activation Readiness Review Against Entry/Exit Criteria | 2026-05-18 A | 2026-05-22 A |  | 0% → 100% | 414d → none |  |  |
| 3561 | **Migration Pathway 3 (MP3) and Migration Pathway 4 (MP4)** | 2022-10-31 → 2026-03-27 A (+1243d) |  | 950d → 61d | 0% → 4% | 0d → 394d |  | was named Wave 2; baseline start 2022-10-31 → 2026-03-27; baseline finish 2026-06-08 → 2026-06-19 |
| 3562 | **MP3 and MP4 - Service Activation Implementation** | 2026-05-15 → 2026-03-27 A (-49d) | 2026-06-08 → 2026-06-09 (+1d) | 16d → 52d | 0% → 22% | 404d → 403d |  | was named Wave 2 - Service Activation Implementation |
| 3565 | PP is Qualified by Code Bodies |  |  |  |  |  |  | constraint start no earlier than 2026-05-27 → none |
| 3570 | MP3 and MP4 - Service Activation Implementation Complete (M) | 2026-06-08 → 2026-06-09 (+1d) | 2026-06-08 → 2026-06-09 (+1d) |  |  | 404d → 403d | 3636 → none | was named Wave 2 - Service Activation Implementation Complete (M); constraint start no earlier than 2026-06-08 → start no earlier than 2026-06-09; baseline start 2026-06-08 → 2026-06-09; baseline finish 2026-06-08 → 2026-06-09 |
| 3571 | **Wave 2 - Service Activation Implementation MDD** | 2022-10-31 → 2026-06-08 (+1316d) | 2022-11-24 → 2026-06-15 (+1299d) | 19d → 6d |  | none → 398d |  |  |
| 3572 | MDD Final Circular Completed | 2026-05-28 → 2026-06-08 (+11d) | 2026-05-28 → 2026-06-08 (+11d) |  |  | 411d → 404d |  | constraint start no earlier than 2026-05-28 → start no earlier than 2026-06-08; baseline start 2026-05-28 → 2026-06-08; baseline finish 2026-05-28 → 2026-06-08 |
| 3585 | **Migration Pathway 5 (MP5)** | 2022-10-31 → 2026-07-13 (+1351d) | 2026-08-14 → 2026-07-24 (-21d) | 990d? → 10d | 0% → 24% | 0d → none |  | was named Wave 3; baseline start 2022-10-31 → 2026-07-13; baseline finish 2026-08-21 → 2026-07-24 |
| 3586 | **MP5 - Service Activation Preparation Tasks** |  |  |  |  | 369d → none |  | was named Wave 3 - Service Activation Preparation Tasks |

| ID | Task | Start | Finish | Duration | Complete | Total float | Predecessors | Other |
| --- | --- | --- | --- | --- | --- | --- | --- | --- |
| 3590 | Review Handover from MP3 and MP4 |  |  |  |  |  |  | was named Review Handover from Wave 2 |
| 3601 | MP5 - Service Activation Preparation Tasks Completed |  |  |  |  |  |  | was named Wave 3 - Service Activation Preparation Tasks Completed |
| 3602 | **MP5 - Service Activation Implementation** | 2022-10-31 → 2026-04-16 A (+1263d) | 2022-11-21 → 2026-06-23 (+1310d) | 16d → 49d | 0% → 46% |  |  | was named Wave 3 - Service Activation Implementation; baseline start 2022-10-31 → 2026-04-16; baseline finish 2022-11-21 → 2026-06-23 |
| 3605 | Market Entry to obtain Effective from Date from PP | 2026-07-17 → 2026-05-27 A (-51d) | 2026-07-17 → 2026-05-27 A (-51d) |  | 0% → 100% | 374d → none |  | constraint start no earlier than 2026-07-17 → start no earlier than 2026-05-27; baseline start 2026-07-17 → 2026-05-27; baseline finish 2026-07-17 → 2026-05-27 |
| 3606 | PP Qualified by Code Bodies | 2026-07-30 → 2026-06-10 (-50d) | 2026-07-30 → 2026-06-10 (-50d) |  |  | 359d → 396d | 2852 → none | constraint start no earlier than 2026-07-29 → start no earlier than 2026-06-10; baseline start 2026-07-30 → 2026-06-10; baseline finish 2026-07-30 → 2026-06-10 |
| 3607 | DIP Promoted to Production | 2026-07-31 → 2026-06-11 (-50d) | 2026-08-06 → 2026-06-17 (-50d) |  |  | 360d → 396d |  | constraint finish no earlier than 2025-12-30 → start no earlier than 2026-06-11; baseline start 2026-07-31 → 2026-06-11; baseline finish 2026-08-06 → 2026-06-17 |
| 3608 | Create M16 in Customer Solution | 2026-07-31 → 2026-06-11 (-50d) | 2026-07-31 → 2026-06-11 (-50d) |  |  | 364d → 400d |  | constraint start no earlier than 2026-07-31 → start no earlier than 2026-06-11; baseline start 2026-07-31 → 2026-06-11; baseline finish 2026-07-31 → 2026-06-11 |
| 3609 | MDD & ISD Publish | 2026-07-31 → 2026-06-15 (-46d) | 2026-07-31 → 2026-06-15 (-46d) |  |  | 359d → 393d |  | constraint finish no earlier than 2025-12-30 → start no earlier than 2026-06-15; baseline start 2026-07-31 → 2026-06-15; baseline finish 2026-07-31 → 2026-06-15 |
| 3610 | MDD & ISD Go-Live | 2026-08-07 → 2026-06-22 (-46d) | 2026-08-07 → 2026-06-22 (-46d) |  |  | 359d → 393d |  | constraint none → start no earlier than 2026-06-22; baseline start 2026-08-07 → 2026-06-22; baseline finish 2026-08-07 → 2026-06-22 |
| 3612 | **MP5 - Service Activation Implementation MDD** | 2026-07-30 → 2026-06-12 (-48d) | 2026-08-14 → 2026-06-12 (-63d) | 12d? → 1d |  | 354d → none |  | was named Wave 3 - Service Activation Implementation MDD; baseline start 2026-07-30 → 2026-06-12; baseline finish 2026-08-21 → 2026-06-12 |
| 3613 | MDD Final Circular Completed | 2026-07-30 → 2026-06-12 (-48d) | 2026-07-30 → 2026-06-12 (-48d) | 1d? → 0d |  | 365d → 400d |  | constraint start no earlier than 2026-07-30 → start no earlier than 2026-06-12; baseline start 2026-07-30 → 2026-06-12; baseline finish 2026-07-30 → 2026-06-12 |
| 3614 | MDD Manual Update | 2026-08-14 → 2026-06-11 (-64d) | 2026-08-14 → 2026-06-12 (-63d) | 1d? → 2d |  | 354d → 399d |  | constraint start no earlier than 2026-08-14 → start no earlier than 2026-06-11; baseline start 2026-08-14 → 2026-06-11; baseline finish 2026-08-14 → 2026-06-12 |
| 3615 | **Migration Pathway 6 (MP6)** | 2022-10-31 → 2026-04-24 A (+1271d) | 2026-11-14 → 2026-07-07 (-130d) | 1055d? → 53d | 0% → 7% | 0d → none |  | was named Wave 4; baseline start 2022-10-31 → 2026-04-24; baseline finish 2026-10-23 → 2026-07-07 |
| 3616 | **MP6 - Service Activation Implementation** | 2022-10-31 → 2026-04-24 A (+1271d) | 2022-11-21 → 2026-07-07 (+1324d) | 16d → 53d | 0% → 10% |  |  | was named Wave 4 - Service Activation Implementation; baseline start 2022-10-31 → 2026-04-24; baseline finish 2022-11-21 → 2026-07-07 |
| 3618 | Market Entry to obtain Effective from Date from PP | 2026-09-11 → 2026-06-11 (-92d) | 2026-09-11 → 2026-06-11 (-92d) |  |  | 334d → 400d |  | constraint start no earlier than 2026-09-11 → start no earlier than 2026-06-11; baseline start 2026-09-11 → 2026-06-11; baseline finish 2026-09-11 → 2026-06-11 |
| 3619 | PP Qualified by Code Bodies | 2026-09-24 → 2026-06-25 (-91d) | 2026-09-24 → 2026-06-25 (-91d) | 0d → 1d |  | 319d → none | 2883 → none | was named MHHSP Enabled Confirmation; constraint start no earlier than 2026-09-23 → start no earlier than 2026-06-25; baseline start 2026-09-24 → 2026-06-25; baseline finish 2026-09-24 → 2026-06-25 |
| 3620 | DIP Promoted to Production | 2026-09-25 → 2026-06-26 (-91d) | 2026-10-01 → 2026-07-02 (-91d) |  |  | 320d → none |  | constraint finish no earlier than 2026-03-05 → start no earlier than 2026-06-26; baseline start 2026-09-25 → 2026-06-26; baseline finish 2026-10-01 → 2026-07-02 |
| 3621 | Create M16 in Customer Solution | 2026-09-25 → 2026-06-26 (-91d) | 2026-09-25 → 2026-06-26 (-91d) |  |  | 319d → none | 3619 → none | constraint start no earlier than 2026-09-25 → start no earlier than 2026-06-26; baseline start 2026-09-25 → 2026-06-26; baseline finish 2026-09-25 → 2026-06-26 |
| 3624 | MP6 - Service Activation Implementation Complete (M) | 2026-10-05 → 2026-07-07 (-90d) | 2026-10-05 → 2026-07-07 (-90d) |  |  | 319d → none | 3660 → 3622 | was named Wave 4 - Service Activation Implementation Complete (M); constraint start no earlier than 2026-10-05 → start no earlier than 2026-07-07; baseline start 2026-10-05 → 2026-07-07; baseline finish 2026-10-05 → 2026-07-07 |
| 3625 | **MP6 - Service Activation Implementation MDD** |  |  | 17d? → 17d |  |  |  | was named Wave 4 - Service Activation Implementation MDD |
| 3626 | MDD Final Circular Completed |  |  | 1d? → 1d |  |  |  |  |
| 3627 | MDD Manual Update |  |  | 1d? → 1d |  |  |  |  |
| 3632 | Market Entry to obtain Effective from Date from PP | 2026-04-02 A → 2026-07-01 (+90d) | 2026-04-02 A → 2026-07-01 (+90d) |  | 100% → 0% |  |  | constraint start no earlier than 2026-04-02 → start no earlier than 2026-07-01; baseline start 2026-04-02 → 2026-07-01; baseline finish 2026-04-02 → 2026-07-01 |
| 3636 | MDD & ISD Publish | 2026-05-29 → 2026-07-20 (+52d) | 2026-05-29 → 2026-07-20 (+52d) |  |  | 404d → none | 3565 → 3635SS | constraint start no earlier than 2026-05-29 → start no earlier than 2026-07-20; baseline start 2026-05-29 → 2026-07-20; baseline finish 2026-05-29 → 2026-07-20 |
| 3637 | MDD & ISD Go-Live | 2026-06-05 → 2026-07-27 (+52d) | 2026-06-05 → 2026-07-27 (+52d) |  |  | 404d → none |  | baseline start 2026-06-05 → 2026-07-27; baseline finish 2026-06-05 → 2026-07-27 |
| 3645 | Market Entry to obtain Effective from Date from PP | 2026-05-15 → 2026-07-16 (+62d) | 2026-05-15 → 2026-07-16 (+62d) |  |  | 419d → 375d |  | constraint start no earlier than 2026-05-15 → start no earlier than 2026-07-16; baseline start 2026-05-15 → 2026-07-16; baseline finish 2026-05-15 → 2026-07-16 |
| 3660 | MDD & ISD Publish | 2026-09-25 → 2026-08-17 (-39d) | 2026-09-25 → 2026-08-17 (-39d) |  |  | 319d → 348d | 3621SS → 3659SS | constraint finish no earlier than 2026-03-06 → start no earlier than 2026-08-17 |
| 3661 | MDD & ISD Go-Live | 2026-10-02 → 2026-08-24 (-39d) | 2026-10-02 → 2026-08-24 (-39d) |  |  | 319d → 348d |  |  |
| 3730 | **M16: Decision Approach** |  |  | 95d? → 95d |  |  |  |  |
| 3735 | **Consult and Agree with Industry** |  |  | 94d? → 94d |  |  |  |  |
| 3753 | Issue Consultation | 2026-04-29 A | 2026-04-29 A |  | 0% → 100% | 268d → none |  |  |
| 3758 | **M16: Monitoring Period** | 2026-05-22 → 2026-04-15 A (-37d) | 2027-06-14 → 2027-06-16 (+2d) | 277d → 306d |  |  |  | baseline start 2026-05-22 → 2026-04-15; baseline finish 2027-06-14 → 2027-06-16 |
| 3759 | STEG 1 | 2026-05-29 → 2026-04-15 A (-44d) | 2026-05-29 → 2026-04-15 A (-44d) |  | 0% → 100% | 410d → none |  | was named STEG - April; constraint start no earlier than 2026-05-29 → start no earlier than 2026-04-15; baseline start 2026-05-29 → 2026-04-15; baseline finish 2026-05-29 → 2026-04-15 |
| 3760 | STEG 2 | 2026-05-22 → 2026-05-13 A (-9d) | 2026-05-22 → 2026-05-13 A (-9d) |  | 0% → 100% | 415d → none |  | was named STEG - May; constraint start no earlier than 2026-05-22 → start no earlier than 2026-05-13; baseline start 2026-05-22 → 2026-05-13; baseline finish 2026-05-22 → 2026-05-13 |
| 3762 | STEG 4 | 2026-06-15 → 2026-06-10 (-5d) | 2026-06-15 → 2026-06-10 (-5d) |  |  | 399d → 402d |  | was named STEG - Jun; constraint start no earlier than 2026-06-15 → start no earlier than 2026-06-10; baseline start 2026-06-15 → 2026-06-10; baseline finish 2026-06-15 → 2026-06-10 |
| 3764 | STEG 6 | 2026-07-13 → 2026-07-08 (-5d) | 2026-07-13 → 2026-07-08 (-5d) |  |  | 346d → 349d |  | was named STEG - Jul; constraint start no earlier than 2026-07-13 → start no earlier than 2026-07-08; baseline start 2026-07-13 → 2026-07-08; baseline finish 2026-07-13 → 2026-07-08 |
| 3766 | STEG 8 | 2026-08-17 → 2026-08-05 (-12d) | 2026-08-17 → 2026-08-05 (-12d) |  |  | 354d → 362d |  | was named STEG Aug; constraint start no earlier than 2026-08-17 → start no earlier than 2026-08-05; baseline start 2026-08-17 → 2026-08-05; baseline finish 2026-08-17 → 2026-08-05 |
| 3768 | STEG 10 | 2026-09-14 → 2026-09-02 (-12d) | 2026-09-14 → 2026-09-02 (-12d) |  |  | 329d → 337d |  | was named STEG Sep; constraint start no earlier than 2026-09-14 → start no earlier than 2026-09-02; baseline start 2026-09-14 → 2026-09-02; baseline finish 2026-09-14 → 2026-09-02 |
| 3771 | STEG 13 | 2026-10-12 → 2026-10-14 (+2d) | 2026-10-12 → 2026-10-14 (+2d) |  |  | 314d → 312d |  | was named STEG Oct; constraint start no earlier than 2026-10-12 → start no earlier than 2026-10-14; baseline start 2026-10-12 → 2026-10-14; baseline finish 2026-10-12 → 2026-10-14 |
| 3773 | STEG 15 | 2026-11-16 → 2026-11-11 (-5d) | 2026-11-16 → 2026-11-11 (-5d) |  |  | 289d → 292d |  | was named STEG Nov; constraint start no earlier than 2026-11-16 → start no earlier than 2026-11-11; baseline start 2026-11-16 → 2026-11-11; baseline finish 2026-11-16 → 2026-11-11 |
| 3775 | STEG 17 | 2026-12-14 → 2026-12-09 (-5d) | 2026-12-14 → 2026-12-09 (-5d) |  |  | 269d → 272d |  | was named STEG Dec; constraint start no earlier than 2026-12-14 → start no earlier than 2026-12-09; baseline start 2026-12-14 → 2026-12-09; baseline finish 2026-12-14 → 2026-12-09 |
| 3777 | STEG 19 | 2027-01-11 → 2027-01-06 (-5d) | 2027-01-11 → 2027-01-06 (-5d) |  |  | 249d → 252d |  | was named STEG Jan; constraint start no earlier than 2027-01-11 → start no earlier than 2027-01-06; baseline start 2027-01-11 → 2027-01-06; baseline finish 2027-01-11 → 2027-01-06 |
| 3779 | STEG 21 | 2027-02-15 → 2027-02-03 (-12d) | 2027-02-15 → 2027-02-03 (-12d) |  |  | 224d → 232d |  | was named STEG Feb; constraint start no earlier than 2027-02-15 → start no earlier than 2027-02-03; baseline start 2027-02-15 → 2027-02-03; baseline finish 2027-02-15 → 2027-02-03 |
| 3781 | STEG 23 | 2027-03-15 → 2027-03-03 (-12d) | 2027-03-15 → 2027-03-03 (-12d) |  |  | 70d → 207d |  | was named STEG Mar; constraint start no earlier than 2027-03-15 → start no earlier than 2027-03-03; baseline start 2027-03-15 → 2027-03-03; baseline finish 2027-03-15 → 2027-03-03 |
| 3783 | STEG 25 | 2027-04-19 → 2027-03-31 (-19d) | 2027-04-19 → 2027-03-31 (-19d) |  |  | 45d → 192d |  | was named STEG Apr; constraint start no earlier than 2027-04-19 → start no earlier than 2027-03-31; baseline start 2027-04-19 → 2027-03-31; baseline finish 2027-04-19 → 2027-03-31 |
| 3787 | STEG June | 2027-06-14 → 2027-06-16 (+2d) | 2027-06-14 → 2027-06-16 (+2d) |  |  | 5d → 137d |  | was named STEG Jun; constraint start no earlier than 2027-06-14 → start no earlier than 2027-06-16; baseline start 2027-06-14 → 2027-06-16; baseline finish 2027-06-14 → 2027-06-16 |
| 3795 | Readiness Assessment 8 Consultation Period Complete |  |  |  |  |  |  | was named Readiness Assessment Consultation Period Complete |
| 3796 | Readiness Assessment 8 Complete |  |  |  |  |  |  | was named Readiness Assessment Complete |
| 3797 | Assess Readiness Assessment 8 and Plan further enagement activity if required |  |  |  |  |  |  | was named Assess Readines Assessment and Plan further enagement activity if required |
| 3809 | STEG to compare Monitoring report against agreed assessment criteria |  |  |  |  |  | 3781, 3783, 3786, 3787 → none | baseline start 2027-06-14 → 2027-06-16; baseline finish 2027-06-14 → 2027-06-16 |
| 3810 | STEG Issue recommendation to MCAG |  |  |  |  |  |  | baseline start 2027-06-18 → 2027-06-22; baseline finish 2027-06-18 → 2027-06-22 |
| 3811 | MCAG Approve Recommendation - Confirm M16 Date |  |  |  |  |  |  | baseline start 2027-06-18 → 2027-06-22; baseline finish 2027-06-18 → 2027-06-22 |
| 3812 | Decision 3 - SF 7WD |  |  |  |  |  |  | baseline start 2027-06-18 → 2027-06-22; baseline finish 2027-06-18 → 2027-06-22 |
| 3826 | **M16 Approval Window** |  |  |  |  |  |  | baseline start 2027-06-25 → 2027-06-29 |
| 3827 | Panel approval that M16 criteria met |  |  |  |  |  |  | baseline start 2027-06-25 → 2027-06-29; baseline finish 2027-06-25 → 2027-06-29 |
| 3893 | **Readiness Assessment 8 - Ready for New Settlement Timetable** |  |  |  |  |  |  | was named Readiness Assessment 8 - Ready to Accept New MPANs |

## Version 29 (data date 2026-06-03, saved 2026-06-03, file MHHS-DEL1139 - MHHS Plan v6.51.mpp)

Last finish stays 2027-12-23.

Added:

| ID | Task | Duration | Start | Finish | Constraint |
| --- | --- | --- | --- | --- | --- |
| 3088 | CR065 Webinar | 1d | 2026-06-01 A | 2026-06-01 A | start no earlier than 2026-06-01 |
| 3089 | CR065 Impact Assessment Window | 10d | 2026-06-01 A | 2026-06-12 | start no earlier than 2026-06-01 |
| 3090 | CR065 PSG Approval | 0d | 2026-07-01 | 2026-07-01 | start no earlier than 2026-07-01 |
| 3707 | STEG 3 | 0d | 2026-06-10 | 2026-06-10 | start no earlier than 2026-06-10 |

Removed: 3550 Wave 1 - Service Activation Hypercare; 3551 Service& Process Monitoring; 3552 Daily Reporting; 3553 Issue Management; 3554 SA Hypercare Close Down Activities; 3555 Handover to MHHSP; 3556 Non-SIT LDSO Service Activation Hypercare Complete (M); 3557 Wave 1 - Service Activation Retro & Go/No Go; 3558 Review; 3559 Lessons Learned; 3560 Wave 2 - Service Activation Readiness Review Against Entry/Exit Criteria; 3571 Wave 2 - Service Activation Implementation MDD; 3572 MDD Final Circular Completed; 3573 MDD Manual Update; 3574 Wave 2 - Service Activation Hypercare; 3575 Service& Process Monitoring; 3576 Daily Reporting; 3577 Issue Management; 3578 SA Hypercare Close Down Activities; 3579 Handover to MHHSP; 3580 Wave 2 - Service Activation Hypercare Complete (M); 3581 Wave 2 - Service Activation Retro & Go/No Go; 3582 Review; 3583 Lessons Learned; 3584 Wave 3 - Service Activation Readiness Review Against Entry/Exit Criteria; 3585 Migration Pathway 5 (MP5); 3586 MP5 - Service Activation Preparation Tasks; 3587 Review Entry/Exit Criteria & Lessons Learned; 3588 Identify Resources; 3589 Confirmation from Qualification of Wave Participants Complete; 3590 Review Handover from MP3 and MP4; 3591 Agree & Understand Support Model; 3592 Confirm Training complete; 3593 Engagement / Communications with Participants; 3594 Internal Communications; 3595 Agree Content for Livewire; 3596 Publish Content for Livewire; 3597 Validate User Access; 3598 Target Systems and Environments Ready; 3599 Provide LWIs; 3600 Business Readiness Governance Approval; 3601 MP5 - Service Activation Preparation Tasks Completed; 3602 MP5 - Service Activation Implementation; 3603 PP to agree Effective from Date 40WD ahead of target PAB; 3604 PP to submit MDD Change Request; 3605 Market Entry to obtain Effective from Date from PP; 3606 PP Qualified by Code Bodies; 3607 DIP Promoted to Production; 3608 Create M16 in Customer Solution; 3609 MDD & ISD Publish; 3610 MDD & ISD Go-Live; 3611 MP5 - Service Activation Implementation Complete (M); 3612 MP5 - Service Activation Implementation MDD; 3613 MDD Final Circular Completed; 3614 MDD Manual Update; 3625 MP6 - Service Activation Implementation MDD; 3626 MDD Final Circular Completed; 3627 MDD Manual Update; 3785 STEG 27; 3937 M16 milestone checkpoint; 3938 M16 milestone checkpoint - date approval

Changed:

| ID | Task | Start | Finish | Duration | Complete | Total float | Other |
| --- | --- | --- | --- | --- | --- | --- | --- |
| 3 | **PROGRAMME MANAGEMENT** |  |  |  | 85% → 86% |  |  |
| 4 | **Programme Management** |  |  |  | 85% → 86% |  |  |
| 5 | Sprint-based prioritisation planning and execution |  |  |  | 85% → 86% |  |  |
| 6 | Programme governance secretariat |  |  |  | 85% → 86% |  |  |
| 7 | RAID management and reporting |  |  |  | 85% → 86% |  |  |
| 8 | Tracking against Programme outcomes and KPIs |  |  |  | 85% → 86% |  |  |
| 9 | Change control and reporting |  |  |  | 85% → 86% |  |  |
| 10 | Ongoing identification of lessons learned relating to the PMO and implementation of improvements |  |  |  | 85% → 86% |  |  |
| 11 | **Programme Internal Assurance Reviews** |  |  |  | 85% → 86% |  |  |
| 12 | Programme Internal Assurance Reviews |  |  |  | 85% → 86% |  |  |
| 13 | **Engagement with PPs** |  |  |  | 85% → 86% |  |  |
| 14 | Ongoing PP liaison activities |  |  |  | 85% → 86% |  |  |
| 15 | Milestone and Control Point objective setting |  |  |  | 85% → 86% |  |  |
| 16 | Reporting |  |  |  | 85% → 86% |  |  |
| 17 | **PP Engagement Events** |  |  |  | 85% → 86% |  |  |
| 18 | Bilateral meetings |  |  |  | 85% → 86% |  |  |
| 19 | Monthly webinars |  |  |  | 85% → 86% |  |  |
| 20 | Open days |  |  |  | 85% → 86% |  |  |
| 21 | **PP Communications** |  |  |  | 85% → 86% |  |  |
| 22 | The Clock updates (weekly) |  |  |  | 85% → 86% |  |  |
| 23 | Maintain and update content on public-facing Portal (and ongoing feedback reviews to identify and implement Portal improvements) |  |  |  | 85% → 86% |  |  |
| 24 | **Code Change Support / Other Programme Alignment** |  |  |  | 85% → 86% |  |  |
| 25 | Support DCC/BEIS on SEC change |  |  |  | 85% → 86% |  |  |
| 26 | Support on Smart Meters Act changes |  |  |  | 85% → 86% |  |  |
| 27 | Support DCC/RECCo on CSS change |  |  |  | 85% → 86% |  |  |
| 28 | Support Elexon on BSC change |  |  |  | 85% → 86% |  |  |
| 29 | Support code change inside & outside CCIAG |  |  |  | 85% → 86% |  |  |
| 30 | Support code change inside & outside CCAG |  |  |  | 85% → 86% |  |  |
| 56 | **Establish Design Change Management Processes** |  |  |  | 84% → 85% |  |  |
| 61 | Maintain E2E MHHS Design (post-M5 design change management processes operational) |  |  |  | 83% → 84% |  |  |
| 1435 | Create test plans and suites in master project |  |  | 2d? → 2d |  |  |  |
| 1436 | Create area paths / iterations |  |  | 2d? → 2d |  |  |  |
| 1437 | Create IAM roles |  |  | 2d? → 2d |  |  |  |
| 1438 | Add users to roles |  |  | 1d? → 1d |  |  |  |
| 1439 | **Testing permissions** |  |  | 2d? → 2d |  |  |  |
| 1440 | Adding tests |  |  | 2d? → 2d |  |  |  |
| 1441 | Deleting tests |  |  | 2d? → 2d |  |  |  |
| 1442 | Adding tests to incorrect Cohort |  |  | 2d? → 2d |  |  |  |
| 1443 | Add / delete defects |  |  | 2d? → 2d |  |  |  |
| 1445 | Testing Permissions - Evidence attachment security |  |  | 10d? → 10d |  |  |  |
| 1452 | Update SIT Dashboards for Sprints 4.1 & 4.2 across all Cohorts |  |  | 1d? → 1d |  |  |  |
| 1673 | **UIT Environment Preparation** |  |  |  | 97% → 98% |  |  |
| 1724 | **Onboarding and Test Data (Sandbox UIT)** |  |  |  | 83% → 86% |  |  |
| 1726 | Supplier & Agent Onboarding and Test Data Creation and Support |  |  |  | 72% → 76% |  |  |
| 1727 | **Sandbox Execution** |  |  |  | 85% → 87% |  |  |
| 1737 | **Sandbox Testing Execution (UIT) - Supplier & Agent Participants** |  |  |  | 72% → 76% |  |  |
| 1740 | Sandbox Testing Execution (UIT) - Supplier & Agent Participants |  |  |  | 72% → 76% |  |  |
| 1980 | **LDSO Onboarding - Phase 2** |  |  |  |  |  | baseline start none → 2025-07-31; baseline finish none → 2025-09-05 |
| 2309 | **ELEXON / HELIX M10 - M16** |  |  |  | 76% → 78% |  |  |
| 2440 | **SAT M16 Test Case Execution** |  |  |  | 37% → 71% |  |  |
| 2442 | SAT Functional Work / Bug Dependency | 2026-05-01 A | 2026-05-29 A |  | 0% → 100% | 387d → none |  |
| 2443 | SAT Test & Sign-off of Two Cases (Elexon Internal Sign-off) | 2026-06-01 A |  |  | 0% → 14% |  |  |
| 2444 | SAT Programme Assurance Review of Test Results |  |  |  | 40% → 71% |  |  |
| 2853 | **Qualification Wave 4** |  |  |  | 67% → 68% |  |  |
| 2876 | **Qualification Wave 4 Exit** |  |  |  | 4% → 9% |  |  |
| 2879 | Qualification Wave 4 Participants submit their Final QAD |  |  |  | 5% → 12% |  |  |
| 2917 | PAB2026/09 | 2026-05-28 A | 2026-05-28 A |  | 0% → 100% | 410d → none |  |
| 3083 | **Regulatory Governance** |  | 2026-04-30 → 2026-07-01 (+62d) | 544d → 587d | 99% → 98% | 430d → 387d |  |
| 3087 | Incentives Implementation | 2026-04-30 → 2026-06-25 (+56d) | 2026-04-30 → 2026-06-25 (+56d) |  |  | 430d → 390d | constraint none → finish no earlier than 2026-06-25 |
| 3304 | **Preparation for Cutover to Live** |  |  |  | 69% → 70% |  |  |
| 3396 | **Migration Sprints** |  |  |  | 35% → 37% |  |  |
| 3417 | **Migration Sprint 2** |  |  |  | 67% → 85% |  |  |
| 3424 | Sprint Execution |  | 2026-06-02 A |  | 77% → 100% | 397d → none |  |
| 3426 | Sprint Execution End | 2026-06-02 A | 2026-06-02 A |  | 0% → 100% | 397d → none |  |
| 3427 | Sprint 2 Retro | 2026-06-03 A |  |  | 0% → 10% |  |  |
| 3434 | Sprint Execution Start | 2026-06-03 A | 2026-06-03 A |  | 0% → 100% | 352d → none |  |
| 3510 | **BUSINESS & OPERATIONAL READINESS** |  |  |  | 83% → 86% |  |  |
| 3511 | **Service Management** |  |  |  | 86% → 91% |  |  |
| 3525 | **Migration Pathway (MP1) and Migration Pathway 2 (MP2)** |  | 2026-05-22 A → 2026-05-15 A (-7d) | 39d → 33d |  |  |  |
| 3553 | **Migration Pathway 3 (MP3) and Migration Pathway 4 (MP4)** |  | 2026-06-19 → 2026-06-09 (-10d) | 61d → 52d | 4% → 99% | 394d → 403d |  |

| ID | Task | Start | Finish | Duration | Complete | Total float | Predecessors | Other |
| --- | --- | --- | --- | --- | --- | --- | --- | --- |
| 3554 | **MP3 and MP4 - Service Activation Implementation** |  |  |  | 22% → 99% |  |  |  |
| 3557 | PP is Qualified by Code Bodies | 2026-05-28 A | 2026-05-28 A |  | 0% → 100% | 404d → none |  |  |
| 3558 | DIP Promoted to Production | 2026-05-29 A | 2026-06-04 A |  | 0% → 100% | 405d → none |  |  |
| 3559 | Create M16 in Customer Solution | 2026-05-29 A | 2026-05-29 A |  | 0% → 100% | 409d → none |  |  |
| 3560 | ISD Publish | 2026-06-01 A | 2026-06-01 A |  | 0% → 100% | 403d → none |  |  |
| 3675 | **M16: Decision Approach** |  |  |  | 77% → 99% |  |  |  |
| 3680 | **Consult and Agree with Industry** |  |  |  | 77% → 99% |  |  |  |
| 3696 | **M16 Decision Making and Monitoring Criteria Consultation** |  |  |  | 33% → 99% | -39d → -19d |  |  |
| 3699 | Consultation Period | 2026-04-29 A | 2026-05-26 A |  | 0% → 100% | -41d → none |  |  |
| 3700 | Consultation Period Completed | 2026-05-26 A | 2026-05-26 A |  | 0% → 100% | -41d → none |  | baseline start 2026-05-07 → 2026-05-26; baseline finish 2026-05-07 → 2026-05-26 |
| 3701 | Materials Issued for Approval at MCAG | 2026-06-02 → 2026-06-16 (+14d) | 2026-06-02 → 2026-06-16 (+14d) |  |  | -41d → -50d |  | constraint finish no earlier than 2026-05-14 → start no earlier than 2026-06-16; baseline start 2026-05-14 → 2026-06-16; baseline finish 2026-05-14 → 2026-06-16 |
| 3702 | M16 Approach Approved at MCAG |  |  |  |  |  |  | baseline start 2026-05-21 → 2026-06-23; baseline finish 2026-05-21 → 2026-06-23 |
| 3708 | STEG 4 | 2026-06-10 → 2026-06-24 (+14d) | 2026-06-10 → 2026-06-24 (+14d) |  |  | 402d → 392d |  | constraint start no earlier than 2026-06-10 → start no earlier than 2026-06-24; baseline start 2026-06-10 → 2026-06-24; baseline finish 2026-06-10 → 2026-06-24 |
| 3709 | STEG 5 | 2026-06-24 → 2026-07-08 (+14d) | 2026-06-24 → 2026-07-08 (+14d) |  |  | 392d → 349d |  | constraint start no earlier than 2026-06-24 → start no earlier than 2026-07-08; baseline start 2026-06-24 → 2026-07-08; baseline finish 2026-06-24 → 2026-07-08 |
| 3710 | STEG 6 | 2026-07-08 → 2026-07-22 (+14d) | 2026-07-08 → 2026-07-22 (+14d) |  |  | 349d → 372d |  | constraint start no earlier than 2026-07-08 → start no earlier than 2026-07-22; baseline start 2026-07-08 → 2026-07-22; baseline finish 2026-07-08 → 2026-07-22 |
| 3711 | STEG 7 | 2026-07-22 → 2026-08-05 (+14d) | 2026-07-22 → 2026-08-05 (+14d) |  |  | 372d → 362d |  | constraint start no earlier than 2026-07-22 → start no earlier than 2026-08-05; baseline start 2026-07-22 → 2026-08-05; baseline finish 2026-07-22 → 2026-08-05 |
| 3712 | STEG 8 | 2026-08-05 → 2026-08-19 (+14d) | 2026-08-05 → 2026-08-19 (+14d) |  |  | 362d → 352d |  | constraint start no earlier than 2026-08-05 → start no earlier than 2026-08-19; baseline start 2026-08-05 → 2026-08-19; baseline finish 2026-08-05 → 2026-08-19 |
| 3713 | STEG 9 | 2026-08-19 → 2026-09-02 (+14d) | 2026-08-19 → 2026-09-02 (+14d) |  |  | 352d → 337d |  | constraint start no earlier than 2026-08-19 → start no earlier than 2026-09-02; baseline start 2026-08-19 → 2026-09-02; baseline finish 2026-08-19 → 2026-09-02 |
| 3714 | STEG 10 | 2026-09-02 → 2026-09-16 (+14d) | 2026-09-02 → 2026-09-16 (+14d) |  |  | 337d → 332d |  | constraint start no earlier than 2026-09-02 → start no earlier than 2026-09-16; baseline start 2026-09-02 → 2026-09-16; baseline finish 2026-09-02 → 2026-09-16 |
| 3715 | STEG 11 | 2026-09-16 → 2026-09-30 (+14d) | 2026-09-16 → 2026-09-30 (+14d) |  |  | 332d → 322d |  | constraint start no earlier than 2026-09-16 → start no earlier than 2026-09-30; baseline start 2026-09-16 → 2026-09-30; baseline finish 2026-09-16 → 2026-09-30 |
| 3716 | STEG 12 | 2026-09-30 → 2026-10-14 (+14d) | 2026-09-30 → 2026-10-14 (+14d) |  |  | 322d → 312d |  | constraint start no earlier than 2026-09-30 → start no earlier than 2026-10-14; baseline start 2026-09-30 → 2026-10-14; baseline finish 2026-09-30 → 2026-10-14 |
| 3717 | STEG 13 | 2026-10-14 → 2026-10-28 (+14d) | 2026-10-14 → 2026-10-28 (+14d) |  |  | 312d → 302d |  | constraint start no earlier than 2026-10-14 → start no earlier than 2026-10-28; baseline start 2026-10-14 → 2026-10-28; baseline finish 2026-10-14 → 2026-10-28 |
| 3718 | STEG 14 | 2026-10-28 → 2026-11-11 (+14d) | 2026-10-28 → 2026-11-11 (+14d) |  |  | 302d → 292d |  | constraint start no earlier than 2026-10-28 → start no earlier than 2026-11-11; baseline start 2026-10-28 → 2026-11-11; baseline finish 2026-10-28 → 2026-11-11 |
| 3719 | STEG 15 | 2026-11-11 → 2026-11-25 (+14d) | 2026-11-11 → 2026-11-25 (+14d) |  |  | 292d → 282d |  | constraint start no earlier than 2026-11-11 → start no earlier than 2026-11-25; baseline start 2026-11-11 → 2026-11-25; baseline finish 2026-11-11 → 2026-11-25 |
| 3720 | STEG 16 | 2026-11-25 → 2026-12-09 (+14d) | 2026-11-25 → 2026-12-09 (+14d) |  |  | 282d → 272d |  | constraint start no earlier than 2026-11-25 → start no earlier than 2026-12-09; baseline start 2026-11-25 → 2026-12-09; baseline finish 2026-11-25 → 2026-12-09 |
| 3721 | STEG 17 | 2026-12-09 → 2026-12-23 (+14d) | 2026-12-09 → 2026-12-23 (+14d) |  |  | 272d → 262d |  | constraint start no earlier than 2026-12-09 → start no earlier than 2026-12-23; baseline start 2026-12-09 → 2026-12-23; baseline finish 2026-12-09 → 2026-12-23 |
| 3722 | STEG 18 | 2026-12-23 → 2027-01-06 (+14d) | 2026-12-23 → 2027-01-06 (+14d) |  |  | 262d → 252d |  | constraint start no earlier than 2026-12-23 → start no earlier than 2027-01-06; baseline start 2026-12-23 → 2027-01-06; baseline finish 2026-12-23 → 2027-01-06 |
| 3723 | STEG 19 | 2027-01-06 → 2027-01-20 (+14d) | 2027-01-06 → 2027-01-20 (+14d) |  |  | 252d → 242d |  | constraint start no earlier than 2027-01-06 → start no earlier than 2027-01-20; baseline start 2027-01-06 → 2027-01-20; baseline finish 2027-01-06 → 2027-01-20 |
| 3724 | STEG 20 | 2027-01-20 → 2027-02-03 (+14d) | 2027-01-20 → 2027-02-03 (+14d) |  |  | 242d → 232d |  | constraint start no earlier than 2027-01-20 → start no earlier than 2027-02-03; baseline start 2027-01-20 → 2027-02-03; baseline finish 2027-01-20 → 2027-02-03 |
| 3725 | STEG 21 | 2027-02-03 → 2027-02-17 (+14d) | 2027-02-03 → 2027-02-17 (+14d) |  |  | 232d → 222d |  | constraint start no earlier than 2027-02-03 → start no earlier than 2027-02-17; baseline start 2027-02-03 → 2027-02-17; baseline finish 2027-02-03 → 2027-02-17 |
| 3726 | STEG 22 | 2027-02-17 → 2027-03-03 (+14d) | 2027-02-17 → 2027-03-03 (+14d) |  |  | 222d → 207d |  | constraint start no earlier than 2027-02-17 → start no earlier than 2027-03-03; baseline start 2027-02-17 → 2027-03-03; baseline finish 2027-02-17 → 2027-03-03 |
| 3727 | STEG 23 | 2027-03-03 → 2027-03-17 (+14d) | 2027-03-03 → 2027-03-17 (+14d) |  |  | 207d → 202d |  | constraint start no earlier than 2027-03-03 → start no earlier than 2027-03-17; baseline start 2027-03-03 → 2027-03-17; baseline finish 2027-03-03 → 2027-03-17 |
| 3728 | STEG 24 | 2027-03-17 → 2027-03-31 (+14d) | 2027-03-17 → 2027-03-31 (+14d) |  |  | 202d → 192d |  | constraint start no earlier than 2027-03-17 → start no earlier than 2027-03-31; baseline start 2027-03-17 → 2027-03-31; baseline finish 2027-03-17 → 2027-03-31 |
| 3729 | STEG 25 | 2027-03-31 → 2027-04-14 (+14d) | 2027-03-31 → 2027-04-14 (+14d) |  |  | 192d → 182d |  | constraint start no earlier than 2027-03-31 → start no earlier than 2027-04-14; baseline start 2027-03-31 → 2027-04-14; baseline finish 2027-03-31 → 2027-04-14 |
| 3730 | STEG 26 | 2027-04-14 → 2027-04-28 (+14d) | 2027-04-14 → 2027-04-28 (+14d) |  |  | 182d → 172d |  | constraint start no earlier than 2027-04-14 → start no earlier than 2027-04-28; baseline start 2027-04-14 → none; baseline finish 2027-04-14 → none |
| 3735 | STEG Issue position to MCAG notifying Decision Checkpoint 1 On-track |  |  |  |  |  | 3710 → 3709 |  |
| 3744 | STEG to compare Monitoring report against agreed assessment criteria |  |  |  |  |  | 3714 → 3713 |  |
| 3749 | STEG to compare Monitoring report against agreed assessment criteria |  |  |  |  |  | 3727 → 3726 |  |
| 3875 | **MILESTONE RANGE CHECKPOINTS** |  | 2027-04-12 → 2027-02-15 (-56d) | 442d → 402d |  | 184d → 224d |  |  |

## Version 30 (data date 2026-06-17, saved 2026-06-17, file MHHS-DEL1139 - MHHS Plan v6.52.mpp)

Last finish stays 2027-12-23. Complete tasks 2792 → 2716.

Removed: 2310 Solution Build Sprints; 2311 25.18; 2312 25.19; 2313 25.20; 2314 25.21; 2315 25.22; 2316 25.23; 2317 25.24; 2318 26.1; 2319 26.2; 2320 26.3; 2321 26.4; 2322 26.5; 2323 26.6; 2324 26.7; 2325 26.8; 2326 26.9; 2327 26.10; 2328 26.11; 2329 26.12; 2330 26.13; 2331 Release management deployment schedule; 2332 25.14.5; 2333 25.14.6; 2334 25.14.7; 2335 25.14.8; 2336 25.14.9; 2337 26.1.0; 2338 26.2.0; 2339 26.3.0; 2340 26.4.0; 2341 26.5.0; 2342 26.6.0; 2343 26.7.0; 2344 26.8.0; 2345 26.9.0; 2346 26.10.0; 2347 26.11.0; 2348 26.12.0; 2349 26.13.0; 2350 26.14.0; 2351 Work Package Development; 2352 DAH; 2353 MSID Counts and Missing DA files (Bronze to Silver); 2354 P0276 & P0277 Reports; 2355 Throughput monitoring for DIP ingestion; 2356 P0213 Report; 2357 P0214 Report; 2358 P0275 Report; 2359 Errors & warnings in new DAH table; 2360 Electralink; 2361 CP1607 IF-51 Data Refresh (CR044); 2362 CP1606 Supplier Start Date Correction Tools (CR045); 2363 MDS Annual Consumption; 2364 Missing Parms report; 2365 Trading Disputes; 2366 Business Validations Analysis; 2367 Merge IF51 into main; 2368 Upload 350K MPANs; 2369 Enable batching to DIP; 2370 Tech debt DA3 test suite improvements; 2371 Data lifecycle; 2372 Business Validations; 2373 CR45 Code Merge; 2374 Tech Debt DA2: Azure cost reduction, optimising data storage and processing; 2375 Tech Debt DA4: Code maintainability enhancements; 2376 SDR Discovery; 2377 P0036A and P0036D; 2378 Electralink improvement; 2379 REP009 CoS Updates; 2380 I022 incremental sequence; 2381 Smart Data Repository; 2382 [OP] – Trading Dispute Tab for Legacy File; 2383 Trading Dispute CR; 2384 WP2 (LSS/MDS/VAS/OP); 2385 Implementation of P0275; 2386 SCCS Technical Work; 2387 SCCS Report; 2388 LSS Publishing Load Shapes; 2389 Update configuration parameters into Operator Portal for LSS / VAS; 2390 Operator Portal Configuration Parameters (part 1); 2391 MDS Annual Consumption; 2392 Missing Parms report; 2393 LSS Threshold; 2394 Errors and Warnings / Business Validation; 2395 Operator portal override functionality; 2396 VAS override functionality; 2397 Pause & resume settlement day / run type; 2398 SCCS Trading Party ID; 2399 OP: Edit configuration parameters from UI; 2400 MDS (remove IF-96); 2401 Make VAS run during transition mode without legacy data; 2402 MDS defaulting invalid consumption; 2403 VAS – Introduce Pre-Runs (analysis); 2404 E2E Settlement Run Automated Test Suite – Add 7 JSON reports to comparison process; 2405 ISD; 2406 ISD Asure; 2407 Validation error messages (RT and CSAD); 2408 LLF publication and filter; 2409 DTID Data to EIS; 2410 P489 – Multiple MST Upload (Analysis); 2411 LLF Process Improvement Analysis; 2412 ISD Refresh; 2413 Tech Debt IA2 & IS2 Empty Catalogue Publication; 2414 ISD Navigation Analysis; 2415 LLF Validation Messages Improvement; 2416 LLF Submissions Improvement; 2417 ISD Salesforce; 2418 ISD UI Alignment; 2419 Tech Debt IA2 & IS2 Empty Catalogue Publication; 2420 Catalogue Publish Improvement Analysis; 2421 Manage ISD Process Improvement Analysis; 2422 ISD Refresh; 2423 Catalogue Publish Improvement Development; 2424 Manage ISD Process Improvement Development; 2425 Settlement Checks; 2426 M10; 2427 M10 Settlement Start Date; 2428 R1; 2429 R2; 2430 R3; 2431 RF; 2432 M11; 2433 M11 Settlement Start Date; 2434 II; 2435 SF; 2436 R1; 2437 R2; 2438 R3; 2439 RF; 3706 STEG 3

Changed:

| ID | Task | Start | Finish | Duration | Complete | Total float |
| --- | --- | --- | --- | --- | --- | --- |
| 1 | **PROGRAMME PLAN.** |  |  |  | 92% → 93% |  |
| 3 | **PROGRAMME MANAGEMENT** |  |  |  | 86% → 87% |  |
| 4 | **Programme Management** |  |  |  | 86% → 87% |  |
| 5 | Sprint-based prioritisation planning and execution |  |  |  | 86% → 87% |  |
| 6 | Programme governance secretariat |  |  |  | 86% → 87% |  |
| 7 | RAID management and reporting |  |  |  | 86% → 87% |  |
| 8 | Tracking against Programme outcomes and KPIs |  |  |  | 86% → 87% |  |
| 9 | Change control and reporting |  |  |  | 86% → 87% |  |
| 10 | Ongoing identification of lessons learned relating to the PMO and implementation of improvements |  |  |  | 86% → 87% |  |
| 11 | **Programme Internal Assurance Reviews** |  |  |  | 86% → 87% |  |
| 12 | Programme Internal Assurance Reviews |  |  |  | 86% → 87% |  |
| 13 | **Engagement with PPs** |  |  |  | 86% → 87% |  |
| 14 | Ongoing PP liaison activities |  |  |  | 86% → 87% |  |
| 15 | Milestone and Control Point objective setting |  |  |  | 86% → 87% |  |
| 16 | Reporting |  |  |  | 86% → 87% |  |
| 17 | **PP Engagement Events** |  |  |  | 86% → 87% |  |
| 18 | Bilateral meetings |  |  |  | 86% → 87% |  |
| 19 | Monthly webinars |  |  |  | 86% → 87% |  |
| 20 | Open days |  |  |  | 86% → 87% |  |
| 21 | **PP Communications** |  |  |  | 86% → 87% |  |
| 22 | The Clock updates (weekly) |  |  |  | 86% → 87% |  |
| 23 | Maintain and update content on public-facing Portal (and ongoing feedback reviews to identify and implement Portal improvements) |  |  |  | 86% → 87% |  |
| 24 | **Code Change Support / Other Programme Alignment** |  |  |  | 86% → 87% |  |
| 25 | Support DCC/BEIS on SEC change |  |  |  | 86% → 87% |  |
| 26 | Support on Smart Meters Act changes |  |  |  | 86% → 87% |  |
| 27 | Support DCC/RECCo on CSS change |  |  |  | 86% → 87% |  |
| 28 | Support Elexon on BSC change |  |  |  | 86% → 87% |  |
| 29 | Support code change inside & outside CCIAG |  |  |  | 86% → 87% |  |
| 30 | Support code change inside & outside CCAG |  |  |  | 86% → 87% |  |
| 56 | **Establish Design Change Management Processes** |  |  |  | 85% → 86% |  |
| 61 | Maintain E2E MHHS Design (post-M5 design change management processes operational) |  |  |  | 84% → 85% |  |
| 1724 | **Onboarding and Test Data (Sandbox UIT)** |  |  |  | 86% → 88% |  |
| 1726 | Supplier & Agent Onboarding and Test Data Creation and Support |  |  |  | 76% → 80% |  |
| 1727 | **Sandbox Execution** |  |  |  | 87% → 89% |  |
| 1737 | **Sandbox Testing Execution (UIT) - Supplier & Agent Participants** |  |  |  | 76% → 80% |  |
| 1740 | Sandbox Testing Execution (UIT) - Supplier & Agent Participants |  |  |  | 76% → 80% |  |
| 2309 | **ELEXON / HELIX M10 - M16** | 2025-09-03 A → 2026-04-01 A (+210d) | 2026-12-09 → 2026-06-30 (-162d) | 331d? → 65d | 78% → 86% | 271d → 387d |
| 2310 | **SAT M16 Test Case Execution** |  |  |  | 71% → 86% |  |
| 2313 | SAT Test & Sign-off of Two Cases (Elexon Internal Sign-off) |  |  |  | 14% → 59% |  |
| 2314 | SAT Programme Assurance Review of Test Results |  |  |  | 71% → 86% |  |
| 2316 | **S & A QUALIFICATION** |  |  |  | 97% → 98% |  |
| 2428 | **MHHS Qualification - Qualification Waves** |  |  |  | 96% → 97% |  |
| 2647 | **Qualification Wave 2** |  | 2026-05-28 A |  | 99% → 100% | 410d → none |
| 2675 | **Qualification Wave 2 Exit** |  | 2026-05-28 A |  | 99% → 100% | 410d → none |
| 2683 | 80% of M14 Critical Wave 2 Participants Qualification approved by BSC PAB and REC Manager | 2026-05-28 A | 2026-05-28 A |  | 0% → 100% | 411d → none |
| 2684 | All M14 Critical Wave 2 Participants Qualification approved by BSC PAB and REC Manager | 2026-05-28 A | 2026-05-28 A |  | 0% → 100% | 410d → none |
| 2685 | **Qualification Wave 3** |  |  |  | 91% → 94% |  |
| 2686 | **Qualification Wave 3 QAD Prep** |  | 2025-12-19 A |  | 97% → 100% | 524d → none |
| 2691 | Code Bodies review of Wave 3 Participants' Initial QAD |  | 2025-12-19 A |  | 90% → 100% | 524d → none |
| 2692 | Completion of Code Bodies review of Initial QAD | 2025-12-19 A | 2025-12-19 A |  | 0% → 100% | 524d → none |
| 2713 | **Qualification Wave 3 Exit** |  |  |  | 74% → 81% |  |
| 2716 | Qualification Wave 3 Participants submit their Final QAD |  |  |  | 87% → 97% |  |
| 2723 | **Qualification Wave 4** |  |  |  | 68% → 74% |  |
| 2724 | **Qualification Wave 4 QAD Prep** |  |  |  | 82% → 99% |  |
| 2728 | Code Bodies review of Wave 4 Participants' Initial QAD |  | 2026-02-27 A |  | 42% → 100% | 474d → none |
| 2740 | **Qualification Wave 4 QT Execution** |  | 2026-07-10 A |  | 98% → 100% | 0.4d → none |
| 2744 | Qualification Wave 4 QT Execution Window |  | 2026-07-10 A |  | 98% → 100% | 0.4d → none |
| 2745 | Qualification Wave 4 Projected Execution End | 2026-07-10 A | 2026-07-10 A |  | 0% → 100% | 0.4d → none |
| 2746 | **Qualification Wave 4 Exit** |  |  |  | 9% → 13% |  |
| 2749 | Qualification Wave 4 Participants submit their Final QAD |  |  |  | 12% → 16% | 0.4d → 1.4d |
| 2751 | Completion of Code Bodies review of Final QAD |  |  |  | 2% → 7% |  |
| 2788 | PAB2026/10 | 2026-06-10 A | 2026-06-10 A |  | 0% → 100% | 401d → none |
| 2953 | **Regulatory Governance** |  |  |  | 98% → 99% |  |
| 2959 | CR065 Impact Assessment Window |  | 2026-06-12 A |  | 30% → 100% | 399d → none |
| 3174 | **Preparation for Cutover to Live** |  |  |  | 70% → 71% |  |
| 3266 | **Migration Sprints** |  |  |  | 37% → 39% |  |
| 3287 | **Migration Sprint 2** |  | 2026-06-16 A |  | 85% → 100% | 397d → none |
| 3297 | Sprint 2 Retro |  | 2026-06-16 A |  | 10% → 100% | 397d → none |
| 3418 | MDD & ISD Go-Live |  |  | 0d → 1d |  |  |
| 3423 | **Migration Pathway 3 (MP3) and Migration Pathway 4 (MP4)** |  | 2026-06-09 A |  | 99% → 100% | 403d → none |

| ID | Task | Start | Finish | Complete | Total float | Predecessors | Other |
| --- | --- | --- | --- | --- | --- | --- | --- |
| 3424 | **MP3 and MP4 - Service Activation Implementation** |  | 2026-06-09 A | 99% → 100% | 403d → none |  |  |
| 3431 | ISD Go-Live | 2026-06-08 A | 2026-06-08 A | 0% → 100% | 403d → none |  |  |
| 3432 | MP3 and MP4 - Service Activation Implementation Complete (M) | 2026-06-09 A | 2026-06-09 A | 0% → 100% | 403d → none |  |  |
| 3433 | **Migration Pathway 6 (MP6)** |  |  | 7% → 9% |  |  |  |
| 3434 | **MP6 - Service Activation Implementation** |  |  | 10% → 20% |  |  |  |
| 3436 | Market Entry to obtain Effective from Date from PP | 2026-06-11 A | 2026-06-11 A | 0% → 100% | 400d → none |  |  |
| 3457 | **Migration Pathway 8 (MP8)** | 2026-06-04 A |  | 0% → 11% |  |  |  |
| 3458 | **MP8 - Service Activation Implementation** | 2026-06-04 A |  | 0% → 11% |  |  |  |
| 3459 | PP to agree Effective from Date 40WD ahead of target PAB | 2026-06-04 A | 2026-06-04 A | 0% → 100% | 405d → none |  |  |
| 3576 | STEG 3 | 2026-06-10 A | 2026-06-10 A | 0% → 100% | 402d → none |  |  |
| 3599 | STEG 26 |  |  |  |  |  | baseline start none → 2027-04-28; baseline finish none → 2027-04-28 |
| 3724 | Readiness Assessment 8 - Ready for New Settlement Timetable - Completed (incl. Readiness Assessment Report approval) | 2026-10-13 → 2026-08-14 (-60d) | 2026-10-13 → 2026-08-14 (-60d) |  | 312d → 355d | 3713 → none | was named Readiness Assessment 8 - Ready to Accept New MPANs - Completed (incl. Readiness Assessment Report approval); constraint none → start no earlier than 2026-08-14; baseline start 2026-10-13 → 2026-08-14; baseline finish 2026-10-13 → 2026-08-14 |

## Version 31 (data date 2026-07-29, saved 2026-07-29, file MHHS-DEL1139 - MHHS Plan v6.55.mpp)

Last finish stays 2027-12-23. Complete tasks 2716 → 2759.

Added:

| ID | Task | Duration | Start | Finish | Predecessors | Constraint |
| --- | --- | --- | --- | --- | --- | --- |
| 3581 | Update Monitoring Data to be provided from Performance Assurance and MCC | 1d | 2026-09-01 | 2026-09-01 |  | start no earlier than 2026-09-01 |
| 3586 | Communication issued to Industry notifying Parties RF will be 7 months | 1d | 2026-09-15 | 2026-09-15 |  | start no earlier than 2026-09-15 |
| 3719 | M14 checkpoint: QAG to assess M14 delivery confidence against the Acceptance Criteria | 0d | 2026-08-18 | 2026-08-18 | 3718 | start no earlier than 2026-08-18 |
| 3720 | M14 Checkpoint: PSG assesses M14 delivery confidence | 0d | 2026-09-02 | 2026-09-02 | 2720 | start no earlier than 2026-09-02 |
| 3721 | Notification to Ofgem of no central issues as of QA+P Annex 4 | 0d | 2026-09-03 | 2026-09-03 | 3720 | start no earlier than 2026-09-03 |
| 3722 | M14 Recommendation: eQWG to confirm Qualified participants for start of Migration | 0d | 2026-10-23 | 2026-10-23 |  | start no earlier than 2026-10-23 |
| 3723 | M14 Recommendation: eQAG to recommend M14 | 0d | 2026-10-26 | 2026-10-26 | 3722 | start no earlier than 2026-10-26 |
| 3724 | M14 Decision: ePSG to confirm M14 | 0d | 2026-10-27 | 2026-10-27 | 3723 | start no earlier than 2026-10-27 |

Removed: 3574 STEG 1; 3575 STEG 2; 3576 STEG 3; 3577 STEG 4; 3578 STEG 5; 3579 STEG 6; 3580 STEG 7; 3581 STEG 8; 3582 STEG 9; 3583 STEG 10; 3584 STEG 11; 3585 STEG 12; 3586 STEG 13; 3587 STEG 14; 3588 STEG 15; 3589 STEG 16; 3590 STEG 17; 3591 STEG 18; 3592 STEG 19; 3593 STEG 20; 3594 STEG 21; 3595 STEG 22; 3596 STEG 23; 3597 STEG 24; 3598 STEG 25; 3599 STEG 26; 3601 STEG June; 3607 Prepare Readiness Assessment - Material Describing Transition Design and Queries to PPs guaging understanding an organisational readiness; 3608 Issue Readiness Assessment Following Interim Recommendation; 3609 Readiness Assessment 8 Consultation Period Complete; 3610 Readiness Assessment 8 Complete; 3611 Assess Readiness Assessment 8 and Plan further enagement activity if required

Changed:

| ID | Task | Start | Finish | Duration | Complete | Total float | Predecessors | Other |
| --- | --- | --- | --- | --- | --- | --- | --- | --- |
| 1 | **PROGRAMME PLAN.** |  |  |  | 93% → 95% |  |  |  |
| 3 | **PROGRAMME MANAGEMENT** |  |  |  | 87% → 90% |  |  |  |
| 4 | **Programme Management** |  |  |  | 87% → 90% |  |  |  |
| 5 | Sprint-based prioritisation planning and execution |  |  |  | 87% → 90% |  |  |  |
| 6 | Programme governance secretariat |  |  |  | 87% → 90% |  |  |  |
| 7 | RAID management and reporting |  |  |  | 87% → 90% |  |  |  |
| 8 | Tracking against Programme outcomes and KPIs |  |  |  | 87% → 90% |  |  |  |
| 9 | Change control and reporting |  |  |  | 87% → 90% |  |  |  |
| 10 | Ongoing identification of lessons learned relating to the PMO and implementation of improvements |  |  |  | 87% → 90% |  |  |  |
| 11 | **Programme Internal Assurance Reviews** |  |  |  | 87% → 90% |  |  |  |
| 12 | Programme Internal Assurance Reviews |  |  |  | 87% → 90% |  |  |  |
| 13 | **Engagement with PPs** |  |  |  | 87% → 90% |  |  |  |
| 14 | Ongoing PP liaison activities |  |  |  | 87% → 90% |  |  |  |
| 15 | Milestone and Control Point objective setting |  |  |  | 87% → 90% |  |  |  |
| 16 | Reporting |  |  |  | 87% → 90% |  |  |  |
| 17 | **PP Engagement Events** |  |  |  | 87% → 90% |  |  |  |
| 18 | Bilateral meetings |  |  |  | 87% → 90% |  |  |  |
| 19 | Monthly webinars |  |  |  | 87% → 90% |  |  |  |
| 20 | Open days |  |  |  | 87% → 90% |  |  |  |
| 21 | **PP Communications** |  |  |  | 87% → 90% |  |  |  |
| 22 | The Clock updates (weekly) |  |  |  | 87% → 90% |  |  |  |
| 23 | Maintain and update content on public-facing Portal (and ongoing feedback reviews to identify and implement Portal improvements) |  |  |  | 87% → 90% |  |  |  |
| 24 | **Code Change Support / Other Programme Alignment** |  |  |  | 87% → 90% |  |  |  |
| 25 | Support DCC/BEIS on SEC change |  |  |  | 87% → 90% |  |  |  |
| 26 | Support on Smart Meters Act changes |  |  |  | 87% → 90% |  |  |  |
| 27 | Support DCC/RECCo on CSS change |  |  |  | 87% → 90% |  |  |  |
| 28 | Support Elexon on BSC change |  |  |  | 87% → 90% |  |  |  |
| 29 | Support code change inside & outside CCIAG |  |  |  | 87% → 90% |  |  |  |
| 30 | Support code change inside & outside CCAG |  |  |  | 87% → 90% |  |  |  |
| 45 | **DESIGN, BUILD & TEST (PIT)** |  |  |  | 98% → 99% |  |  |  |
| 46 | **Design Baseline & Enduring PP Support** |  |  |  | 93% → 95% |  |  |  |
| 56 | **Establish Design Change Management Processes** |  |  |  | 86% → 88% |  |  |  |
| 61 | Maintain E2E MHHS Design (post-M5 design change management processes operational) |  |  |  | 85% → 88% |  |  |  |
| 1673 | **UIT Environment Preparation** |  |  |  | 98% → 99% |  |  |  |
| 1724 | **Onboarding and Test Data (Sandbox UIT)** |  |  |  | 88% → 95% |  |  |  |
| 1726 | Supplier & Agent Onboarding and Test Data Creation and Support |  |  |  | 80% → 92% |  |  |  |
| 1727 | **Sandbox Execution** |  |  |  | 89% → 95% |  |  |  |
| 1737 | **Sandbox Testing Execution (UIT) - Supplier & Agent Participants** |  |  |  | 80% → 92% |  |  |  |
| 1740 | Sandbox Testing Execution (UIT) - Supplier & Agent Participants |  |  |  | 80% → 92% |  |  |  |
| 2309 | **ELEXON / HELIX M10 - M16** |  | 2026-06-30 A |  | 86% → 100% | 387d → none |  |  |
| 2310 | **SAT M16 Test Case Execution** |  | 2026-06-30 A |  | 86% → 100% | 387d → none |  |  |
| 2313 | SAT Test & Sign-off of Two Cases (Elexon Internal Sign-off) |  | 2026-06-30 A |  | 59% → 100% | 387d → none |  |  |
| 2314 | SAT Programme Assurance Review of Test Results |  | 2026-06-30 A |  | 86% → 100% | 387d → none |  |  |
| 2316 | **S & A QUALIFICATION** |  |  |  | 98% → 99% |  |  |  |
| 2428 | **MHHS Qualification - Qualification Waves** |  |  |  | 97% → 99% |  |  |  |
| 2685 | **Qualification Wave 3** |  |  | 254d? → 254d | 94% → 99% |  |  |  |
| 2706 | **Qualification Wave 3 QT Execution** |  | 2026-05-15 → 2026-05-08 A (-7d) | 110d? → 105d |  |  |  | baseline start 2025-11-03 → 2025-12-15; baseline finish 2026-03-24 → 2026-05-15 |
| 2713 | **Qualification Wave 3 Exit** |  |  |  | 81% → 99% |  |  |  |
| 2716 | Qualification Wave 3 Participants submit their Final QAD |  | 2026-05-22 A |  | 97% → 100% | 414d → none |  |  |
| 2718 | All Qualification Wave 3 Participants have submitted their Final QAD | 2026-05-22 A | 2026-05-22 A |  | 0% → 100% | 414d → none |  |  |
| 2719 | Completion of Code Bodies review of Final QAD | 2026-05-25 A | 2026-06-19 A |  | 0% → 100% | 365d → none |  |  |
| 2720 | QAD Sign Off deadline | 2026-06-26 A | 2026-06-26 A |  | 0% → 100% | 365d → none |  |  |
| 2723 | **Qualification Wave 4** |  |  |  | 74% → 99% |  |  |  |
| 2724 | **Qualification Wave 4 QAD Prep** |  | 2026-02-27 A |  | 99% → 100% | 474d → none |  |  |
| 2729 | Completion of Code Bodies review of Initial QAD | 2026-02-27 A | 2026-02-27 A |  | 0% → 100% | 474d → none |  |  |
| 2744 | Qualification Wave 4 QT Execution Window |  |  |  |  |  |  | baseline finish 2026-07-17 → 2026-07-10 |
| 2746 | **Qualification Wave 4 Exit** |  |  |  | 13% → 96% |  |  |  |
| 2747 | Assurance on PP Test Completion Report | 2026-07-13 A | 2026-07-24 A |  | 0% → 100% | 1.4d → none |  |  |
| 2749 | Qualification Wave 4 Participants submit their Final QAD |  | 2026-07-24 A |  | 16% → 100% | 1.4d → none |  |  |
| 2750 | Qualification Wave 4 Participants have submitted their Final QAD | 2026-07-24 A | 2026-07-24 A |  | 0% → 100% | 1.4d → none |  |  |
| 2751 | Completion of Code Bodies review of Final QAD |  |  |  | 7% → 78% | 235d → 0.62d |  |  |
| 2752 | QAD Sign Off deadline | 2026-08-28 A |  |  | 0% → 62% |  |  |  |
| 2755 | All suppliers must be able to access MPANs under the new TOM (M14) |  |  |  |  |  | 2753FS+24d → 2753FS+24d, 3724 |  |
| 2756 | All suppliers must be able to access MPANs under the new TOM (M14*) - Late Exit |  |  |  |  |  | 2755FS+66d → 2755FS+66d, 3724 |  |
| 2789 | PAB2026/11 | 2026-06-25 A | 2026-06-25 A |  | 0% → 100% | 390d → none |  |  |
| 2790 | PAB2026/12 | 2026-07-15 A | 2026-07-15 A |  | 0% → 100% | 376d → none |  |  |
| 2952 | **MIGRATION** |  |  |  | 95% → 96% |  |  |  |
| 2953 | **Regulatory Governance** |  | 2026-07-01 A |  | 99% → 100% | 387d → none |  |  |
| 2957 | Incentives Implementation | 2026-06-25 A | 2026-06-25 A |  | 0% → 100% | 390d → none |  |  |
| 2960 | CR065 PSG Approval | 2026-07-01 A | 2026-07-01 A |  | 0% → 100% | 387d → none |  |  |

| ID | Task | Start | Finish | Duration | Complete | Total float | Predecessors | Other |
| --- | --- | --- | --- | --- | --- | --- | --- | --- |
| 3174 | **Preparation for Cutover to Live** |  |  |  | 71% → 75% |  |  |  |
| 3266 | **Migration Sprints** |  |  |  | 39% → 47% |  |  |  |
| 3298 | **Migration Sprint 3** |  |  |  | 10% → 77% |  |  |  |
| 3305 | Sprint Execution | 2026-06-04 A |  |  | 0% → 91% |  |  |  |
| 3308 | **Migration Sprint 4** | 2026-07-08 A |  |  | 0% → 10% |  |  |  |
| 3309 | Sprint 4 Planning start date | 2026-07-08 A | 2026-07-15 A |  | 0% → 100% | 307d → none |  |  |
| 3310 | Issue Envelope | 2026-07-15 A | 2026-07-15 A |  | 0% → 100% | 307d → none |  |  |
| 3311 | Supplier Submission Deadline | 2026-07-22 A | 2026-07-22 A |  | 0% → 100% | 307d → none |  |  |
| 3312 | Baseline Schedule Publication | 2026-07-29 A | 2026-07-29 A |  | 0% → 100% | 307d → none |  |  |
| 3313 | Migration Sprint 4 Schedule Baselined | 2026-07-29 A | 2026-07-29 A |  | 0% → 100% | 307d → none |  |  |
| 3339 | Sprint 7 Planning start date |  |  |  |  |  |  | was named Sprint 6 Planning start date |
| 3380 | **BUSINESS & OPERATIONAL READINESS** |  |  | 1344d → 1344d? | 86% → 88% |  |  |  |
| 3381 | **Service Management** |  |  |  | 91% → 94% |  |  |  |
| 3433 | **Migration Pathway 6 (MP6)** |  |  |  | 9% → 43% |  |  |  |
| 3434 | **MP6 - Service Activation Implementation** |  | 2026-07-07 A |  | 20% → 100% |  |  |  |
| 3437 | PP Qualified by Code Bodies | 2026-06-25 A | 2026-06-25 A |  | 0% → 100% |  |  |  |
| 3438 | DIP Promoted to Production | 2026-06-26 A | 2026-07-02 A |  | 0% → 100% |  |  |  |
| 3439 | Create M16 in Customer Solution | 2026-06-26 A | 2026-06-26 A |  | 0% → 100% |  |  |  |
| 3440 | ISD Publish | 2026-06-29 A | 2026-06-29 A |  | 0% → 100% |  |  |  |
| 3441 | ISD Go-Live | 2026-07-06 A | 2026-07-06 A |  | 0% → 100% |  |  |  |
| 3442 | MP6 - Service Activation Implementation Complete (M) | 2026-07-07 A | 2026-07-07 A |  | 0% → 100% |  |  |  |
| 3443 | **Migration Pathway 7 (MP7)** |  | 2026-07-28 A |  | 38% → 100% | 368d → none |  |  |
| 3444 | **MP7 - Service Activation Implementation** |  | 2026-07-28 A |  | 43% → 100% | 0d → none |  |  |
| 3447 | Market Entry to obtain Effective from Date from PP | 2026-07-01 A | 2026-07-01 A |  | 0% → 100% |  |  |  |
| 3448 | PP Qualified by Code Bodies | 2026-07-15 A | 2026-07-15 A |  | 0% → 100% |  | 2753 → none |  |
| 3449 | DIP Promoted to Production | 2026-07-16 A | 2026-07-22 A |  | 0% → 100% |  | 3448 → none |  |
| 3450 | Create M16 in Customer Solution | 2026-07-16 A | 2026-07-16 A |  | 0% → 100% |  |  |  |
| 3451 | MDD & ISD Publish | 2026-07-20 A | 2026-07-20 A |  | 0% → 100% |  |  |  |
| 3452 | MDD & ISD Go-Live | 2026-07-27 A | 2026-07-27 A |  | 0% → 100% |  |  |  |
| 3453 | MP7 - Service Activation Implementation Complete (M) | 2026-07-28 A | 2026-07-28 A |  | 0% → 100% |  |  |  |
| 3454 | **MP7 - Service Activation Implementation MDD** | 2026-07-16 A | 2026-07-17 A |  | 0% → 100% | 374d → none |  |  |
| 3455 | MDD Final Circular Completed | 2026-07-17 A | 2026-07-17 A |  | 0% → 100% | 375d → none |  |  |
| 3456 | MDD Manual Update | 2026-07-16 A | 2026-07-17 A |  | 0% → 100% | 374d → none |  |  |
| 3457 | **Migration Pathway 8 (MP8)** |  |  |  | 11% → 22% |  |  |  |
| 3458 | **MP8 - Service Activation Implementation** |  |  |  | 11% → 22% |  |  |  |
| 3460 | Market Entry to obtain Effective from Date from PP | 2026-07-16 A | 2026-07-16 A |  | 0% → 100% | 375d → none |  |  |
| 3461 | PP Qualified by Code Bodies |  |  |  |  |  | 2753 → none |  |
| 3467 | **Migration Pathway 9 (MP9)** | 2026-06-18 A |  |  | 0% → 38% | 40d → 348d |  |  |
| 3468 | **MP9 - Service Activation Implementation** | 2026-06-18 A |  |  | 0% → 43% |  |  |  |
| 3469 | PP to agree Effective from Date 40WD ahead of target PAB | 2026-06-18 A | 2026-06-18 A |  | 0% → 100% | 395d → none |  |  |
| 3470 | PP to submit MDD Change Request | 2026-06-18 A | 2026-06-24 A |  | 0% → 100% | 391d → none |  |  |
| 3472 | PP Qualified by Code Bodies |  |  |  |  |  | 2753 → none |  |
| 3481 | **Migration Pathway 10 (MP10)** | 2026-07-03 A |  |  | 0% → 11% |  |  |  |
| 3482 | **MP10 - Service Activation Implementation** | 2026-07-03 A |  |  | 0% → 11% |  |  |  |
| 3483 | PP to agree Effective from Date 40WD ahead of target PAB | 2026-07-03 A | 2026-07-03 A |  | 0% → 100% | 384d → none |  |  |
| 3485 | PP Qualified by Code Bodies |  |  |  |  |  | 2753 → none |  |
| 3491 | **Migration Pathway 11 (MP11)** | 2026-07-13 A |  |  | 0% → 38% | 23d → 328d |  |  |
| 3492 | **MP11 - Service Activation Implementation** | 2026-07-13 A |  |  | 0% → 43% |  |  |  |
| 3493 | PP to agree Effective from Date 40WD ahead of target PAB | 2026-07-13 A | 2026-07-13 A |  | 0% → 100% | 378d → none |  |  |
| 3494 | PP to submit MDD Change Request | 2026-07-13 A | 2026-07-17 A |  | 0% → 100% | 374d → none |  |  |
| 3496 | PP Qualified by Code Bodies |  |  |  |  |  | 2753 → none |  |
| 3505 | **Migration Pathway 12a (MP12a)** | 2026-07-29 A |  |  | 0% → 11% |  |  |  |
| 3506 | **MP12a - Service Activation Implementation** | 2026-07-29 A |  |  | 0% → 11% |  |  |  |
| 3507 | PP to agree Effective from Date 40WD ahead of target PAB | 2026-07-29 A | 2026-07-29 A |  | 0% → 100% | 366d → none |  |  |
| 3515 | **Migration Pathway 12b (MP12b)** | 2026-07-29 A |  |  | 0% → 6% | 56d → 303d |  |  |
| 3516 | **MP12b - Service Activation Implementation** | 2026-07-29 A |  |  | 0% → 7% |  |  |  |
| 3517 | PP to agree Effective from Date 40WD ahead of target PAB | 2026-07-29 A | 2026-07-29 A |  | 0% → 100% | 366d → none |  |  |
| 3545 | **M16: Decision Approach** |  |  | 95d → 95d? | 99% → 100% |  |  |  |
| 3550 | **Consult and Agree with Industry** |  |  | 94d → 94d? | 99% → 100% |  |  |  |
| 3566 | **M16 Decision Making and Monitoring Criteria Consultation - Decisions 1 and 2** |  | 2026-06-23 → 2026-07-07 A (+14d) | 62d → 72d | 99% → 100% | -19d → none |  | was named M16 Decision Making and Monitoring Criteria Consultation; baseline start none → 2026-03-27; baseline finish none → 2026-07-07 |
| 3567 | Prepare Consultation material |  |  |  |  |  |  | was named Prepare consultation material |
| 3571 | Materials Issued for Approval at eMCAG | 2026-06-16 → 2026-06-30 A (+14d) | 2026-06-16 → 2026-06-30 A (+14d) |  | 0% → 100% | -50d → none |  | was named Materials Issued for Approval at MCAG; constraint start no earlier than 2026-06-16 → start no earlier than 2026-06-30; baseline start 2026-06-16 → 2026-06-30; baseline finish 2026-06-16 → 2026-06-30 |
| 3572 | Decision 1 (RF to 7 months) and Decision 2 (RF to 4 months) Criteria approved at eMCAG | 2026-06-23 → 2026-07-07 A (+14d) | 2026-06-23 → 2026-07-07 A (+14d) |  | 0% → 100% | -50d → none |  | was named M16 Approach Approved at MCAG; constraint start no earlier than 2026-06-23 → start no earlier than 2026-07-07; baseline start 2026-06-23 → 2026-07-07; baseline finish 2026-06-23 → 2026-07-07 |
| 3573 | **M16: Monitoring Period** | 2026-04-15 A → 2026-04-15 |  |  |  |  |  |  |
| 3575 | **M16: Decision Points** |  |  | 245d → 245d? |  |  |  |  |
| 3576 | **STEG to Assess Monitoring Report and recommend interim position to MCAG on Decision 1** | 2026-07-13 → 2026-08-19 (+37d) | 2026-07-17 → 2026-08-25 (+39d) |  |  |  |  | baseline start 2026-07-13 → 2026-08-19; baseline finish 2026-07-17 → 2026-08-25 |
| 3577 | STEG Issue position to MCAG notifying Decision Checkpoint 1 On-track | 2026-07-15 → 2026-08-19 (+35d) | 2026-07-15 → 2026-08-19 (+35d) |  |  | 344d → 352d | STEG 5 → none | constraint start no earlier than 2026-07-15 → start no earlier than 2026-08-19; baseline start 2026-07-15 → 2026-08-19; baseline finish 2026-07-15 → 2026-08-19 |
| 3578 | MCAG endorses STEG Assessment that M16 likely to be met | 2026-07-17 → 2026-08-25 (+39d) | 2026-07-17 → 2026-08-25 (+39d) |  |  | 344d → 348d | 3577FS+3d → none | was named MCAG Endorses Assessment; constraint start no earlier than 2026-07-15 → start no earlier than 2026-08-25; baseline start 2026-07-17 → 2026-08-25; baseline finish 2026-07-17 → 2026-08-25 |
| 3579 | M16 Checkpoint 1 | 2026-07-17 → 2026-08-25 (+39d) | 2026-07-17 → 2026-08-25 (+39d) |  |  | 374d → 348d |  | constraint finish no earlier than 2026-07-17 → none; baseline start 2026-07-17 → 2026-08-25; baseline finish 2026-07-17 → 2026-08-25 |
| 3580 | **Decision 1 RF Change to 7 months from Settlement Day 01/10** | 2026-09-14 → 2026-09-01 (-13d) |  | 5d → 14d |  |  |  | baseline start 2026-09-14 → 2026-09-01 |

| ID | Task | Start | Finish | Duration | Complete | Total float | Predecessors | Other |
| --- | --- | --- | --- | --- | --- | --- | --- | --- |
| 3582 | STEG to compare Monitoring report against agreed Assessment Criteria | 2026-09-14 → 2026-09-08 (-6d) | 2026-09-14 → 2026-09-08 (-6d) |  |  | 329d → 333d | STEG 9 → none | was named STEG to compare Monitoring report against agreed assessment criteria; constraint start no earlier than 2026-09-14 → start no earlier than 2026-09-08; baseline start 2026-09-14 → 2026-09-08; baseline finish 2026-09-14 → 2026-09-08 |
| 3583 | STEG Issue recommendation to MCAG | 2026-09-14 → 2026-09-08 (-6d) | 2026-09-14 → 2026-09-08 (-6d) |  |  | 334d → 337d |  | constraint start no earlier than 2026-09-14 → finish no earlier than 2026-09-08 |
| 3584 | eMCAG Approve Recommendation to Change to RF 7 Months Calendar | 2026-09-18 → 2026-09-15 (-3d) | 2026-09-18 → 2026-09-15 (-3d) |  |  | 329d → 333d |  | was named MCAG Approve Recommendation to change to RF 7 months calendar; constraint finish no earlier than 2026-09-18 → start no earlier than 2026-09-15; baseline start 2026-09-18 → 2026-09-15; baseline finish 2026-09-18 → 2026-09-15 |
| 3585 | Decision 1 - RF 7 Months | 2026-09-18 → 2026-09-15 (-3d) | 2026-09-18 → 2026-09-15 (-3d) |  |  | 329d → 332d |  | constraint finish no earlier than 2026-09-18 → finish no earlier than 2026-09-15; baseline start 2026-09-18 → 2026-09-15; baseline finish 2026-09-18 → 2026-09-15 |
| 3588 | STEG to compare Monitoring report against agreed assessment criteria |  |  |  |  |  | STEG 22 → none |  |
| 3593 | STEG to compare Monitoring report against agreed assessment criteria |  |  |  |  |  |  | baseline start 2027-06-16 → 2027-06-14; baseline finish 2027-06-16 → 2027-06-14 |
| 3594 | STEG Issue recommendation to MCAG |  |  |  |  |  |  | baseline start 2027-06-22 → 2027-06-18; baseline finish 2027-06-22 → 2027-06-18 |
| 3595 | MCAG Approve Recommendation - Confirm M16 Date |  |  |  |  |  |  | baseline start 2027-06-22 → 2027-06-18; baseline finish 2027-06-22 → 2027-06-18 |
| 3596 | Decision 3 - SF 7WD |  |  |  |  |  |  | baseline start 2027-06-22 → 2027-06-18; baseline finish 2027-06-22 → 2027-06-18 |
| 3605 | **Post Decision 3** |  | 2027-04-02 → 2027-06-17 (+76d) | 20d → 74d |  |  |  | baseline start 2027-04-02 → 2027-03-08 |
| 3677 | **Readiness Assessment 8 - Ready for New Settlement Timetable** | 2026-08-06 → 2026-07-01 A (-36d) | 2026-10-13 → 2026-09-02 (-41d) | 49d → 46d | 0% → 22% | 312d → none |  | baseline start 2026-08-06 → 2026-07-01; baseline finish 2026-10-13 → 2026-09-02 |
| 3678 | Launch Readiness Assessment survey | 2026-08-06 → 2026-07-01 A (-36d) | 2026-08-06 → 2026-07-01 A (-36d) |  | 0% → 100% | 312d → none | 2755FS-60d → none | constraint none → start no earlier than 2026-07-01; baseline start 2026-08-06 → 2026-07-01; baseline finish 2026-08-06 → 2026-07-01 |
| 3679 | PPs submit survey responses | 2026-08-06 → 2026-07-01 A (-36d) | 2026-08-26 → 2026-07-29 A (-28d) | 15d → 21d | 0% → 100% | 312d → none |  | baseline start 2026-08-06 → 2026-07-01; baseline finish 2026-08-26 → 2026-07-29 |
| 3680 | Analyse survey responses | 2026-08-27 → 2026-07-30 (-28d) | 2026-09-16 → 2026-09-02 (-14d) | 15d → 25d |  | 312d → 341d |  | baseline start 2026-08-27 → 2026-07-30; baseline finish 2026-09-16 → 2026-09-02 |
| 3681 | Conduct deep-dive interviews (sample of PPs) | 2026-08-27 → 2026-07-30 (-28d) | 2026-09-16 → 2026-09-02 (-14d) | 15d → 25d |  | 312d → 341d | 3679 → none | constraint none → start no earlier than 2026-07-30; baseline start 2026-08-27 → 2026-07-30; baseline finish 2026-09-16 → 2026-09-02 |
| 3682 | Produce Readiness Assessment Reports (Overall Report & Individual Participant Reports) | 2026-09-17 → 2026-07-30 (-49d) | 2026-10-07 → 2026-09-02 (-35d) | 15d → 25d |  | 312d → 341d | 3680, 3681 → none | constraint none → start no earlier than 2026-07-30; baseline start 2026-09-17 → 2026-07-30; baseline finish 2026-10-07 → 2026-09-02 |
| 3683 | Readiness Assessment 8 - Ready for New Settlement Timetable - Completed (incl. Readiness Assessment Report approval) | 2026-10-13 → 2026-09-02 (-41d) | 2026-10-13 → 2026-09-02 (-41d) |  |  | 312d → 342d | 3682FS+4d → none | was named Readiness Assessment 8 - Ready to Accept New MPANs - Completed (incl. Readiness Assessment Report approval); constraint none → start no earlier than 2026-09-02; baseline start 2026-10-13 → 2026-09-02; baseline finish 2026-10-13 → 2026-09-02 |
| 3694 | Readiness Assessment 8 - Ready for New Settlement Timetable - Completed (incl. Readiness Assessment Report approval) | 2026-08-14 → 2026-09-02 (+19d) | 2026-08-14 → 2026-09-02 (+19d) |  |  | 355d → 342d |  | constraint start no earlier than 2026-08-14 → start no earlier than 2026-09-02; baseline start 2026-08-14 → 2026-09-02; baseline finish 2026-08-14 → 2026-09-02 |
| 3714 | **MILESTONE RANGE CHECKPOINTS** |  |  | 402d → 402d? |  |  |  |  |
| 3717 | **M14 milestone checkpoint** | 2026-08-06 → 2026-08-11 (+5d) | 2026-08-06 → 2026-10-27 (+82d) | 0d → 56d? |  | 361d → none |  | baseline start 2026-08-06 → 2026-08-11; baseline finish 2026-08-06 → 2026-10-27 |
| 3718 | M14 Checkpoint: QWG to assess M14 delivery confidence against the Acceptance Criteria | 2026-08-06 → 2026-08-11 (+5d) | 2026-08-06 → 2026-08-11 (+5d) |  |  | 361d → 358d | 2755FS-3mo → none | was named M14 milestone checkpoint - date approval; constraint none → start no earlier than 2026-08-11; baseline start 2026-08-06 → 2026-08-11; baseline finish 2026-08-06 → 2026-08-11 |

## Version 32 (data date 2026-08-12, saved 2026-08-12, file MHHS-DEL1139 - MHHS Plan v6.56.mpp)

Last finish stays 2027-12-23. Complete tasks 2759 → 2776.

Changed:

| ID | Task | Start | Finish | Complete | Total float | Other |
| --- | --- | --- | --- | --- | --- | --- |
| 3 | **PROGRAMME MANAGEMENT** |  |  | 90% → 91% |  |  |
| 4 | **Programme Management** |  |  | 90% → 91% |  |  |
| 5 | Sprint-based prioritisation planning and execution |  |  | 90% → 91% |  |  |
| 6 | Programme governance secretariat |  |  | 90% → 91% |  |  |
| 7 | RAID management and reporting |  |  | 90% → 91% |  |  |
| 8 | Tracking against Programme outcomes and KPIs |  |  | 90% → 91% |  |  |
| 9 | Change control and reporting |  |  | 90% → 91% |  |  |
| 10 | Ongoing identification of lessons learned relating to the PMO and implementation of improvements |  |  | 90% → 91% |  |  |
| 11 | **Programme Internal Assurance Reviews** |  |  | 90% → 91% |  |  |
| 12 | Programme Internal Assurance Reviews |  |  | 90% → 91% |  |  |
| 13 | **Engagement with PPs** |  |  | 90% → 91% |  |  |
| 14 | Ongoing PP liaison activities |  |  | 90% → 91% |  |  |
| 15 | Milestone and Control Point objective setting |  |  | 90% → 91% |  |  |
| 16 | Reporting |  |  | 90% → 91% |  |  |
| 17 | **PP Engagement Events** |  |  | 90% → 91% |  |  |
| 18 | Bilateral meetings |  |  | 90% → 91% |  |  |
| 19 | Monthly webinars |  |  | 90% → 91% |  |  |
| 20 | Open days |  |  | 90% → 91% |  |  |
| 21 | **PP Communications** |  |  | 90% → 91% |  |  |
| 22 | The Clock updates (weekly) |  |  | 90% → 91% |  |  |
| 23 | Maintain and update content on public-facing Portal (and ongoing feedback reviews to identify and implement Portal improvements) |  |  | 90% → 91% |  |  |
| 24 | **Code Change Support / Other Programme Alignment** |  |  | 90% → 91% |  |  |
| 25 | Support DCC/BEIS on SEC change |  |  | 90% → 91% |  |  |
| 26 | Support on Smart Meters Act changes |  |  | 90% → 91% |  |  |
| 27 | Support DCC/RECCo on CSS change |  |  | 90% → 91% |  |  |
| 28 | Support Elexon on BSC change |  |  | 90% → 91% |  |  |
| 29 | Support code change inside & outside CCIAG |  |  | 90% → 91% |  |  |
| 30 | Support code change inside & outside CCAG |  |  | 90% → 91% |  |  |
| 56 | **Establish Design Change Management Processes** |  |  | 88% → 89% |  |  |
| 61 | Maintain E2E MHHS Design (post-M5 design change management processes operational) |  |  | 88% → 89% |  |  |
| 1466 | Update the documents on loading tests into ADO |  |  |  |  | was named Update the documents on loading tests into ADO? |
| 1724 | **Onboarding and Test Data (Sandbox UIT)** |  |  | 95% → 97% |  |  |
| 1726 | Supplier & Agent Onboarding and Test Data Creation and Support |  |  | 92% → 95% |  |  |
| 1727 | **Sandbox Execution** |  |  | 95% → 98% |  |  |
| 1737 | **Sandbox Testing Execution (UIT) - Supplier & Agent Participants** |  |  | 92% → 95% |  |  |
| 1740 | Sandbox Testing Execution (UIT) - Supplier & Agent Participants |  |  | 92% → 95% |  |  |
| 2378 | **MHHS Qualification - SIT Participants** |  | 2026-07-30 A | 99% → 100% | 366d → none |  |
| 2405 | **MHHS Qualification - Not M11-Ready** |  | 2026-07-30 A | 99% → 100% | 366d → none |  |
| 2414 | SIT Participants are Qualified | 2026-07-30 A | 2026-07-30 A | 0% → 100% | 366d → none |  |
| 2721 | 80% of M14 Critical Wave 3 Participants Qualification approved by BSC PAB and REC Manager | 2026-07-30 A | 2026-07-30 A | 0% → 100% | 366d → none |  |
| 2746 | **Qualification Wave 4 Exit** |  |  | 96% → 98% |  |  |
| 2751 | Completion of Code Bodies review of Final QAD |  |  | 78% → 88% | 0.62d → 0.86d |  |
| 2752 | QAD Sign Off deadline |  |  | 62% → 86% |  |  |
| 2791 | PAB2026/13 | 2026-07-30 A | 2026-07-30 A | 0% → 100% | 365d → none |  |
| 2792 | PAB2026/14 | 2026-08-12 A | 2026-08-12 A | 0% → 100% | 356d → none |  |
| 3174 | **Preparation for Cutover to Live** |  |  | 75% → 76% |  |  |
| 3266 | **Migration Sprints** |  |  | 47% → 50% |  |  |
| 3298 | **Migration Sprint 3** |  |  | 77% → 93% |  |  |
| 3305 | Sprint Execution |  | 2026-08-04 A | 91% → 100% | 352d → none |  |
| 3306 | Sprint Execution End | 2026-08-04 A | 2026-08-04 A | 0% → 100% | 352d → none |  |
| 3307 | Sprint 3 Retro | 2026-08-05 A |  | 0% → 60% |  |  |
| 3308 | **Migration Sprint 4** |  |  | 10% → 18% |  |  |
| 3314 | Sprint Execution Start | 2026-08-05 A | 2026-08-05 A | 0% → 100% | 307d → none |  |
| 3315 | Sprint Execution | 2026-08-06 A |  | 0% → 11% |  |  |
| 3381 | **Service Management** |  |  | 94% → 96% |  |  |
| 3433 | **Migration Pathway 6 (MP6)** |  |  | 43% → 55% |  |  |
| 3457 | **Migration Pathway 8 (MP8)** |  | 2026-08-11 A | 22% → 100% | 358d → none |  |
| 3458 | **MP8 - Service Activation Implementation** |  | 2026-08-11 A | 22% → 100% | 358d → none |  |
| 3461 | PP Qualified by Code Bodies | 2026-07-30 A | 2026-07-30 A | 0% → 100% | 360d → none |  |
| 3462 | DIP Promoted to Production | 2026-07-31 A | 2026-08-06 A | 0% → 100% | 360d → none |  |
| 3463 | Create M16 in Customer Solution | 2026-07-31 A | 2026-07-31 A | 0% → 100% | 359d → none |  |
| 3464 | ISD Publish | 2026-08-03 A | 2026-08-03 A | 0% → 100% | 358d → none |  |
| 3465 | ISD Go-Live | 2026-08-10 A | 2026-08-10 A | 0% → 100% | 358d → none |  |
| 3466 | MP8 - Service Activation Implementation Complete (M) | 2026-08-11 A | 2026-08-11 A | 0% → 100% | 358d → none |  |
| 3467 | **Migration Pathway 9 (MP9)** |  |  | 38% → 44% |  |  |
| 3468 | **MP9 - Service Activation Implementation** |  |  | 43% → 50% |  |  |
| 3471 | Market Entry to obtain Effective from Date from PP | 2026-07-29 A | 2026-07-29 A | 0% → 100% | 366d → none |  |
| 3472 | PP Qualified by Code Bodies | 2026-08-12 A | 2026-08-12 A | 0% → 100% | 351d → none |  |
| 3515 | **Migration Pathway 12b (MP12b)** |  |  | 6% → 38% |  |  |
| 3516 | **MP12b - Service Activation Implementation** |  |  | 7% → 43% |  |  |

| ID | Task | Start | Finish | Complete | Total float |
| --- | --- | --- | --- | --- | --- |
| 3518 | PP to submit MDD Change Request | 2026-07-29 A | 2026-08-04 A | 0% → 100% | 362d → none |
| 3655 | **READINESS ASSESSMENTS** |  |  | 60% → 66% |  |
| 3677 | **Readiness Assessment 8 - Ready for New Settlement Timetable** |  |  | 22% → 43% |  |
| 3680 | Analyse survey responses | 2026-07-30 A |  | 0% → 40% |  |
| 3681 | Conduct deep-dive interviews (sample of PPs) | 2026-07-30 A |  | 0% → 40% |  |
| 3717 | **M14 milestone checkpoint** | 2026-08-11 A |  |  |  |
| 3718 | M14 Checkpoint: QWG to assess M14 delivery confidence against the Acceptance Criteria | 2026-08-11 A | 2026-08-11 A | 0% → 100% | 358d → none |

## Version 33 (data date 2026-08-26, saved 2026-08-26, file MHHS-DEL1139 - MHHS Plan v6.57.mpp)

Last finish stays 2027-12-23. Complete tasks 2776 → 2790.

Changed:

| ID | Task | Start | Finish | Complete | Total float | Other |
| --- | --- | --- | --- | --- | --- | --- |
| 1 | **PROGRAMME PLAN.** |  |  | 95% → 96% |  |  |
| 3 | **PROGRAMME MANAGEMENT** |  |  | 91% → 92% |  |  |
| 4 | **Programme Management** |  |  | 91% → 92% |  |  |
| 5 | Sprint-based prioritisation planning and execution |  |  | 91% → 92% |  |  |
| 6 | Programme governance secretariat |  |  | 91% → 92% |  |  |
| 7 | RAID management and reporting |  |  | 91% → 92% |  |  |
| 8 | Tracking against Programme outcomes and KPIs |  |  | 91% → 92% |  |  |
| 9 | Change control and reporting |  |  | 91% → 92% |  |  |
| 10 | Ongoing identification of lessons learned relating to the PMO and implementation of improvements |  |  | 91% → 92% |  |  |
| 11 | **Programme Internal Assurance Reviews** |  |  | 91% → 92% |  |  |
| 12 | Programme Internal Assurance Reviews |  |  | 91% → 92% |  |  |
| 13 | **Engagement with PPs** |  |  | 91% → 92% |  |  |
| 14 | Ongoing PP liaison activities |  |  | 91% → 92% |  |  |
| 15 | Milestone and Control Point objective setting |  |  | 91% → 92% |  |  |
| 16 | Reporting |  |  | 91% → 92% |  |  |
| 17 | **PP Engagement Events** |  |  | 91% → 92% |  |  |
| 18 | Bilateral meetings |  |  | 91% → 92% |  |  |
| 19 | Monthly webinars |  |  | 91% → 92% |  |  |
| 20 | Open days |  |  | 91% → 92% |  |  |
| 21 | **PP Communications** |  |  | 91% → 92% |  |  |
| 22 | The Clock updates (weekly) |  |  | 91% → 92% |  |  |
| 23 | Maintain and update content on public-facing Portal (and ongoing feedback reviews to identify and implement Portal improvements) |  |  | 91% → 92% |  |  |
| 24 | **Code Change Support / Other Programme Alignment** |  |  | 91% → 92% |  |  |
| 25 | Support DCC/BEIS on SEC change |  |  | 91% → 92% |  |  |
| 26 | Support on Smart Meters Act changes |  |  | 91% → 92% |  |  |
| 27 | Support DCC/RECCo on CSS change |  |  | 91% → 92% |  |  |
| 28 | Support Elexon on BSC change |  |  | 91% → 92% |  |  |
| 29 | Support code change inside & outside CCIAG |  |  | 91% → 92% |  |  |
| 30 | Support code change inside & outside CCAG |  |  | 91% → 92% |  |  |
| 46 | **Design Baseline & Enduring PP Support** |  |  | 95% → 96% |  |  |
| 56 | **Establish Design Change Management Processes** |  |  | 89% → 90% |  |  |
| 61 | Maintain E2E MHHS Design (post-M5 design change management processes operational) |  |  | 89% → 90% |  |  |
| 1466 | Update the documents on loading tests into ADO? |  |  |  |  | was named Update the documents on loading tests into ADO |
| 1724 | **Onboarding and Test Data (Sandbox UIT)** |  |  | 97% → 99% |  |  |
| 1726 | Supplier & Agent Onboarding and Test Data Creation and Support |  |  | 95% → 99% |  |  |
| 1727 | **Sandbox Execution** |  |  | 98% → 99% |  |  |
| 1737 | **Sandbox Testing Execution (UIT) - Supplier & Agent Participants** |  |  | 95% → 99% |  |  |
| 1740 | Sandbox Testing Execution (UIT) - Supplier & Agent Participants |  |  | 95% → 99% |  |  |
| 2721 | 80% of M14 Critical Wave 3 Participants Qualification approved by BSC PAB and REC Manager | 2026-07-30 A → 2026-07-30 | 2026-07-30 A → 2026-07-30 | 100% → 0% | none → 366d |  |
| 2746 | **Qualification Wave 4 Exit** |  |  | 98% → 96% |  |  |
| 2751 | Completion of Code Bodies review of Final QAD |  |  | 88% → 78% | 0.86d → 0.62d |  |
| 2752 | QAD Sign Off deadline |  |  | 86% → 62% |  |  |
| 3174 | **Preparation for Cutover to Live** |  |  | 76% → 77% |  |  |
| 3266 | **Migration Sprints** |  |  | 50% → 53% |  |  |
| 3298 | **Migration Sprint 3** |  | 2026-08-18 A | 93% → 100% | 352d → none |  |
| 3307 | Sprint 3 Retro |  | 2026-08-18 A | 60% → 100% | 352d → none |  |
| 3308 | **Migration Sprint 4** |  |  | 18% → 35% |  |  |
| 3315 | Sprint Execution |  |  | 11% → 34% |  |  |
| 3380 | **BUSINESS & OPERATIONAL READINESS** |  |  | 88% → 89% |  |  |
| 3381 | **Service Management** |  |  | 96% → 97% |  |  |
| 3433 | **Migration Pathway 6 (MP6)** |  |  | 55% → 68% |  |  |
| 3467 | **Migration Pathway 9 (MP9)** |  | 2026-08-25 A | 44% → 100% | 348d → none |  |
| 3468 | **MP9 - Service Activation Implementation** |  | 2026-08-25 A | 50% → 100% | 348d → none |  |
| 3473 | DIP Promoted to Production | 2026-08-13 A | 2026-08-19 A | 0% → 100% | 351d → none |  |
| 3474 | Create M16 in Customer Solution | 2026-08-13 A | 2026-08-13 A | 0% → 100% | 350d → none |  |
| 3475 | MDD & ISD Publish | 2026-08-17 A | 2026-08-17 A | 0% → 100% | 348d → none |  |
| 3476 | MDD & ISD Go-Live | 2026-08-24 A | 2026-08-24 A | 0% → 100% | 348d → none |  |
| 3477 | MP9 - Service Activation Implementation Complete (M) | 2026-08-25 A | 2026-08-25 A | 0% → 100% | 348d → none |  |
| 3478 | **MP9 - Service Activation Implementation MDD** | 2026-08-13 A | 2026-08-14 A | 0% → 100% |  |  |
| 3479 | MDD Final Circular Completed | 2026-08-14 A | 2026-08-14 A | 0% → 100% | 355d → none |  |
| 3480 | MDD Manual Update | 2026-08-13 A | 2026-08-14 A | 0% → 100% | 354d → none |  |
| 3481 | **Migration Pathway 10 (MP10)** |  |  | 11% → 22% |  |  |
| 3482 | **MP10 - Service Activation Implementation** |  |  | 11% → 22% |  |  |
| 3484 | Market Entry to obtain Effective from Date from PP | 2026-08-13 A | 2026-08-13 A | 0% → 100% | 355d → none |  |
| 3491 | **Migration Pathway 11 (MP11)** |  |  | 38% → 56% |  |  |
| 3492 | **MP11 - Service Activation Implementation** |  |  | 43% → 50% |  |  |
| 3495 | Market Entry to obtain Effective from Date from PP | 2026-08-25 A | 2026-08-25 A | 0% → 100% | 347d → none |  |
| 3502 | **MP11 - Service Activation Implementation MDD** | 2026-08-13 A |  | 0% → 99% |  |  |
| 3504 | MDD Manual Update | 2026-08-13 A | 2026-08-14 A | 0% → 100% | 354d → none |  |
| 3576 | **STEG to Assess Monitoring Report and recommend interim position to MCAG on Decision 1** | 2026-08-19 A | 2026-08-25 A | 0% → 100% |  |  |

| ID | Task | Start | Finish | Duration | Complete | Total float |
| --- | --- | --- | --- | --- | --- | --- |
| 3577 | STEG Issue position to MCAG notifying Decision Checkpoint 1 On-track | 2026-08-19 A | 2026-08-19 A |  | 0% → 100% | 352d → none |
| 3578 | MCAG endorses STEG Assessment that M16 likely to be met | 2026-08-25 A | 2026-08-25 A |  | 0% → 100% | 348d → none |
| 3579 | M16 Checkpoint 1 | 2026-08-25 A | 2026-08-25 A |  | 0% → 100% | 348d → none |
| 3597 | **M16: Creation & Implementation of Updated Settlement Calendars** | 2026-03-09 → 2027-01-04 (+301d) |  | 334d → 119d |  | none → 0d |
| 3655 | **READINESS ASSESSMENTS** |  |  |  | 66% → 78% |  |
| 3677 | **Readiness Assessment 8 - Ready for New Settlement Timetable** |  |  |  | 43% → 84% |  |
| 3680 | Analyse survey responses |  |  |  | 40% → 80% |  |
| 3681 | Conduct deep-dive interviews (sample of PPs) |  |  |  | 40% → 80% |  |
| 3682 | Produce Readiness Assessment Reports (Overall Report & Individual Participant Reports) | 2026-07-30 A |  |  | 0% → 80% |  |
| 3719 | M14 checkpoint: QAG to assess M14 delivery confidence against the Acceptance Criteria | 2026-08-18 A | 2026-08-18 A |  | 0% → 100% | 353d → none |

## Version 34 (data date 2026-09-09, saved 2026-09-09, file MHHS-DEL1139 - MHHS Plan v6.58.mpp)

Last finish stays 2027-12-23. Complete tasks 2790 → 2813.

Changed:

| ID | Task | Start | Finish | Complete | Total float | Predecessors | Other |
| --- | --- | --- | --- | --- | --- | --- | --- |
| 3 | **PROGRAMME MANAGEMENT** |  |  | 92% → 93% |  |  |  |
| 4 | **Programme Management** |  |  | 92% → 93% |  |  |  |
| 5 | Sprint-based prioritisation planning and execution |  |  | 92% → 93% |  |  |  |
| 6 | Programme governance secretariat |  |  | 92% → 93% |  |  |  |
| 7 | RAID management and reporting |  |  | 92% → 93% |  |  |  |
| 8 | Tracking against Programme outcomes and KPIs |  |  | 92% → 93% |  |  |  |
| 9 | Change control and reporting |  |  | 92% → 93% |  |  |  |
| 10 | Ongoing identification of lessons learned relating to the PMO and implementation of improvements |  |  | 92% → 93% |  |  |  |
| 11 | **Programme Internal Assurance Reviews** |  |  | 92% → 93% |  |  |  |
| 12 | Programme Internal Assurance Reviews |  |  | 92% → 93% |  |  |  |
| 13 | **Engagement with PPs** |  |  | 92% → 93% |  |  |  |
| 14 | Ongoing PP liaison activities |  |  | 92% → 93% |  |  |  |
| 15 | Milestone and Control Point objective setting |  |  | 92% → 93% |  |  |  |
| 16 | Reporting |  |  | 92% → 93% |  |  |  |
| 17 | **PP Engagement Events** |  |  | 92% → 93% |  |  |  |
| 18 | Bilateral meetings |  |  | 92% → 93% |  |  |  |
| 19 | Monthly webinars |  |  | 92% → 93% |  |  |  |
| 20 | Open days |  |  | 92% → 93% |  |  |  |
| 21 | **PP Communications** |  |  | 92% → 93% |  |  |  |
| 22 | The Clock updates (weekly) |  |  | 92% → 93% |  |  |  |
| 23 | Maintain and update content on public-facing Portal (and ongoing feedback reviews to identify and implement Portal improvements) |  |  | 92% → 93% |  |  |  |
| 24 | **Code Change Support / Other Programme Alignment** |  |  | 92% → 93% |  |  |  |
| 25 | Support DCC/BEIS on SEC change |  |  | 92% → 93% |  |  |  |
| 26 | Support on Smart Meters Act changes |  |  | 92% → 93% |  |  |  |
| 27 | Support DCC/RECCo on CSS change |  |  | 92% → 93% |  |  |  |
| 28 | Support Elexon on BSC change |  |  | 92% → 93% |  |  |  |
| 29 | Support code change inside & outside CCIAG |  |  | 92% → 93% |  |  |  |
| 30 | Support code change inside & outside CCAG |  |  | 92% → 93% |  |  |  |
| 56 | **Establish Design Change Management Processes** |  |  | 90% → 91% |  |  |  |
| 61 | Maintain E2E MHHS Design (post-M5 design change management processes operational) |  |  | 90% → 91% |  |  |  |
| 507 | **SYSTEMS INTEGRATION TESTING (SIT)** |  |  | 99% → 100% |  |  |  |
| 1673 | **UIT Environment Preparation** |  | 2026-08-28 A | 99% → 100% | 344d → none |  |  |
| 1724 | **Onboarding and Test Data (Sandbox UIT)** |  | 2026-08-28 A | 99% → 100% | 344d → none |  |  |
| 1726 | Supplier & Agent Onboarding and Test Data Creation and Support |  | 2026-08-28 A | 99% → 100% | 344d → none |  |  |
| 1727 | **Sandbox Execution** |  | 2026-08-28 A | 99% → 100% | 344d → none |  |  |
| 1737 | **Sandbox Testing Execution (UIT) - Supplier & Agent Participants** |  | 2026-08-28 A | 99% → 100% | 344d → none |  |  |
| 1740 | Sandbox Testing Execution (UIT) - Supplier & Agent Participants |  | 2026-08-28 A | 99% → 100% | 344d → none |  |  |
| 1741 | Sandbox Testing End (UIT) - Supplier & Agent Participants | 2026-08-28 A | 2026-08-28 A | 0% → 100% | 344d → none |  |  |
| 2685 | **Qualification Wave 3** |  | 2026-07-30 A | 99% → 100% | 365d → none |  |  |
| 2713 | **Qualification Wave 3 Exit** |  | 2026-07-30 A | 99% → 100% | 365d → none |  |  |
| 2721 | 80% of M14 Critical Wave 3 Participants Qualification approved by BSC PAB and REC Manager | 2026-07-30 A | 2026-07-30 A | 0% → 100% | 366d → none |  |  |
| 2722 | All M14 Critical Wave 3 Participants Qualification approved by BSC PAB and REC Manager | 2026-07-30 A | 2026-07-30 A | 0% → 100% | 365d → none |  |  |
| 2746 | **Qualification Wave 4 Exit** |  |  | 96% → 99% |  |  |  |
| 2751 | Completion of Code Bodies review of Final QAD |  |  | 78% → 98% | 0.62d → 0.98d |  |  |
| 2752 | QAD Sign Off deadline |  |  | 62% → 98% |  |  |  |
| 2793 | PAB2026/15 | 2026-08-27 A | 2026-08-27 A | 0% → 100% | 345d → none |  |  |
| 2794 | PAB2026/16 | 2026-09-09 A | 2026-09-09 A | 0% → 100% | 336d → none |  |  |
| 3174 | **Preparation for Cutover to Live** |  |  | 77% → 78% |  |  |  |
| 3266 | **Migration Sprints** |  |  | 53% → 55% |  |  |  |
| 3308 | **Migration Sprint 4** |  |  | 35% → 52% |  |  |  |
| 3315 | Sprint Execution |  |  | 34% → 57% |  |  |  |
| 3318 | **Migration Sprint 5** | 2026-09-09 A |  | 0% → 2% |  |  |  |
| 3319 | Sprint 5 Planning start date | 2026-09-09 A |  | 0% → 17% |  |  |  |
| 3381 | **Service Management** |  |  | 97% → 98% |  |  |  |
| 3433 | **Migration Pathway 6 (MP6)** |  |  | 68% → 75% |  |  |  |
| 3481 | **Migration Pathway 10 (MP10)** |  |  | 22% → 100% |  |  |  |
| 3482 | **MP10 - Service Activation Implementation** |  |  | 22% → 100% |  |  |  |
| 3485 | PP Qualified by Code Bodies | 2026-08-27 A | 2026-08-27 A | 0% → 100% | 340d → none |  |  |
| 3486 | DIP Promoted to Production | 2026-08-28 A | 2026-09-03 A | 0% → 100% | 340d → none |  |  |
| 3487 | Create M16 in Customer Solution | 2026-08-28 A | 2026-08-28 A | 0% → 100% | 339d → none |  |  |
| 3488 | ISD Publish | 2026-09-01 A | 2026-09-01 A | 0% → 100% | 337d → none |  |  |
| 3489 | ISD Go-Live | 2026-09-08 A | 2026-09-08 A | 0% → 100% | 337d → none |  |  |
| 3490 | MP10 - Service Activation Implementation Complete (M) | 2026-09-09 A | 2026-09-09 A | 0% → 100% | 337d → none |  |  |
| 3496 | PP Qualified by Code Bodies | 2026-09-09 A | 2026-09-09 A | 0% → 100% | 331d → none |  |  |
| 3575 | **M16: Decision Points** |  |  | 0% → 50% |  |  |  |
| 3580 | **Decision 1 RF Change to 7 months from Settlement Day 01/10** |  |  | 0% → 50% |  |  |  |
| 3581 | Update Monitoring Data to be provided from Performance Assurance and MCC | 2026-09-01 → 2026-08-14 A (-18d) | 2026-09-01 → 2026-08-14 A (-18d) | 0% → 100% | 342d → none |  | constraint start no earlier than 2026-09-01 → start no earlier than 2026-08-14 |
| 3582 | STEG to compare Monitoring report against agreed Assessment Criteria | 2026-09-08 → 2026-09-02 A (-6d) | 2026-09-08 → 2026-09-02 A (-6d) | 0% → 100% | 333d → none | none → 3581 | constraint start no earlier than 2026-09-08 → start no earlier than 2026-09-02; baseline start 2026-09-08 → 2026-09-02; baseline finish 2026-09-08 → 2026-09-02 |
| 3583 | STEG Issue recommendation to eMCAG |  |  |  |  |  | was named STEG Issue recommendation to MCAG |
| 3588 | STEG to compare Monitoring report against agreed assessment criteria | 2027-03-15 → 2027-03-10 (-5d) | 2027-03-15 → 2027-03-10 (-5d) |  | 199d → 202d |  | constraint start no earlier than 2027-03-15 → start no earlier than 2027-03-10; baseline start 2027-03-15 → 2027-03-10; baseline finish 2027-03-15 → 2027-03-10 |

| ID | Task | Start | Finish | Duration | Complete | Total float | Predecessors | Other |
| --- | --- | --- | --- | --- | --- | --- | --- | --- |
| 3589 | STEG Issue recommendation to MCAG | 2027-03-19 → 2027-03-16 (-3d) | 2027-03-19 → 2027-03-16 (-3d) |  |  | 199d → 202d |  | constraint finish no earlier than 2027-03-19 → start no earlier than 2027-03-16; baseline start 2027-03-19 → 2027-03-16; baseline finish 2027-03-19 → 2027-03-16 |
| 3590 | MCAG Approve recommendation | 2027-03-19 → 2027-03-23 (+4d) | 2027-03-19 → 2027-03-23 (+4d) |  |  | 199d → 198d |  | constraint finish no earlier than 2027-03-19 → start no earlier than 2027-03-23; baseline start 2027-03-19 → 2027-03-23; baseline finish 2027-03-19 → 2027-03-23 |
| 3591 | Decision 2 - RF 4 Months | 2027-03-19 → 2027-03-23 (+4d) | 2027-03-19 → 2027-03-23 (+4d) |  |  | 199d → 198d |  | baseline start 2027-03-19 → 2027-03-23; baseline finish 2027-03-19 → 2027-03-23 |
| 3593 | STEG to compare Monitoring report against agreed assessment criteria | 2027-06-14 → 2027-06-02 (-12d) | 2027-06-14 → 2027-06-02 (-12d) |  |  | 5d → 13d |  | constraint start no earlier than 2027-06-14 → start no earlier than 2027-06-02; baseline start 2027-06-14 → 2027-06-02; baseline finish 2027-06-14 → 2027-06-02 |
| 3594 | STEG Issue recommendation to eMCAG | 2027-06-18 → 2027-06-15 (-3d) | 2027-06-18 → 2027-06-15 (-3d) |  |  | 5d → 9d |  | was named STEG Issue recommendation to MCAG; constraint finish no earlier than 2027-06-18 → start no earlier than 2027-06-15; baseline start 2027-06-18 → 2027-06-15; baseline finish 2027-06-18 → 2027-06-15 |
| 3595 | MCAG Approve Recommendation - Confirm M16 Date | 2027-06-18 → 2027-06-15 (-3d) | 2027-06-18 → 2027-06-15 (-3d) |  |  | 5d → 9d |  | constraint finish no earlier than 2027-06-18 → start no earlier than 2027-06-15; baseline start 2027-06-18 → 2027-06-15; baseline finish 2027-06-18 → 2027-06-15 |
| 3596 | Decision 3 - SF 7WD | 2027-06-18 → 2027-06-15 (-3d) | 2027-06-18 → 2027-06-15 (-3d) |  |  | 134d → 138d |  | constraint finish no earlier than 2027-06-18 → start no earlier than 2027-06-15; baseline start 2027-06-18 → 2027-06-15; baseline finish 2027-06-18 → 2027-06-15 |
| 3597 | **M16: Creation & Implementation of Updated Settlement Calendars** |  | 2027-06-17 → 2027-07-02 (+15d) | 119d → 130d |  |  |  |  |
| 3604 | Implementation of April - Jun 2027 Calendar | 2027-03-19 → 2027-03-23 (+4d) | 2027-03-19 → 2027-03-23 (+4d) |  |  | 199d → 198d |  | baseline start 2027-03-19 → 2027-03-23; baseline finish 2027-03-19 → 2027-03-23 |
| 3609 | Implementation of July 2027 Calendar | 2027-06-17 → 2027-07-02 (+15d) | 2027-06-17 → 2027-07-02 (+15d) |  |  | 11d → 0d | 3608FS+10d → 3608FS+21d | was named Implementation of Jul - Mar 2027 Calendar; baseline start 2027-06-17 → 2027-07-02; baseline finish 2027-06-17 → 2027-07-02 |
| 3610 | **M16 Approval Window** | 2027-06-25 → 2027-06-21 (-4d) |  | 129d → 133d |  |  |  |  |
| 3611 | Panel approval that M16 criteria met | 2027-06-25 → 2027-06-21 (-4d) | 2027-06-25 → 2027-06-21 (-4d) |  |  | 5d → 9d |  |  |
| 3655 | **READINESS ASSESSMENTS** |  |  |  | 78% → 82% |  |  |  |
| 3677 | **Readiness Assessment 8 - Ready for New Settlement Timetable** |  | 2026-09-02 A |  | 84% → 100% |  |  |  |
| 3680 | Analyse survey responses |  | 2026-09-02 A |  | 80% → 100% | 341d → none |  |  |
| 3681 | Conduct deep-dive interviews (sample of PPs) |  | 2026-09-02 A |  | 80% → 100% | 341d → none |  |  |
| 3682 | Produce Readiness Assessment Reports (Overall Report & Individual Participant Reports) |  | 2026-09-02 A |  | 80% → 100% | 341d → none |  |  |
| 3683 | Readiness Assessment 8 - Ready for New Settlement Timetable - Completed (incl. Readiness Assessment Report approval) | 2026-09-02 A | 2026-09-02 A |  | 0% → 100% | 342d → none |  |  |
| 3694 | Readiness Assessment 8 - Ready for New Settlement Timetable - Completed (incl. Readiness Assessment Report approval) | 2026-09-02 A | 2026-09-02 A |  | 0% → 100% | 342d → none |  |  |
| 3720 | M14 Checkpoint: PSG assesses M14 delivery confidence | 2026-09-02 A | 2026-09-02 A |  | 0% → 100% | 342d → none |  |  |
| 3721 | Notification to Ofgem of no central issues as of QA+P Annex 4 | 2026-09-03 A | 2026-09-03 A |  | 0% → 100% | 341d → none |  |  |

## Version 35 (data date 2026-09-23, saved 2026-09-24, file MHHS-DEL1139 - MHHS Plan v6.59.mpp)

Last finish stays 2027-12-23. Complete tasks 2813 → 2828.

Added:

| ID | Task | Duration | Start | Finish | Constraint |
| --- | --- | --- | --- | --- | --- |
| 2958 | **CR065** | 22d | 2026-06-01 A | 2026-07-01 A |  |
| 2962 | **CR067** | 63d | 2026-09-28 | 2026-12-23 |  |
| 2963 | CR067 Webinar | 1d | 2026-09-28 | 2026-09-28 | start no earlier than 2026-09-28 |
| 2964 | CR067 Impact Assessment Window | 10d | 2026-09-28 | 2026-10-09 | start no earlier than 2026-09-28 |
| 2965 | CR067 PSG Approval | 1d | 2026-11-04 | 2026-11-04 | start no earlier than 2026-11-04 |
| 2966 | CR067 Ofgem Approval | 1d | 2026-12-23 | 2026-12-23 | start no earlier than 2026-12-23 |

Removed: 3684 Readiness Assessment 9 - Ready for New Settlement Timetable and CP5 Check; 3685 Launch Readiness Assessment survey; 3686 PPs submit survey responses; 3687 Analyse survey responses; 3688 Conduct deep-dive interviews (sample of PPs); 3689 Produce Readiness Assessment Reports (Overall Report & Individual Participant Reports); 3690 Readiness Assessment 9 - Readiness for New Settlement Timetable - Completed (incl. Readiness Assessment Report approval); 3695 Readiness Assessment 9 - Readiness for New Settlement Timetable - Completed (incl. Readiness Assessment Report approval)

Changed:

| ID | Task | Start | Finish | Duration | Complete | Total float | Other |
| --- | --- | --- | --- | --- | --- | --- | --- |
| 3 | **PROGRAMME MANAGEMENT** |  |  |  | 93% → 94% |  |  |
| 13 | **Engagement with PPs** |  |  |  | 93% → 94% |  |  |
| 21 | **PP Communications** |  |  |  | 93% → 94% |  |  |
| 22 | The Clock updates (weekly) |  |  |  | 93% → 94% |  |  |
| 23 | Maintain and update content on public-facing Portal (and ongoing feedback reviews to identify and implement Portal improvements) |  |  |  | 93% → 94% |  |  |
| 56 | **Establish Design Change Management Processes** |  |  |  | 91% → 92% |  |  |
| 61 | Maintain E2E MHHS Design (post-M5 design change management processes operational) |  |  |  | 91% → 92% |  |  |
| 2953 | **Regulatory Governance** |  | 2026-07-01 A → 2026-12-23 (+175d) | 587d → 713d | 100% → 96% | none → 261d |  |
| 3180 | **Preparation for Cutover to Live** |  |  |  | 78% → 80% |  |  |
| 3272 | **Migration Sprints** |  |  |  | 55% → 58% |  |  |
| 3314 | **Migration Sprint 4** |  |  |  | 52% → 68% |  |  |
| 3321 | Sprint Execution |  |  |  | 57% → 80% |  |  |
| 3324 | **Migration Sprint 5** |  |  |  | 2% → 11% |  |  |
| 3325 | Sprint 5 Planning start date |  | 2026-09-16 A |  | 17% → 100% | 267d → none |  |
| 3326 | Issue Envelope | 2026-09-16 A | 2026-09-16 A |  | 0% → 100% | 267d → none |  |
| 3327 | Supplier Submission Deadline | 2026-09-23 A | 2026-09-23 A |  | 0% → 100% | 267d → none |  |
| 3386 | **BUSINESS & OPERATIONAL READINESS** |  |  |  | 89% → 90% |  |  |
| 3439 | **Migration Pathway 6 (MP6)** |  |  |  | 75% → 84% |  |  |
| 3497 | **Migration Pathway 11 (MP11)** |  | 2026-09-22 A |  | 56% → 100% | 328d → none |  |
| 3498 | **MP11 - Service Activation Implementation** |  | 2026-09-22 A |  | 50% → 100% | 328d → none |  |
| 3503 | DIP Promoted to Production | 2026-09-10 A | 2026-09-16 A |  | 0% → 100% | 331d → none |  |
| 3504 | Create M16 in Customer Solution | 2026-09-10 A | 2026-09-10 A |  | 0% → 100% | 330d → none |  |
| 3505 | MDD & ISD Publish | 2026-09-14 A | 2026-09-14 A |  | 0% → 100% | 328d → none |  |
| 3506 | MDD & ISD Go-Live | 2026-09-21 A | 2026-09-21 A |  | 0% → 100% | 328d → none |  |
| 3507 | MP11 - Service Activation Implementation Complete (M) | 2026-09-22 A | 2026-09-22 A |  | 0% → 100% | 328d → none |  |
| 3508 | **MP11 - Service Activation Implementation MDD** |  |  |  | 99% → 100% |  |  |
| 3509 | MDD Final Circular Completed | 2026-09-11 A | 2026-09-11 A |  | 0% → 100% | 335d → none |  |
| 3511 | **Migration Pathway 12a (MP12a)** |  |  |  | 11% → 22% |  |  |
| 3512 | **MP12a - Service Activation Implementation** |  |  |  | 11% → 22% |  |  |
| 3514 | Market Entry to obtain Effective from Date from PP | 2026-09-10 A | 2026-09-10 A |  | 0% → 100% | 335d → none |  |
| 3521 | **Migration Pathway 12b (MP12b)** |  |  |  | 38% → 44% |  |  |
| 3522 | **MP12b - Service Activation Implementation** |  |  |  | 43% → 50% |  |  |
| 3525 | Market Entry to obtain Effective from Date from PP | 2026-09-10 A | 2026-09-10 A |  | 0% → 100% | 335d → none |  |
| 3581 | **M16: Decision Points** |  |  |  | 50% → 99% |  |  |
| 3586 | **Decision 1 RF Change to 7 months from Settlement Day 01/10** |  |  |  | 50% → 100% |  |  |
| 3589 | STEG Issue recommendation to eMCAG | 2026-09-08 A | 2026-09-08 A |  | 0% → 100% | 337d → none |  |
| 3590 | eMCAG Approve Recommendation to Change to RF 7 Months Calendar | 2026-09-15 A | 2026-09-15 A |  | 0% → 100% | 333d → none |  |
| 3591 | Decision 1 - RF 7 Months | 2026-09-15 A | 2026-09-15 A |  | 0% → 100% | 332d → none |  |
| 3592 | Communication issued to Industry notifying Parties RF will be 7 months | 2026-09-15 A | 2026-09-15 A |  | 0% → 100% | 332d → none |  |
| 3596 | MCAG Approve Recommendation to Change to RF 4 Months Calendar |  |  |  |  |  | was named MCAG Approve recommendation |
| 3598 | **Decision 3 SF Change from 15WD to 7WD from Settlement Date 02/07** | 2027-06-14 → 2027-06-02 (-12d) | 2027-06-18 → 2027-06-15 (-3d) | 5d → 10d |  |  | baseline start 2027-06-14 → 2027-06-02; baseline finish 2027-06-18 → 2027-06-15 |
| 3600 | STEG Issue recommendation to eMCAG | 2027-06-15 → 2027-06-09 (-6d) | 2027-06-15 → 2027-06-09 (-6d) |  |  | 9d → 13d | constraint start no earlier than 2027-06-15 → start no earlier than 2027-06-09; baseline start 2027-06-15 → 2027-06-09; baseline finish 2027-06-15 → 2027-06-09 |
| 3601 | eMCAG Approve Recommendation - Confirm M16 Date |  |  |  |  |  | was named MCAG Approve Recommendation - Confirm M16 Date |
| 3661 | **READINESS ASSESSMENTS** |  | 2027-06-17 → 2026-09-02 A (-288d) | 988d → 782d | 82% → 100% | 135d → none |  |
| 3690 | **Readiness Assessments - Tier 1 Milestones** |  | 2027-06-17 → 2026-09-02 A (-288d) | 512d → 305d | 0% → 100% | 135d → none |  |

## Version 36 (data date 2026-10-07, saved 2026-10-07, file MHHS-DEL1139 - MHHS Plan v6.60.mpp)

Last finish stays 2027-12-23. Complete tasks 2828 → 2846.

Added:

| ID | Task | Duration | Start | Finish | Predecessors | Constraint |
| --- | --- | --- | --- | --- | --- | --- |
| 3364 | **Complex Sites Migration** | 67d | 2026-11-02 A | 2027-02-02 |  |  |
| 3365 | Complex Sites - Phase 1 | 10d | 2026-11-02 A | 2026-11-13 |  |  |
| 3366 | Complex Sites - Phase 2 | 29d | 2026-11-16 A | 2026-12-24 |  | finish no earlier than 2026-12-24 |
| 3367 | Complex Sites - Phase 3 | 22d | 2027-01-04 A | 2027-02-02 |  | finish no earlier than 2027-02-02 |
| 3598 | Transition Design states that RF to 4 months to take effect from 1 April 2027 onwards | 1d? | 2027-04-01 | 2027-04-01 | 3601 | start no earlier than 2027-04-01 |
| 3604 | Transition Design states that SF from 15WD to 7WD to take effect from 2 July 2027 onwards | 1d? | 2027-07-02 | 2027-07-02 | 3607 | start no earlier than 2027-07-02 |

Changed:

| ID | Task | Start | Finish | Duration | Complete | Total float | Other |
| --- | --- | --- | --- | --- | --- | --- | --- |
| 1 | **PROGRAMME PLAN.** |  |  |  | 96% → 97% |  |  |
| 4 | **Programme Management** |  |  |  | 93% → 94% |  |  |
| 5 | Sprint-based prioritisation planning and execution |  |  |  | 93% → 94% |  |  |
| 6 | Programme governance secretariat |  |  |  | 93% → 94% |  |  |
| 7 | RAID management and reporting |  |  |  | 93% → 94% |  |  |
| 8 | Tracking against Programme outcomes and KPIs |  |  |  | 93% → 94% |  |  |
| 9 | Change control and reporting |  |  |  | 93% → 94% |  |  |
| 10 | Ongoing identification of lessons learned relating to the PMO and implementation of improvements |  |  |  | 93% → 94% |  |  |
| 11 | **Programme Internal Assurance Reviews** |  |  |  | 93% → 94% |  |  |
| 12 | Programme Internal Assurance Reviews |  |  |  | 93% → 94% |  |  |
| 14 | Ongoing PP liaison activities |  |  |  | 93% → 94% |  |  |
| 15 | Milestone and Control Point objective setting |  |  |  | 93% → 94% |  |  |
| 16 | Reporting |  |  |  | 93% → 94% |  |  |
| 17 | **PP Engagement Events** |  |  |  | 93% → 94% |  |  |
| 18 | Bilateral meetings |  |  |  | 93% → 94% |  |  |
| 19 | Monthly webinars |  |  |  | 93% → 94% |  |  |
| 20 | Open days |  |  |  | 93% → 94% |  |  |
| 24 | **Code Change Support / Other Programme Alignment** |  |  |  | 93% → 94% |  |  |
| 25 | Support DCC/BEIS on SEC change |  |  |  | 93% → 94% |  |  |
| 26 | Support on Smart Meters Act changes |  |  |  | 93% → 94% |  |  |
| 27 | Support DCC/RECCo on CSS change |  |  |  | 93% → 94% |  |  |
| 28 | Support Elexon on BSC change |  |  |  | 93% → 94% |  |  |
| 29 | Support code change inside & outside CCIAG |  |  |  | 93% → 94% |  |  |
| 30 | Support code change inside & outside CCAG |  |  |  | 93% → 94% |  |  |
| 46 | **Design Baseline & Enduring PP Support** |  |  |  | 96% → 97% |  |  |
| 56 | **Establish Design Change Management Processes** |  |  |  | 92% → 93% |  |  |
| 61 | Maintain E2E MHHS Design (post-M5 design change management processes operational) |  |  |  | 92% → 93% |  |  |
| 2751 | Completion of Code Bodies review of Final QAD |  | 2026-08-21 A |  | 98% → 100% | 0.98d → none |  |
| 2752 | QAD Sign Off deadline |  | 2026-08-28 A |  | 98% → 100% | 235d → none |  |
| 2795 | PAB2026/17 | 2026-09-24 A | 2026-09-24 A |  | 0% → 100% | 325d → none |  |
| 2953 | **Regulatory Governance** |  |  |  | 96% → 99% |  |  |
| 2962 | **CR067** | 2026-09-28 A |  |  | 0% → 69% |  |  |
| 2963 | CR067 Webinar | 2026-09-28 A | 2026-09-28 A |  | 0% → 100% | 323d → none |  |
| 2964 | CR067 Impact Assessment Window | 2026-09-28 A |  |  | 0% → 80% |  |  |
| 3180 | **Preparation for Cutover to Live** |  |  |  | 80% → 77% |  |  |
| 3272 | **Migration Sprints** |  |  |  | 58% → 54% |  |  |
| 3314 | **Migration Sprint 4** |  |  |  | 68% → 85% |  |  |
| 3321 | Sprint Execution |  | 2026-10-06 A |  | 80% → 100% | 307d → none |  |
| 3322 | Sprint Execution End | 2026-10-06 A | 2026-10-06 A |  | 0% → 100% | 307d → none |  |
| 3323 | Sprint 4 Retro | 2026-10-07 A |  |  | 0% → 10% |  |  |
| 3328 | Baseline Schedule Publication | 2026-09-30 A | 2026-09-30 A |  | 0% → 100% | 267d → none |  |
| 3329 | Migration Sprint 5 Schedule Baselined | 2026-09-30 A | 2026-09-30 A |  | 0% → 100% | 267d → none |  |
| 3330 | Sprint Execution Start | 2026-10-07 A | 2026-10-07 A |  | 0% → 100% | 267d → none |  |
| 3360 | Sprint Execution Start |  |  |  |  |  | constraint none → start no earlier than 2027-03-29 |
| 3391 | **Service Management** |  |  |  | 98% → 99% |  |  |
| 3443 | **Migration Pathway 6 (MP6)** |  |  |  | 84% → 97% |  |  |
| 3515 | **Migration Pathway 12a (MP12a)** |  | 2026-10-06 A |  | 22% → 100% | 318d → none |  |
| 3516 | **MP12a - Service Activation Implementation** |  | 2026-10-06 A |  | 22% → 100% | 318d → none |  |
| 3519 | PP Qualified by Code Bodies | 2026-09-24 A | 2026-09-24 A |  | 0% → 100% | 319d → none |  |
| 3520 | DIP Promoted to Production | 2026-09-25 A | 2026-10-01 A |  | 0% → 100% | 320d → none |  |
| 3521 | Create M16 in Customer Solution | 2026-09-25 A | 2026-09-25 A |  | 0% → 100% | 319d → none |  |
| 3522 | ISD Publish | 2026-09-28 A | 2026-09-28 A |  | 0% → 100% | 318d → none |  |
| 3523 | ISD Go-Live | 2026-10-05 A | 2026-10-05 A |  | 0% → 100% | 318d → none |  |
| 3524 | MP12a - Service Activation Implementation Complete (M) | 2026-10-06 A | 2026-10-06 A |  | 0% → 100% | 318d → none |  |
| 3525 | **Migration Pathway 12b (MP12b)** |  |  |  | 44% → 81% |  |  |
| 3526 | **MP12b - Service Activation Implementation** |  |  |  | 50% → 93% |  |  |
| 3530 | PP Qualified by Code Bodies | 2026-09-24 A | 2026-09-24 A |  | 0% → 100% | 319d → none |  |
| 3531 | DIP Promoted to Production | 2026-09-25 A | 2026-10-01 A |  | 0% → 100% | 320d → none |  |
| 3532 | Create M16 in Customer Solution | 2026-09-25 A | 2026-09-25 A |  | 0% → 100% | 319d → none |  |
| 3584 | STEG May - M16 Checkpoint 2 | 2027-05-17 → 2027-05-12 (-5d) | 2027-05-17 → 2027-05-12 (-5d) |  |  | 159d → 162d | constraint start no earlier than 2027-05-17 → start no earlier than 2027-05-12 |
| 3585 | **M16: Decision Points** |  |  |  | 99% → 50% |  |  |
| 3590 | **Decision 1 RF Change to 7 months from Settlement Day 01/10** | 2026-09-01 → 2026-08-14 A (-18d) | 2026-09-18 → 2026-09-15 A (-3d) | 14d → 23d |  |  | baseline start 2026-09-01 → 2026-08-14; baseline finish 2026-09-18 → 2026-09-15 |
| 3597 | **Decision 2 RF Change to 4 months from Settlement Date 01/04** | 2027-03-15 → 2027-03-10 (-5d) | 2027-03-19 → 2027-03-23 (+4d) | 5d → 10d? |  |  | baseline start 2027-03-15 → 2027-03-10; baseline finish 2027-03-19 → 2027-03-23 |
| 3603 | **Decision 3 SF Change from 15WD to 7WD from Settlement Date 02/07** |  |  | 10d → 10d? |  |  |  |

## Version 37 (data date 2026-10-21, saved 2026-10-21, file MHHS-DEL1139 - MHHS Plan v6.61.mpp)

Last finish stays 2027-12-23. Complete tasks 2846 → 2853.

Removed: 2756 All suppliers must be able to access MPANs under the new TOM (M14*) - Late Exit; 3389 Full transition complete (M15*) - Late Exit; 3626 Cut over to new settlement timetable (M16*) - Late Exit

Changed:

| ID | Task | Start | Finish | Duration | Complete | Total float |
| --- | --- | --- | --- | --- | --- | --- |
| 3 | **PROGRAMME MANAGEMENT** |  |  |  | 94% → 95% |  |
| 4 | **Programme Management** |  |  |  | 94% → 95% |  |
| 5 | Sprint-based prioritisation planning and execution |  |  |  | 94% → 95% |  |
| 6 | Programme governance secretariat |  |  |  | 94% → 95% |  |
| 7 | RAID management and reporting |  |  |  | 94% → 95% |  |
| 8 | Tracking against Programme outcomes and KPIs |  |  |  | 94% → 95% |  |
| 9 | Change control and reporting |  |  |  | 94% → 95% |  |
| 10 | Ongoing identification of lessons learned relating to the PMO and implementation of improvements |  |  |  | 94% → 95% |  |
| 11 | **Programme Internal Assurance Reviews** |  |  |  | 94% → 95% |  |
| 12 | Programme Internal Assurance Reviews |  |  |  | 94% → 95% |  |
| 13 | **Engagement with PPs** |  |  |  | 94% → 95% |  |
| 14 | Ongoing PP liaison activities |  |  |  | 94% → 95% |  |
| 15 | Milestone and Control Point objective setting |  |  |  | 94% → 95% |  |
| 16 | Reporting |  |  |  | 94% → 95% |  |
| 17 | **PP Engagement Events** |  |  |  | 94% → 95% |  |
| 18 | Bilateral meetings |  |  |  | 94% → 95% |  |
| 19 | Monthly webinars |  |  |  | 94% → 95% |  |
| 20 | Open days |  |  |  | 94% → 95% |  |
| 21 | **PP Communications** |  |  |  | 94% → 95% |  |
| 22 | The Clock updates (weekly) |  |  |  | 94% → 95% |  |
| 23 | Maintain and update content on public-facing Portal (and ongoing feedback reviews to identify and implement Portal improvements) |  |  |  | 94% → 95% |  |
| 24 | **Code Change Support / Other Programme Alignment** |  |  |  | 94% → 95% |  |
| 25 | Support DCC/BEIS on SEC change |  |  |  | 94% → 95% |  |
| 26 | Support on Smart Meters Act changes |  |  |  | 94% → 95% |  |
| 27 | Support DCC/RECCo on CSS change |  |  |  | 94% → 95% |  |
| 28 | Support Elexon on BSC change |  |  |  | 94% → 95% |  |
| 29 | Support code change inside & outside CCIAG |  |  |  | 94% → 95% |  |
| 30 | Support code change inside & outside CCAG |  |  |  | 94% → 95% |  |
| 56 | **Establish Design Change Management Processes** |  |  |  | 93% → 94% |  |
| 61 | Maintain E2E MHHS Design (post-M5 design change management processes operational) |  |  |  | 93% → 94% |  |
| 2316 | **S & A QUALIFICATION** |  | 2027-01-28 → 2026-12-09 (-50d) | 843d? → 807d? |  | 235d → 271d |
| 2428 | **MHHS Qualification - Qualification Waves** |  | 2027-01-28 → 2026-12-09 (-50d) | 814d? → 778d? |  | 235d → 271d |
| 2723 | **Qualification Wave 4** |  | 2027-01-28 → 2026-12-09 (-50d) | 526d → 490d |  | 235d → 271d |
| 2746 | **Qualification Wave 4 Exit** |  | 2026-09-24 A |  | 99% → 100% | 235d → none |
| 2753 | Qualification Wave 4 Participants Qualification approved by BSC PAB and REC Manager | 2026-09-24 A | 2026-09-24 A |  | 0% → 100% | 235d → none |
| 2754 | **Qualification Tier 1 Milestone** |  | 2027-01-28 → 2026-10-28 (-92d) | 66d → 0d |  | 235d → 301d |
| 2795 | PAB2026/18 | 2026-10-14 A | 2026-10-14 A |  | 0% → 100% | 311d → none |
| 2951 | **MIGRATION** |  | 2027-08-09 → 2027-05-20 (-81d) | 1246d? → 1189d? |  | 98d → 155d |
| 2961 | **CR067** |  |  |  | 69% → 85% |  |
| 2963 | CR067 Impact Assessment Window |  | 2026-10-09 A |  | 80% → 100% | 314d → none |
| 3179 | **Preparation for Cutover to Live** |  |  |  | 77% → 78% |  |
| 3271 | **Migration Sprints** |  |  |  | 54% → 57% |  |
| 3313 | **Migration Sprint 4** |  | 2026-10-20 A |  | 85% → 100% | 307d → none |
| 3322 | Sprint 4 Retro |  | 2026-10-20 A |  | 10% → 100% | 307d → none |
| 3323 | **Migration Sprint 5** |  |  |  | 11% → 29% |  |
| 3330 | Sprint Execution | 2026-10-08 A |  |  | 0% → 26% |  |
| 3380 | **Migration - Tier 1 Milestones** |  | 2027-08-09 → 2027-05-07 (-94d) | 490d → 424d |  | 98d → 0d |
| 3441 | **Migration Pathway 6 (MP6)** |  |  |  | 97% → 99% |  |
| 3523 | **Migration Pathway 12b (MP12b)** |  |  |  | 81% → 99% |  |
| 3524 | **MP12b - Service Activation Implementation** |  |  |  | 93% → 99% |  |
| 3531 | MDD & ISD Publish | 2026-10-19 A | 2026-10-19 A |  | 0% → 100% | 303d → none |
| 3534 | **MP12b - Service Activation Implementation MDD** | 2026-10-15 A | 2026-10-16 A |  | 0% → 100% |  |
| 3535 | MDD Final Circular Completed | 2026-10-16 A | 2026-10-16 A |  | 0% → 100% | 310d → none |
| 3536 | MDD Manual Update | 2026-10-15 A | 2026-10-16 A |  | 0% → 100% | 309d → none |
